# IC consolidation

Schedule from MS Project, 2013-02-11 to 2014-11-20.

## Calendars

- Standard: Mon-Fri 08:00-12:00, 13:00-17:00; Sat-Sun off. Exceptions (off unless hours are given): 2013-03-29 (2013 Good Friday), 2013-04-01 (2013 Easter Monday), 2013-05-01 (2013 1st May), 2013-05-09 (2013 Ascension day), 2013-05-20 (2013 Whit Monday), 2013-09-05 (2013 Jeune Genevois), 2013-12-23 to 2014-01-03 (2013 Xmas Holidays), 2014-04-18 (2014 Good Friday), 2014-04-21 (2014 Easter Monday), 2014-05-01 (2014 1st May), 2014-05-29 (2014 Ascension day), 2014-06-29 (2014 Whit Monday), 2014-09-04 (2014 jeune genevois).

## Resources

| Resource |
| --- |
| Open close |
| SIT |
| BLM |
| Insulation Vacuum |
| DN200 |
| Train |
| ELQA |
| QPS |
| Sleeves cutting |
| QC Open close |
| Insulation |
| Splice de-resoldering |
| Welding QC |
| BB surfacing |
| Shunt installation |
| TIG welding |
| SIT MAGNETS |
| Protection beam |
| Protection beam line |
| Leak test |

## Schedule

| ID | WBS | Task | Type | Duration | Start | Finish | Predecessors | Total slack | Free slack | Resources | Work | Location | Text1 | fla2 |
| --- | --- | --- | --- | --- | --- | --- | --- | --- | --- | --- | --- | --- | --- | --- |
| 1 | 1 | **sector 56** |  | 417d | 2013-02-11 | 2014-10-15 |  | 0d |  |  | 6592h | arc 56 |  |  |
| 2 | 1.1 | Preliminary activities | manual | 46d | 2013-02-11 | 2013-04-17 |  |  |  |  |  |  |  |  |
| 3 | 1.2 | BLM and nQPS dismounting |  | 3d | 2013-04-18 | 2013-04-22 | 2 | 8d | 0d | BLM | 24h | arc 56 | S Grishin | BE BI |
| 4 | 1.3 | Room temperature on the arc, P atm | milestone | 0d | 2013-04-17 | 2013-04-17 | 2 | 396.5d |  |  |  | arc 56 |  |  |
| 5 | 1.4 | Aimants: nothing to replace in this arc | milestone | 0d | 2013-04-17 | 2013-04-17 | 2 | 396.5d |  | SIT |  | arc 56 | N Bourcey | TE MSC |
| 6 | 1.5 | DN 200: nothing to install on this arc | milestone | 0d | 2013-04-17 | 2013-04-17 | 2 | 396.5d |  | DN200 |  | arc 56 | A. Musso | TE MSC |
| 7 | 1.6 | Ball test |  | 3d | 2013-04-18 | 2013-04-22 | 2 | 349.5d | 49d | Insulation Vacuum | 24h | arc 56 | P Cruikshank | TE VSC |
| 8 | 1.7 | **Interconnections activities 56** |  | 130d | 2013-04-18 | 2013-10-23 |  | 8d | 0d |  | 6416h | arc 56 |  |  |
| 9 | 1.7.1 | Opening W and remove thermal insulation |  | 3w | 2013-04-18 | 2013-05-13 | 3SS+0.5d | 8d | 0d | Open close | 120h | arc 56 | A. Musso | TE MSC |
| 10 | 1.7.2 | Inspection beam line |  | 3w | 2013-04-23 | 2013-05-15 | 9SS+0.5w | 9d | 0d | QC Open close | 120h | arc 56 | R Ostojic |  |
| 11 | 1.7.3 | Protection beam line |  | 3w | 2013-04-23 | 2013-05-15 | 9SS+0.5w | 362.5d |  | Open close | 120h | arc 56 | A. Musso | TE MSC |
| 12 | 1.7.4 | **Train 56** |  | 74d | 2013-04-25 | 2013-08-12 |  | 9d |  | Train | 4632h | arc 56 | JPh Tock | TE MSC |
| 13 | 1.7.4.1 | Cutting M sleeves |  | 5w | 2013-04-25 | 2013-06-04 | 10SS+0.5w | 9d | 0d | Sleeves cutting | 200h | arc 56 | F Savary | TE MSC |
| 14 | 1.7.4.2 | Removal of IC splices electrical insulation |  | 5w | 2013-05-03 | 2013-06-11 | 13SS+1w | 9d | 0d | Insulation | 200h | arc 56 | F Savary | TE MSC |
| 15 | 1.7.4.3 | QC |  | 5w | 2013-05-08 | 2013-06-13 | 14SS+0.5w | 9.5d | 0d | QC Open close | 200h | arc 56 | R Ostojic |  |
| 16 | 1.7.4.4 | Desoldering BB (Hp:15%) |  | 5w | 2013-05-16 | 2013-06-20 | 15SS+1w | 9.5d | 0d | Splice de-resoldering | 200h | arc 56 | F Savary | TE MSC |
| 17 | 1.7.4.5 | QC |  | 5w | 2013-05-21 | 2013-06-25 | 16SS+0.5w | 9.5d | 0d | Welding QC | 200h | arc 56 | R Ostojic |  |
| 18 | 1.7.4.6 | soldering BB (Hp: 15%) |  | 5w | 2013-05-28 | 2013-07-02 | 17SS+1w | 9.5d | 0d | Splice de-resoldering | 200h | arc 56 | F Savary | TE MSC |
| 19 | 1.7.4.7 | QC |  | 5w | 2013-05-31 | 2013-07-04 | 18SS+0.5w | 9.5d | 0d | Welding QC | 200h | arc 56 | R Ostojic |  |
| 20 | 1.7.4.8 | Busbar surface machining |  | 5w | 2013-06-07 | 2013-07-11 | 19SS+1w | 9.5d | 0d | BB surfacing | 200h | arc 56 | F Savary | TE MSC |
| 21 | 1.7.4.9 | shunt splices installation |  | 5w | 2013-06-14 | 2013-07-18 | 20SS+1w | 9.5d | 0d | Shunt installation | 200h | arc 56 | F Savary | TE MSC |
| 22 | 1.7.4.10 | QC splices/shunts |  | 5w | 2013-06-18 | 2013-07-23 | 21SS+0.5w | 12d | 0d | Welding QC | 200h | arc 56 | R Ostojic |  |
| 23 | 1.7.4.11 | Mounting insulation & QC |  | 5w | 2013-06-21 | 2013-07-25 | 22SS+0.5w | 12d | 2.5d | Insulation | 200h | arc 56 | F Savary | TE MSC |
| 24 | 1.7.4.12 | Welding M sleeves |  | 5w | 2013-07-04 | 2013-08-07 | 30FF+2d | 19d | 0d | TIG welding | 200h | arc 56 | S Atieh | EN MME |
| 25 | 1.7.4.13 | Welding QC (M lines) |  | 5w | 2013-07-08 | 2013-08-12 | 24SS+0.5w | 19d | 0d | Welding QC | 200h | arc 56 |  |  |

Notes:
- 3: According to skeleton
- 4: According to skeleton
- 5: According to skeleton
- 6: According to skeleton
- 7: According to skeleton
- 8: According to skeleton

| ID | WBS | Task | Type | Duration | Start | Finish | Predecessors | Total slack | Free slack | Constraint | Resources | Work | Text1 | Location | fla2 |
| --- | --- | --- | --- | --- | --- | --- | --- | --- | --- | --- | --- | --- | --- | --- | --- |
| 26 | 1.7.4.14 | **PAQ HV and continuity test** |  | 60d | 2013-05-08 | 2013-08-01 | 14SS+0.5w | 19d | 0d |  | ELQA | 1440h | K Dahlerup | arc 56 | TE-MPE |
| 27 | 1.7.4.14.1 | Spools BB |  | 12w | 2013-05-08 | 2013-08-01 | 14SS+0.5w, 23FF+2d | 19d |  |  | ELQA | 480h | K Dahlerup | arc 56 | TE-MPE |
| 28 | 1.7.4.14.2 | 13 kA BB |  | 12w | 2013-05-08 | 2013-08-01 | 14SS+0.5w, 23FF+2d | 19d |  |  | ELQA | 480h | K Dahlerup | arc 56 | TE-MPE |
| 29 | 1.7.5 | PIMs repairing |  | 1w | 2013-07-04 | 2013-07-10 | 7, 24SS | 300.5d | 0d |  | SIT | 40h | N Bourcey | arc 56 | TE MSC |
| 30 | 1.7.6 | IC electrical non conformities (find pb, solution and HV test) |  | 12w | 2013-05-13 | 2013-08-05 | 26FF+2d | 19d | 0d |  | Splice de-resoldering | 480h | F Savary | arc 56 | TE MSC |
| 31 | 1.7.7 | VAC sectors leak test (M lines) clamps system |  | 4w | 2013-07-17 | 2013-08-14 | 30FF+0.5w, 25FF+2d | 271d | 0d |  | Insulation Vacuum | 160h | P Cruikshank | arc 56 | TE VSC |
| 32 | 1.7.8 | Vac leak test beam lines |  | 1w | 2013-07-11 | 2013-07-17 | 29 | 300.5d | 29.5d |  | Insulation Vacuum | 40h | P Cruikshank | arc 56 | TE VSC |
| 33 | 1.7.9 | IC Non Conformities on M lines (leaks, find pb, solution and new leak test)) |  | 3w | 2013-07-31 | 2013-08-21 | 31FF+1w | 271d | 0d |  | SIT | 120h | N Bourcey | arc 56 | TE MSC |
| 34 | 1.7.10 | Ball test |  | 3d | 2013-08-28 | 2013-09-02 | 33FS+1w, 32 | 271d | 0d |  | Insulation Vacuum | 24h | P Cruikshank | arc 56 | TE VSC |
| 35 | 1.7.11 | half shells installation on beam lines |  | 3w | 2013-09-02 | 2013-09-24 | 31, 32, 33, 34 | 271d |  |  | Protection beam line | 120h | C Garion | arc 56 | TE VSC |
| 36 | 1.7.12 | Closure W |  | 4w | 2013-08-27 | 2013-09-25 | 12, 294 | 8d | 0d |  | Open close | 160h | A. Musso | arc 56 | TE MSC |
| 37 | 1.7.13 | VAC Leak test |  | 7w | 2013-09-03 | 2013-10-23 | 36FF+4w | 250d |  |  | Insulation Vacuum | 280h | P Cruikshank | arc 56 | TE VSC |
| 38 | 1.8 | **BLM & nQPS** |  | 16d | 2013-10-23 | 2013-11-14 | 8 | 250d |  |  |  | 128h |  | arc 56 | BE BI |
| 39 | 1.8.1 | BLM & nQPS re-installation |  | 8d | 2013-10-23 | 2013-11-04 | 8 | 250d | 0d |  | BLM | 64h | S Grishin | arc 56 | BE BI |
| 40 | 1.8.2 | BLM sources tests (nights) |  | 3d | 2013-11-04 | 2013-11-07 | 39 | 250d | 0d |  | BLM | 24h | S Grishin | arc 56 | BE BI |
| 41 | 1.8.3 | QPS cable replacement/validation |  | 1w | 2013-11-07 | 2013-11-14 | 40 | 250d |  |  | QPS | 40h | K Dahlerup | arc 56 | TE MPE |
| 42 | 1.9 | Final Activities (untill end of powering tests) |  | 241d | 2013-10-23 | 2014-10-15 |  | 25.5d |  | finish no earlier than 2014-10-15 |  |  |  |  |  |
| 43 | 2 | **Sector 67** |  | 366d | 2013-02-15 | 2014-08-08 |  | 10.5d |  |  |  | 6592h |  | arc 67 |  |
| 44 | 2.1 | Preliminary activities |  | 55d | 2013-02-15 | 2013-05-07 |  | 10.5d | 0d | finish no earlier than 2013-05-07 |  |  |  |  |  |
| 45 | 2.2 | Room temperature on the arc, P atm | milestone | 0w | 2013-05-07 | 2013-05-07 | 44 | 383.5d |  |  |  |  |  | arc 67 |  |
| 46 | 2.3 | Aimants: nothing to replace in this arc | milestone | 0d | 2013-05-07 | 2013-05-07 | 44 | 383.5d |  |  | SIT MAGNETS |  | N Bourcey | arc 67 | TE MSC |
| 47 | 2.4 | DN 200: nothing to install on this arc | milestone | 0d | 2013-05-07 | 2013-05-07 | 44 | 383.5d |  |  | DN200 |  | A. Musso | arc 67 | TE MSC |
| 48 | 2.5 | Ball test |  | 3d | 2013-05-08 | 2013-05-13 | 44 | 336.5d | 61d |  | Insulation Vacuum | 24h | P Cruikshank | arc 67 | TE VSC |
| 49 | 2.6 | **Interconnections activities 67** |  | 137.5d | 2013-05-08 | 2013-11-20 |  | 10.5d | 0d |  |  | 6440h |  | arc 67 |  |
| 50 | 2.6.1 | BLM and nQPS dismounting |  | 3d | 2013-05-08 | 2013-05-13 | 44 | 364.5d |  |  | BLM | 24h | S Grishin | arc 67 | BE BI |
| 51 | 2.6.2 | Opening W and remove thermal insulation |  | 3w | 2013-05-13 | 2013-06-04 | 9, 44 | 8d | 0d |  | Open close | 120h | A. Musso | arc 67 | TE MSC |
| 52 | 2.6.3 | Inspection beam lines |  | 3w | 2013-05-16 | 2013-06-06 | 51SS+0.5w | 19d | 10d |  | QC Open close | 120h | R Ostojic | arc 67 |  |
| 53 | 2.6.4 | Protection beam line |  | 3w | 2013-05-16 | 2013-06-06 | 51SS+0.5w | 347.5d |  |  | Open close | 120h | A. Musso | arc 67 | TE MSC |

Notes:
- 26: Les tests ELQA se deroulent en // au train, ils sont integres au train selon le planning journalier suivant: / Train 6h00-10h00 / 11h00-15h00 / HV tests 17h00 -23h00 / Transport 23h00-6h00
- 45: According to skeleton
- 46: According to skeleton
- 47: According to skeleton
- 48: According to skeleton
- 49: According to skeleton

| ID | WBS | Task | Duration | Start | Finish | Predecessors | Total slack | Free slack | Resources | Work | Text1 | Location | fla2 |
| --- | --- | --- | --- | --- | --- | --- | --- | --- | --- | --- | --- | --- | --- |
| 54 | 2.6.5 | **Train 67** | 74d | 2013-06-04 | 2013-09-17 |  | 9d | 6d | Train | 4632h | JPh Tock | arc 67 | TE MSC |
| 55 | 2.6.5.1 | Cutting M sleeves | 5w | 2013-06-04 | 2013-07-09 | 52SS+0.5w, 13 | 9d | 0d | Sleeves cutting | 200h | F Savary | arc 67 | TE MSC |
| 56 | 2.6.5.2 | Removal of IC splices electrical insulation | 5w | 2013-06-11 | 2013-07-16 | 55SS+1w, 14 | 9d | 0d | Insulation | 200h | F Savary | arc 67 | TE MSC |
| 57 | 2.6.5.3 | QC | 5w | 2013-06-14 | 2013-07-18 | 56SS+0.5w | 9.5d | 0d | QC Open close | 200h | R Ostojic | arc 67 |  |
| 58 | 2.6.5.4 | Desoldering BB (Hp 15%) | 5w | 2013-06-21 | 2013-07-25 | 57SS+1w, 16 | 9.5d | 0d | Splice de-resoldering | 200h | F Savary | arc 67 | TE MSC |
| 59 | 2.6.5.5 | QC | 5w | 2013-06-25 | 2013-07-30 | 58SS+0.5w | 9.5d | 0d | Welding QC | 200h | R Ostojic | arc 67 |  |
| 60 | 2.6.5.6 | soldering BB (Hp 15%) | 5w | 2013-07-02 | 2013-08-06 | 59SS+1w, 18 | 9.5d | 0d | Splice de-resoldering | 200h | F Savary | arc 67 | TE MSC |
| 61 | 2.6.5.7 | QC | 5w | 2013-07-05 | 2013-08-08 | 60SS+0.5w | 9.5d | 0d | Welding QC | 200h | R Ostojic | arc 67 |  |
| 62 | 2.6.5.8 | Busbar surface machining | 5w | 2013-07-12 | 2013-08-15 | 61SS+1w, 20 | 9.5d | 0d | BB surfacing | 200h | F Savary | arc 67 | TE MSC |
| 63 | 2.6.5.9 | shunt splices installation | 5w | 2013-07-19 | 2013-08-22 | 62SS+1w, 21 | 9.5d | 0d | Shunt installation | 200h | F Savary | arc 67 | TE MSC |
| 64 | 2.6.5.10 | QC splices/shunts | 5w | 2013-07-23 | 2013-08-27 | 63SS+0.5w | 9.5d | 0d | Welding QC | 200h | R Ostojic | arc 67 |  |
| 65 | 2.6.5.11 | Mounting & QC insulation | 5w | 2013-07-30 | 2013-09-03 | 64SS+1w, 23 | 9.5d | 0d | Insulation | 200h | F Savary | arc 67 | TE MSC |
| 66 | 2.6.5.12 | **PAQ HV and continuity test** | 60d | 2013-06-14 | 2013-09-06 | 56SS+0.5w | 14d | 0d | ELQA | 1440h | K Dahlerup | arc 67 | TE-MPE |
| 67 | 2.6.5.12.1 | Spools BB | 12w | 2013-06-14 | 2013-09-06 | 56SS+0.5w, 65FF+2d | 14d |  | ELQA | 480h | K Dahlerup | arc 67 | TE-MPE |
| 68 | 2.6.5.12.2 | 13 kA BB | 12w | 2013-06-14 | 2013-09-06 | 56SS+0.5w, 65FF+2d | 14d |  | ELQA | 480h | K Dahlerup | arc 67 | TE-MPE |
| 69 | 2.6.5.13 | Welding M sleeves | 5w | 2013-08-08 | 2013-09-12 | 72FF+2d | 14d | 0d | TIG welding | 200h | S Atieh | arc 67 | EN MME |
| 70 | 2.6.5.14 | Welding QC (M lines) | 5w | 2013-08-12 | 2013-09-17 | 69SS+0.5w | 14d | 0d | Welding QC | 200h |  | arc 67 |  |
| 71 | 2.6.6 | PIMS repairing | 1w | 2013-08-08 | 2013-08-14 | 48, 69SS | 275.5d | 0d | SIT | 40h | N Bourcey | arc 67 | TE MSC |
| 72 | 2.6.7 | IC electrical non conformities (find pb, solution and HV test) | 12w | 2013-06-18 | 2013-09-10 | 66FF+2d | 14d | 0d | Splice de-resoldering | 480h | F Savary | arc 67 | TE MSC |
| 73 | 2.6.8 | VAC sectors leak test (M lines) clamps system | 4w | 2013-08-21 | 2013-09-19 | 69SS+0.5w, 70FF+2d | 246d | 0d | Insulation Vacuum | 160h | P Cruikshank | arc 67 | TE VSC |
| 74 | 2.6.9 | Vac leak test beam lines | 1w | 2013-08-15 | 2013-08-21 | 71 | 275.5d | 29.5d | Insulation Vacuum | 40h | P Cruikshank | arc 67 | TE VSC |
| 75 | 2.6.10 | IC Non Conformities on M lines (leaks, find pb, solution and new leak test) | 3w | 2013-09-04 | 2013-09-26 | 73FF+1w | 246d | 0d | SIT | 120h | N Bourcey | arc 67 | TE MSC |
| 76 | 2.6.11 | Ball test | 3d | 2013-10-03 | 2013-10-08 | 74, 75FS+1w | 246d | 0d | Insulation Vacuum | 24h | P Cruikshank | arc 67 | TE VSC |
| 77 | 2.6.12 | half shells installation on beam lines | 3w | 2013-10-08 | 2013-10-29 | 73, 74, 75, 76 | 246d |  | Protection beam line | 120h | C Garion | arc 67 | TE VSC |
| 78 | 2.6.13 | Closure W | 4w | 2013-09-25 | 2013-10-23 | 54, 36 | 8d | 0d | Open close | 160h | A. Musso | arc 67 | TE MSC |
| 79 | 2.6.14 | VAC Leak test | 7w | 2013-10-02 | 2013-11-20 | 78FF+4w | 226d | 153.5d | Insulation Vacuum | 280h | P Cruikshank | arc 67 | TE VSC |

| ID | WBS | Task | Type | Duration | Start | Finish | Predecessors | Total slack | Free slack | Constraint | Resources | Work | Location | fla2 | Text1 |
| --- | --- | --- | --- | --- | --- | --- | --- | --- | --- | --- | --- | --- | --- | --- | --- |
| 80 | 2.7 | **BLM & nQPS** |  | 16d | 2013-11-20 | 2013-12-12 | 49 | 230d |  |  |  | 128h | arc 67 | BE BI |  |
| 81 | 2.7.1 | BLM & nQPS re-installation |  | 8d | 2013-11-20 | 2013-12-02 | 49 | 230d | 0d |  | BLM | 64h | arc 67 | BE BI | S Grishin |
| 82 | 2.7.2 | BLM sources tests (nights) |  | 3d | 2013-12-02 | 2013-12-05 | 81 | 230d | 0d |  | BLM | 24h | arc 67 | BE BI | S Grishin |
| 83 | 2.7.3 | QPS cable replacement/validation |  | 1w | 2013-12-05 | 2013-12-12 | 82 | 230d |  |  | QPS | 40h | arc 67 | TE MPE | K Dahlerup |
| 84 | 2.8 | Final Activities |  | 4w | 2014-07-14 | 2014-08-08 | 79 | 72.5d |  | finish no earlier than 2014-08-08 |  |  | arc 67 |  |  |
| 85 | 3 | **sector 78** |  | 366d | 2013-02-15 | 2014-08-08 |  | 18.5d |  |  |  | 12256h | arc 78 |  |  |
| 86 | 3.1 | Preliminary activities |  | 59d | 2013-02-15 | 2013-05-14 |  | 18.5d | 0d | start no earlier than 2013-02-15 |  |  |  |  |  |
| 87 | 3.2 | Room temperature on the arc, P atm | milestone | 0d | 2013-05-14 | 2013-05-14 | 86 | 18.5d | 0d |  |  |  | arc 78 |  |  |
| 88 | 3.3 | **Aimants** |  | 214.5d | 2013-05-15 | 2014-03-27 | 87 | 97d |  |  | SIT MAGNETS | 4484h | arc 78 | TE MSC | N Bourcey |
| 89 | 3.3.1 | opening W and remove thermal insulation |  | 0.5d | 2013-05-15 | 2013-05-15 |  | 99.5d | 2.5d |  | SIT MAGNETS | 4h | arc 78 | TE MSC | N Bourcey |
| 90 | 3.3.2 | **B30R7** |  | 25d | 2013-05-21 | 2013-06-24 |  | 97d |  |  | SIT MAGNETS | 400h | arc 78 | TE MSC | N Bourcey |
| 91 | 3.3.2.1 | deconnecting |  | 6d | 2013-05-21 | 2013-05-28 | 101SS+3d, 89 | 97d | 0d |  | SIT MAGNETS | 48h | arc 78 | TE MSC | N Bourcey |
| 92 | 3.3.2.2 | IC repairing |  | 3d | 2013-05-29 | 2013-05-31 | 91 | 351.5d | 0d |  | SIT MAGNETS | 24h | arc 78 | TE MSC | N Bourcey |
| 93 | 3.3.2.3 | B30R7 disponible pour transport | milestone | 0d | 2013-05-28 | 2013-05-28 | 91 | 370.5d |  |  | SIT MAGNETS |  | arc 78 | TE MSC | N Bourcey |
| 94 | 3.3.2.4 | reconnection |  | 16d | 2013-06-03 | 2013-06-24 | 92 | 351.5d |  |  | SIT MAGNETS | 128h | arc 78 | TE MSC | N Bourcey |
| 95 | 3.3.3 | **B21L8** |  | 25d | 2013-05-24 | 2013-06-27 |  | 97d |  |  | SIT MAGNETS | 400h | arc 78 | TE MSC | N Bourcey |
| 96 | 3.3.3.1 | deconnection |  | 6d | 2013-05-24 | 2013-05-31 | 91SS+3d | 97d | 0d |  | SIT MAGNETS | 48h | arc 78 | TE MSC | N Bourcey |
| 97 | 3.3.3.2 | IC repairing |  | 3d | 2013-06-03 | 2013-06-05 | 96 | 348.5d | 0d |  | SIT MAGNETS | 24h | arc 78 | TE MSC | N Bourcey |
| 98 | 3.3.3.3 | B21L8 disponible pour transport | milestone | 0d | 2013-05-31 | 2013-05-31 | 96 | 367.5d |  |  | SIT MAGNETS |  | arc 78 | TE MSC | N Bourcey |
| 99 | 3.3.3.4 | reconnection |  | 16d | 2013-06-06 | 2013-06-27 | 97 | 348.5d |  |  | SIT MAGNETS | 128h | arc 78 | TE MSC | N Bourcey |
| 100 | 3.3.4 | **Q5L8** |  | 214.5d | 2013-05-15 | 2014-03-27 |  | 97d |  |  | SIT MAGNETS | 1964h | arc 78 | TE MSC | N Bourcey |
| 101 | 3.3.4.1 | deconnection |  | 8d | 2013-05-15 | 2013-05-27 | 86 | 97d | 0d |  | SIT MAGNETS | 64h | arc 78 | TE MSC | N Bourcey |
| 102 | 3.3.4.2 | Q5L8 disponible pour le transport | milestone | 0d | 2013-05-27 | 2013-05-27 | 101 | 371.5d |  |  | SIT MAGNETS |  | arc 78 | TE MSC | N Bourcey |
| 103 | 3.3.4.3 | IC repairing |  | 3d | 2013-05-28 | 2013-05-30 | 101 | 368.5d |  |  | SIT MAGNETS | 24h | arc 78 | TE MSC | N Bourcey |
| 104 | 3.3.4.4 | reconnection |  | 20d | 2014-02-27 | 2014-03-27 | 410 | 165d |  |  | SIT MAGNETS | 160h | arc 78 | TE MSC | N Bourcey |

Notes:
- 87: According to skeleton
- 88: According to skeleton

| ID | WBS | Task | Duration | Start | Finish | Predecessors | Total slack | Free slack | Resources | Work | Text1 | Location | fla2 |
| --- | --- | --- | --- | --- | --- | --- | --- | --- | --- | --- | --- | --- | --- |
| 105 | 3.4 | **DN 200** | 37.5d | 2013-05-15 | 2013-07-08 | 87 | 234d |  | DN200 | 1100h | A. Musso | arc 78 | TE MSC |
| 106 | 3.4.1 | Partial opening W | 10d | 2013-05-15 | 2013-05-29 |  | 234d | 0d | DN200 | 80h | A. Musso | arc 78 |  |
| 107 | 3.4.2 | 168 DN200 to install from Q8R7 | 6w | 2013-05-17 | 2013-07-01 | 106SS+0.5w | 342d | 0d | DN200 | 240h | A. Musso | arc 78 |  |
| 108 | 3.4.3 | Welding QC | 6w | 2013-05-23 | 2013-07-03 | 107SS+0.5w | 342d | 0d | Welding QC | 240h | R Ostojic | arc 78 |  |
| 109 | 3.4.4 | Weldings leak test | 6w | 2013-05-27 | 2013-07-08 | 108SS+0.5w | 342d |  | Insulation Vacuum | 240h | P Cruikshank | arc 78 |  |
| 110 | 3.5 | Ball test | 3d | 2013-05-15 | 2013-05-17 | 87 | 18.5d | 10.5d | Insulation Vacuum | 24h | P Cruikshank | arc 78 | TE VSC |
| 111 | 3.6 | **Interconnections activities 78** | 153.5d | 2013-05-15 | 2013-12-18 | 87 | 21.5d | 0d |  | 6520h |  | arc 78 |  |
| 112 | 3.6.1 | BLM & nQPS dismounting | 3d | 2013-05-15 | 2013-05-17 |  | 360.5d |  | BLM | 24h | S Grishin | arc 78 | BE BI |
| 113 | 3.6.2 | Opening W and remove thermal insulation | 3w | 2013-06-04 | 2013-06-25 | 51, 110 | 8d | 0d | Open close | 120h | A. Musso | arc 78 | TE MSC |
| 114 | 3.6.3 | Inspection beam line | 3w | 2013-06-07 | 2013-06-27 | 113SS+0.5w | 29d | 20d | QC Open close | 120h | R Ostojic | arc 78 |  |
| 115 | 3.6.4 | protection beam line | 3w | 2013-06-07 | 2013-06-27 | 113SS+0.5w | 332.5d |  | Open close | 120h | a. Musso |  |  |
| 116 | 3.6.5 | **Train 78** | 74d | 2013-07-09 | 2013-10-22 |  | 9d | 1d | Train | 4632h | JPh Tock | arc 78 | TE MSC |
| 117 | 3.6.5.1 | Cutting M sleeves | 5w | 2013-07-09 | 2013-08-13 | 55, 114SS+0.5w | 9d | 0d | Sleeves cutting | 200h | F Savary | arc 78 | TE MSC |
| 118 | 3.6.5.2 | Removal of IC splices electrical insulation | 5w | 2013-07-16 | 2013-08-20 | 117SS+1w, 56 | 9d | 0d | Insulation | 200h | F Savary | arc 78 | TE MSC |
| 119 | 3.6.5.3 | QC | 5w | 2013-07-19 | 2013-08-22 | 118SS+0.5w | 9.5d | 0d | QC Open close | 200h | R Ostojic | arc 78 |  |
| 120 | 3.6.5.4 | Desoldering BB (Hp 15%) | 5w | 2013-07-26 | 2013-08-29 | 119SS+1w, 58 | 9.5d | 0d | Splice de-resoldering | 200h | F Savary | arc 78 | TE MSC |
| 121 | 3.6.5.5 | QC | 5w | 2013-07-30 | 2013-09-03 | 120SS+0.5w | 9.5d | 0d | Welding QC | 200h | R Ostojic | arc 78 |  |
| 122 | 3.6.5.6 | soldering BB (Hp: 15%) | 5w | 2013-08-06 | 2013-09-11 | 121SS+1w, 60 | 9.5d | 0d | Splice de-resoldering | 200h | F Savary | arc 78 | TE MSC |
| 123 | 3.6.5.7 | QC | 5w | 2013-08-09 | 2013-09-13 | 122SS+0.5w | 9.5d | 0d | Welding QC | 200h | R Ostojic | arc 78 |  |
| 124 | 3.6.5.8 | Busbar surface machining | 5w | 2013-08-16 | 2013-09-20 | 123SS+1w, 62 | 9.5d | 0d | BB surfacing | 200h | F Savary | arc 78 | TE MSC |
| 125 | 3.6.5.9 | shunt splices installation | 5w | 2013-08-23 | 2013-09-27 | 124SS+1w, 63 | 9.5d | 0d | Shunt installation | 200h | F Savary | arc 78 | TE MSC |
| 126 | 3.6.5.10 | QC splices/shunts | 5w | 2013-08-27 | 2013-10-02 | 125SS+0.5w | 9.5d | 0d | Welding QC | 200h | R Ostojic | arc 78 |  |
| 127 | 3.6.5.11 | Mounting & QC insulation | 5w | 2013-09-03 | 2013-10-09 | 126SS+1w, 65 | 9.5d | 0d | Insulation | 200h | F Savary | arc 78 | TE MSC |
| 128 | 3.6.5.12 | **PAQ HV and continuity test** | 60d | 2013-07-19 | 2013-10-11 | 118SS+2.5d | 9d | 0d | ELQA | 1440h | K Dahlerup | arc 78 | TE-MPE |
| 129 | 3.6.5.12.1 | Spools BB | 12w | 2013-07-19 | 2013-10-11 | 118SS+2.5d, 127FF+2d | 9d |  | ELQA | 480h | K Dahlerup | arc 78 | TE-MPE |
| 130 | 3.6.5.12.2 | 13 kA BB | 12w | 2013-07-19 | 2013-10-11 | 118SS+2.5d, 127FF+2d | 9d |  | ELQA | 480h | K Dahlerup | arc 78 | TE-MPE |
| 131 | 3.6.5.13 | Welding M sleeves | 5w | 2013-09-13 | 2013-10-17 | 134FF+2d | 9d | 0d | TIG welding | 200h | S Atieh | arc 78 | EN MME |
| 132 | 3.6.5.14 | Welding QC (M lines) | 5w | 2013-09-17 | 2013-10-22 | 131SS+0.5w | 9d | 0d | Welding QC | 200h |  | arc 78 |  |
| 133 | 3.6.6 | PIMs repairing | 3w | 2013-09-13 | 2013-10-03 | 110, 131SS | 240.5d | 0d | SIT | 120h | N Bourcey | arc 78 | TE MSC |
| 134 | 3.6.7 | IC electrical non conformities (find pb, solution and HV test) | 12w | 2013-07-23 | 2013-10-15 | 128FF+2d | 9d | 0d | Splice de-resoldering | 480h | F Savary | arc 78 | TE MSC |
| 135 | 3.6.8 | VAC sectors leak test (M lines) clamps system | 4w | 2013-09-26 | 2013-10-24 | 131SS+0.5w, 132FF+2d | 221d | 0d | Insulation Vacuum | 160h | P Cruikshank | arc 78 | TE VSC |
| 136 | 3.6.9 | Vac leak test beam lines | 1w | 2013-10-04 | 2013-10-10 | 133 | 240.5d | 19.5d | Insulation Vacuum | 40h | P Cruikshank | arc 78 | TE VSC |
| 137 | 3.6.10 | IC Non Conformities on M lines (leaks, find pb, solution and new leak test) | 3w | 2013-10-10 | 2013-10-31 | 135FF+1w | 221d | 0d | SIT | 120h | N Bourcey | arc 78 | TE MSC |
| 138 | 3.6.11 | Ball test | 3d | 2013-11-07 | 2013-11-12 | 137FS+1w, 136 | 221d | 0d | Insulation Vacuum | 24h | P Cruikshank | arc 78 | TE VSC |
| 139 | 3.6.12 | half shells installation on beam lines | 3w | 2013-11-12 | 2013-12-03 | 135, 136, 137, 138 | 221d |  | Protection beam line | 120h | C Garion | arc 78 | TE VSC |
| 140 | 3.6.13 | Closure W | 4w | 2013-10-23 | 2013-11-20 | 116, 78 | 8d | 0d | Open close | 160h | A. Musso | arc 78 | TE MSC |
| 141 | 3.6.14 | VAC Leak test | 7w | 2013-10-30 | 2013-12-18 | 140FF+4w | 210d |  | Insulation Vacuum | 280h | P Cruikshank | arc 78 | TE VSC |

Notes:
- 105: According to skeleton
- 110: According to skeleton
- 111: According to skeleton

| ID | WBS | Task | Type | Duration | Start | Finish | Predecessors | Total slack | Free slack | Constraint | Resources | Work | Location | Text1 | fla2 |
| --- | --- | --- | --- | --- | --- | --- | --- | --- | --- | --- | --- | --- | --- | --- | --- |
| 142 | 3.7 | **BLM & nQPS** |  | 16d | 2013-12-18 | 2014-01-23 | 111 | 210d |  |  |  | 128h |  |  |  |
| 143 | 3.7.1 | BLM & nQPS re-installation |  | 8d | 2013-12-18 | 2014-01-13 | 111 | 210d | 0d |  | BLM | 64h |  |  |  |
| 144 | 3.7.2 | BLM sources tests (nights) |  | 3d | 2014-01-13 | 2014-01-16 | 143 | 210d | 0d |  | BLM | 24h |  |  |  |
| 145 | 3.7.3 | QPS cable replacement/validation |  | 1w | 2014-01-16 | 2014-01-23 | 144 | 210d |  |  | QPS | 40h |  |  |  |
| 146 | 3.8 | Final Activities |  | 151d | 2014-01-06 | 2014-08-08 |  | 72.5d |  | finish no earlier than 2014-08-08 |  |  |  |  |  |
| 147 | 4 | **Sector 81** |  | 418d | 2013-02-18 | 2014-10-23 |  |  |  |  |  | 7732h | arc 81 |  |  |
| 148 | 4.1 | Preliminary activities |  | 61d | 2013-02-19 | 2013-05-21 |  | 29.5d | 0d | finish no earlier than 2013-05-21 |  |  |  |  |  |
| 149 | 4.2 | Room temperature on the arc, P atm | milestone | 0d | 2013-05-21 | 2013-05-21 | 148 | 240d | 6d |  |  |  | arc 81 |  |  |
| 150 | 4.3 | Aimants: nothing to replace in this arc | milestone | 0d | 2013-05-21 | 2013-05-21 | 148 | 356d |  |  | SIT MAGNETS |  | arc 81 | N Bourcey | TE MSC |
| 151 | 4.4 | **DN 200** |  | 37.5d | 2013-05-30 | 2013-07-22 | 149 | 234d |  |  | DN200 | 1100h | arc 81 | A. Musso | TE MSC |
| 152 | 4.4.1 | Partial opening W |  | 10d | 2013-05-30 | 2013-06-12 | 106, 148 | 234d | 0d |  | DN200 | 80h | arc 81 | A. Musso | TE MSC |
| 153 | 4.4.2 | 168 DN200 to install |  | 6w | 2013-06-03 | 2013-07-15 | 152SS+0.5w | 312.5d | 0d |  | DN200 | 240h | arc 81 | A. Musso | TE MSC |
| 154 | 4.4.3 | Welding QC |  | 6w | 2013-06-06 | 2013-07-17 | 153SS+0.5w | 312.5d | 0d |  | Welding QC | 240h | arc 81 | R Ostojic |  |
| 155 | 4.4.4 | Weldings leak test |  | 6w | 2013-06-10 | 2013-07-22 | 154SS+0.5w | 312.5d |  |  | Insulation Vacuum | 240h | arc 81 | P Cruikshank | TE VSC |
| 156 | 4.5 | Ball test |  | 3d | 2013-05-22 | 2013-05-24 | 148 | 304d | 103d |  | Insulation Vacuum | 24h | arc 81 | P Cruikshank | TE VSC |
| 157 | 4.6 | **Interconnections activities 81** |  | 207.5d | 2013-05-22 | 2014-03-24 |  | 29.5d | 0d |  |  | 6480h | arc 81 |  |  |
| 158 | 4.6.1 | BLM dismounting |  | 3d | 2013-05-22 | 2013-05-24 | 148 | 29.5d | 21.5d |  | BLM | 24h | arc 81 | S Grishin | BE BI |
| 159 | 4.6.2 | Opening W and remove thermal insulation |  | 3w | 2013-06-25 | 2013-07-16 | 113, 158 | 8d | 0d |  | Open close | 120h | arc 81 | A. Musso | TE MSC |
| 160 | 4.6.3 | Inspection beam line |  | 3w | 2013-06-28 | 2013-07-18 | 159SS+0.5w | 42d | 30d |  | QC Open close | 120h | arc 81 | R Ostojic |  |
| 161 | 4.6.4 | Protection beam line |  | 3w | 2013-06-28 | 2013-07-18 | 159SS+0.5w | 298d |  |  | Open close | 120h |  | A. Musso | TE MSC |
| 162 | 4.6.5 | **Train 81** |  | 74d | 2013-08-13 | 2013-11-26 |  | 12d |  |  | Train | 4632h | arc 81 | JPh Tock | TE MSC |
| 163 | 4.6.5.1 | Cutting M sleeves |  | 5w | 2013-08-13 | 2013-09-18 | 160SS+0.5w, 117 | 12d | 0d |  | Sleeves cutting | 200h | arc 81 | F Savary | TE MSC |
| 164 | 4.6.5.2 | Removal of IC splices electrical insulation |  | 5w | 2013-08-20 | 2013-09-25 | 163SS+1w, 118 | 12d | 0d |  | Insulation | 200h | arc 81 | F Savary | TE MSC |
| 165 | 4.6.5.3 | QC |  | 5w | 2013-08-23 | 2013-09-27 | 164SS+0.5w | 12d | 0d |  | QC Open close | 200h | arc 81 | R Ostojic |  |
| 166 | 4.6.5.4 | Desoldering BB (Hp 15%) |  | 5w | 2013-08-30 | 2013-10-04 | 165SS+1w, 120 | 12d | 0d |  | Splice de-resoldering | 200h | arc 81 | F Savary | TE MSC |
| 167 | 4.6.5.5 | QC |  | 5w | 2013-09-03 | 2013-10-09 | 166SS+0.5w | 12d | 0d |  | Welding QC | 200h | arc 81 | R Ostojic |  |
| 168 | 4.6.5.6 | soldering BB (Hp: 15%) |  | 5w | 2013-09-11 | 2013-10-16 | 167SS+1w, 122 | 12d | 0d |  | Splice de-resoldering | 200h | arc 81 | F Savary | TE MSC |
| 169 | 4.6.5.7 | QC |  | 5w | 2013-09-16 | 2013-10-18 | 168SS+0.5w | 12d | 0d |  | Welding QC | 200h | arc 81 | R Ostojic |  |
| 170 | 4.6.5.8 | Busbar surface machining |  | 5w | 2013-09-23 | 2013-10-25 | 169SS+1w, 124 | 12d | 0d |  | BB surfacing | 200h | arc 81 | F Savary | TE MSC |
| 171 | 4.6.5.9 | shunt splices installation |  | 5w | 2013-09-30 | 2013-11-01 | 170SS+1w, 125 | 12d | 0d |  | Shunt installation | 200h | arc 81 | F Savary | TE MSC |
| 172 | 4.6.5.10 | QC splices/shunts |  | 5w | 2013-10-02 | 2013-11-06 | 171SS+0.5w | 14.5d | 0d |  | Welding QC | 200h | arc 81 | R Ostojic |  |
| 173 | 4.6.5.11 | Mounting & QC insulation |  | 5w | 2013-10-09 | 2013-11-13 | 172SS+1w, 127 | 14.5d | 0d |  | Insulation | 200h | arc 81 | F Savary | TE MSC |

Notes:
- 149: According to skeleton
- 150: According to skeleton
- 151: According to skeleton
- 156: According to skeleton
- 157: According to skeleton

| ID | WBS | Task | Type | Duration | Start | Finish | Predecessors | Total slack | Free slack | Constraint | Resources | Work | Text1 | Location | fla2 |
| --- | --- | --- | --- | --- | --- | --- | --- | --- | --- | --- | --- | --- | --- | --- | --- |
| 174 | 4.6.5.12 | **PAQ HV and continuity test** |  | 60d | 2013-08-23 | 2013-11-15 | 164SS+0.5w | 14d | 0d |  | ELQA | 1440h | K Dahlerup | arc 81 | TE-MPE |
| 175 | 4.6.5.12.1 | Spools BB |  | 12w | 2013-08-23 | 2013-11-15 | 173FF+2d | 14d |  |  | ELQA | 480h | K Dahlerup | arc 81 | TE-MPE |
| 176 | 4.6.5.12.2 | 13 kA BB |  | 12w | 2013-08-23 | 2013-11-15 | 173FF+2d | 14d |  |  | ELQA | 480h | K Dahlerup | arc 81 | TE-MPE |
| 177 | 4.6.5.13 | Welding M sleeves |  | 5w | 2013-10-18 | 2013-11-21 | 131, 180FF+2d | 14d | 0d |  | TIG welding | 200h | S Atieh | arc 81 | EN MME |
| 178 | 4.6.5.14 | Welding QC (M Lines) |  | 5w | 2013-10-22 | 2013-11-26 | 177SS+0.5w | 34d | 0d |  | Welding QC | 200h |  | arc 81 |  |
| 179 | 4.6.6 | PIMS repairing |  | 2w | 2013-10-18 | 2013-10-31 | 156, 177SS | 201d | 0d |  | SIT | 80h | N Bourcey | arc 81 | TE MSC |
| 180 | 4.6.7 | IC electrical non conformities (find pb, solution and HV test) |  | 12w | 2013-08-27 | 2013-11-19 | 174FF+2d | 14d | 0d |  | Splice de-resoldering | 480h | F Savary | arc 81 | TE MSC |
| 181 | 4.6.8 | VAC sectors leak test (M lines) clamps system |  | 4w | 2013-10-31 | 2013-11-28 | 177SS+0.5w, 178FF+2d | 176.5d | 0d |  | Insulation Vacuum | 160h | P Cruikshank | arc 81 | TE VSC |
| 182 | 4.6.9 | Vac leak test beam lines |  | 1w | 2013-11-01 | 2013-11-07 | 179 | 201d | 24.5d |  | Insulation Vacuum | 40h | P Cruikshank | arc 81 | TE VSC |
| 183 | 4.6.10 | IC Non Conformities on M lines (leaks, find pb, solution and new leak test) |  | 3w | 2013-11-14 | 2013-12-05 | 181FF+1w | 176.5d | 0d |  | SIT | 120h | N Bourcey | arc 81 | TE MSC |
| 184 | 4.6.11 | Ball test |  | 3d | 2013-12-12 | 2013-12-17 | 183FS+1w, 182 | 176.5d | 0d |  | Insulation Vacuum | 24h | P Cruikshank | arc 81 | TE VSC |
| 185 | 4.6.12 | half shells installation on beam lines |  | 3w | 2013-12-17 | 2014-01-21 | 181, 182, 183, 184 | 176.5d |  |  | Protection beam line | 120h | C Garion | arc 81 | TE VSC |
| 186 | 4.6.13 | Closure W |  | 4w | 2014-01-27 | 2014-02-24 | 162, 419 | 0d |  |  | Open close | 160h | A. Musso | arc 81 | TE MSC |
| 187 | 4.6.14 | VAC Leak test |  | 7w | 2014-02-03 | 2014-03-24 | 186FF+4w | 132.5d |  |  | Insulation Vacuum | 280h | P Cruikshank | arc 81 | TE VSC |
| 188 | 4.7 | **BLM & nQPS** |  | 16d | 2014-03-24 | 2014-04-15 | 157 | 132.5d |  |  |  | 128h |  | arc 81 | BE BI |
| 189 | 4.7.1 | BLM & nQPS re-installation |  | 8d | 2014-03-24 | 2014-04-03 |  | 132.5d | 0d |  | BLM | 64h | S Grishin | arc 81 | BE BI |
| 190 | 4.7.2 | BLM sources tests (nights) |  | 3d | 2014-04-03 | 2014-04-08 | 189 | 132.5d | 0d |  | BLM | 24h | S Grishin | arc 81 | BE BI |
| 191 | 4.7.3 | QPS cable replacement/validation |  | 1w | 2014-04-08 | 2014-04-15 | 190 | 132.5d |  |  | QPS | 40h | K Dahlerup | arc 81 | TE MPE |
| 192 | 4.8 | Final Activities |  | 385.12d | 2014-03-25 | 2014-07-31 |  | 335.38d |  | finish no earlier than 2014-07-31 |  |  |  | arc 81 |  |
| 193 | 5 | **Sector 12** |  | 377d? | 2013-02-19 | 2014-08-27 |  | 43.5d |  |  |  | 9704h |  | arc 12 |  |
| 194 | 5.1 | Preliminary activities |  | 65d | 2013-02-19 | 2013-05-27 |  | 43.5d | 0d | start no earlier than 2013-02-19 |  |  |  |  |  |
| 195 | 5.2 | Room temperature on the arc, P atm | milestone | 0d | 2013-05-27 | 2013-05-27 | 194 | 371.5d |  |  |  |  |  | arc 12 |  |
| 196 | 5.3 | DN 200: nothing to install on this arc | milestone | 0d | 2013-05-27 | 2013-05-27 | 194 | 371.5d |  |  | DN200 |  | A. Musso | arc 56 | TE MSC |
| 197 | 5.4 | **Aimants** |  | 77d | 2013-06-07 | 2013-09-24 |  | 97d |  |  | SIT MAGNETS | 3032h | N Bourcey | arc 12 | TE MSC |
| 198 | 5.4.1 | opening W and remove thermal insulation |  | 2d | 2013-06-07 | 2013-06-10 | 96SS+10d, 194 | 97d | 0d |  | SIT MAGNETS | 16h | N Bourcey | arc 12 | TE MSC |

Notes:
- 195: According to skeleton
- 196: According to skeleton
- 197: According to skeleton

| ID | WBS | Task | Type | Duration | Start | Finish | Predecessors | Total slack | Free slack | Resources | Work | Text1 | Location | fla2 |
| --- | --- | --- | --- | --- | --- | --- | --- | --- | --- | --- | --- | --- | --- | --- |
| 199 | 5.4.2 | **C15R1** |  | 25d | 2013-06-11 | 2013-07-15 |  | 97d |  | SIT MAGNETS | 400h | N Bourcey | arc 12 | TE MSC |
| 200 | 5.4.2.1 | deconnection |  | 6d | 2013-06-11 | 2013-06-18 | 198 | 97d | 0d | SIT MAGNETS | 48h | N Bourcey | arc 12 | TE MSC |
| 201 | 5.4.2.2 | C15R1 available for transport | milestone | 0d | 2013-06-18 | 2013-06-18 | 200 | 336.5d | 0d | SIT MAGNETS |  | N Bourcey | arc 12 | TE MSC |
| 202 | 5.4.2.3 | IC repairing |  | 3d | 2013-06-19 | 2013-06-21 | 201 | 336.5d | 0d | SIT MAGNETS | 24h | N Bourcey | arc 12 | TE MSC |
| 203 | 5.4.2.4 | reconnection |  | 16d | 2013-06-24 | 2013-07-15 | 202 | 336.5d |  | SIT MAGNETS | 128h | N Bourcey | arc 12 | TE MSC |
| 204 | 5.4.3 | **A22R1** |  | 25d | 2013-06-25 | 2013-07-29 |  | 97d |  | SIT MAGNETS | 400h | N Bourcey | arc 12 | TE MSC |
| 205 | 5.4.3.1 | deconnection |  | 6d | 2013-06-25 | 2013-07-02 | 200SS+10d | 97d | 0d | SIT MAGNETS | 48h | N Bourcey | arc 12 | TE MSC |
| 206 | 5.4.3.2 | A22R1 available for transport | milestone | 0d | 2013-07-02 | 2013-07-02 | 205 | 345.5d |  | SIT MAGNETS |  | N Bourcey | arc 12 | TE MSC |
| 207 | 5.4.3.3 | IC repairing |  | 3d | 2013-07-03 | 2013-07-05 | 205 | 326.5d | 0d | SIT MAGNETS | 24h | N Bourcey | arc 12 | TE MSC |
| 208 | 5.4.3.4 | reconnection |  | 16d | 2013-07-08 | 2013-07-29 | 207 | 326.5d |  | SIT MAGNETS | 128h | N Bourcey | arc 12 | TE MSC |
| 209 | 5.4.4 | **C30R1** |  | 25d | 2013-07-09 | 2013-08-12 |  | 97d |  | SIT MAGNETS | 400h | N Bourcey | arc 12 | TE MSC |
| 210 | 5.4.4.1 | deconnection |  | 6d | 2013-07-09 | 2013-07-16 | 205SS+10d | 97d | 0d | SIT MAGNETS | 48h | N Bourcey | arc 12 | TE MSC |
| 211 | 5.4.4.2 | C30R1 available for transport | milestone | 0d | 2013-07-16 | 2013-07-16 | 210 | 335.5d |  | SIT MAGNETS |  | N Bourcey | arc 12 | TE MSC |
| 212 | 5.4.4.3 | IC repairing |  | 3d | 2013-07-17 | 2013-07-19 | 210 | 316.5d | 0d | SIT MAGNETS | 24h | N Bourcey | arc 12 | TE MSC |
| 213 | 5.4.4.4 | reconnection |  | 16d | 2013-07-22 | 2013-08-12 | 212 | 316.5d |  | SIT MAGNETS | 128h | N Bourcey | arc 12 | TE MSC |
| 214 | 5.4.5 | **C33L2** |  | 25d | 2013-07-23 | 2013-08-26 |  | 97d |  | SIT MAGNETS | 400h | N Bourcey | arc 12 | TE MSC |
| 215 | 5.4.5.1 | deconnection |  | 6d | 2013-07-23 | 2013-07-30 | 210SS+10d | 97d | 0d | SIT MAGNETS | 48h | N Bourcey | arc 12 | TE MSC |
| 216 | 5.4.5.2 | C33L2 available for transport | milestone | 0d | 2013-07-30 | 2013-07-30 | 215 | 325.5d |  | SIT MAGNETS |  | N Bourcey | arc 12 | TE MSC |
| 217 | 5.4.5.3 | IC repairing |  | 3d | 2013-07-31 | 2013-08-02 | 215 | 306.5d | 0d | SIT MAGNETS | 24h | N Bourcey | arc 12 | TE MSC |
| 218 | 5.4.5.4 | reconnection |  | 16d | 2013-08-05 | 2013-08-26 | 217 | 306.5d |  | SIT MAGNETS | 128h | N Bourcey | arc 12 | TE MSC |
| 219 | 5.4.6 | **C33R1** |  | 25d | 2013-08-06 | 2013-09-10 |  | 97d |  | SIT MAGNETS | 400h | N Bourcey | arc 12 | TE MSC |
| 220 | 5.4.6.1 | deconnection |  | 6d | 2013-08-06 | 2013-08-13 | 215SS+10d | 97d | 0d | SIT MAGNETS | 48h | N Bourcey | arc 12 | TE MSC |
| 221 | 5.4.6.2 | C33R1 available for transport | milestone | 0d | 2013-08-13 | 2013-08-13 | 220 | 315.5d |  | SIT MAGNETS |  | N Bourcey | arc 12 | TE MSC |
| 222 | 5.4.6.3 | IC repairing |  | 3d | 2013-08-14 | 2013-08-16 | 220 | 296.5d | 0d | SIT MAGNETS | 24h | N Bourcey | arc 12 | TE MSC |
| 223 | 5.4.6.4 | reconnection |  | 16d | 2013-08-19 | 2013-09-10 | 222 | 296.5d |  | SIT MAGNETS | 128h | N Bourcey | arc 12 | TE MSC |

| ID | WBS | Task | Type | Duration | Start | Finish | Predecessors | Total slack | Free slack | Constraint | Resources | Work | Text1 | Location | fla2 |
| --- | --- | --- | --- | --- | --- | --- | --- | --- | --- | --- | --- | --- | --- | --- | --- |
| 224 | 5.4.7 | **A29L2** |  | 25d | 2013-08-20 | 2013-09-24 |  | 97d |  |  | SIT MAGNETS | 400h | N Bourcey | arc 12 | TE MSC |
| 225 | 5.4.7.1 | deconnection |  | 6d | 2013-08-20 | 2013-08-27 | 220SS+10d | 97d | 0d |  | SIT MAGNETS | 48h | N Bourcey | arc 12 | TE MSC |
| 226 | 5.4.7.2 | A29L2 available for transport | milestone | 0d | 2013-08-27 | 2013-08-27 | 225 | 305.5d |  |  | SIT MAGNETS |  | N Bourcey | arc 12 | TE MSC |
| 227 | 5.4.7.3 | IC repairing |  | 3d | 2013-08-28 | 2013-08-30 | 225 | 286.5d | 0d |  | SIT MAGNETS | 24h | N Bourcey | arc 12 | TE MSC |
| 228 | 5.4.7.4 | reconnection |  | 16d | 2013-09-02 | 2013-09-24 | 227 | 286.5d |  |  | SIT MAGNETS | 128h | N Bourcey | arc 12 | TE MSC |
| 229 | 5.5 | Ball test |  | 3d | 2013-05-28 | 2013-05-30 | 194 | 314.5d | 124d |  | Insulation Vacuum | 24h | P Cruikshank | arc 12 | TE VSC |
| 230 | 5.6 | **Interconnections activities 12** |  | 223.5d | 2013-05-28 | 2014-04-23 |  | 43.5d | 0d |  |  | 6520h |  | arc 12 |  |
| 231 | 5.6.1 | BLM & nQPS dismounting |  | 3d | 2013-05-28 | 2013-05-30 | 194 | 352.5d |  |  | BLM | 24h | S Grishin | arc 12 | BE BI |
| 232 | 5.6.2 | Opening W and remove thermal insulation |  | 3w | 2013-07-16 | 2013-08-06 | 159, 194 | 8d | 0d |  | Open close | 120h | A. Musso | arc 12 | TE MSC |
| 233 | 5.6.3 | Inspection beam line |  | 3w | 2013-07-19 | 2013-08-08 | 232SS+0.5w | 52d | 40d |  | QC Open close | 120h | R Ostojic | arc 12 |  |
| 234 | 5.6.4 | Protection beam line |  | 3w | 2013-07-19 | 2013-08-08 | 232SS+0.5w | 302.5d |  |  | Open close | 120h | A. Musso |  | TE MSC |
| 235 | 5.6.5 | **Train 12** |  | 74d | 2013-09-18 | 2014-01-14 |  | 12d |  |  | Train | 4632h | JPh Tock | arc 12 | TE MSC |
| 236 | 5.6.5.1 | Cutting M sleeves |  | 5w | 2013-09-18 | 2013-10-23 | 233SS+0.5w, 163 | 12d | 0d |  | Sleeves cutting | 200h | F Savary | arc 12 | TE MSC |
| 237 | 5.6.5.2 | Removal of IC splices electrical insulation |  | 5w | 2013-09-25 | 2013-10-30 | 236SS+1w, 164 | 12d | 0d |  | Insulation | 200h | F Savary | arc 12 | TE MSC |
| 238 | 5.6.5.3 | QC |  | 5w | 2013-09-30 | 2013-11-01 | 237SS+0.5w | 12d | 0d |  | QC Open close | 200h | R Ostojic | arc 12 |  |
| 239 | 5.6.5.4 | Desoldering BB (Hp: 15%) |  | 5w | 2013-10-07 | 2013-11-08 | 238SS+1w, 166 | 12d | 0d |  | Splice de-resoldering | 200h | F Savary | arc 12 | TE MSC |
| 240 | 5.6.5.5 | QC |  | 5w | 2013-10-09 | 2013-11-13 | 239SS+0.5w | 12d | 0d |  | Welding QC | 200h | R Ostojic | arc 12 |  |
| 241 | 5.6.5.6 | Soldering BB (Hp: 15%) |  | 5w | 2013-10-16 | 2013-11-20 | 240SS+1w, 168 | 12d | 0d |  | Splice de-resoldering | 200h | F Savary | arc 12 | TE MSC |
| 242 | 5.6.5.7 | QC |  | 5w | 2013-10-21 | 2013-11-22 | 241SS+0.5w | 12d | 0d |  | Welding QC | 200h | R Ostojic | arc 12 |  |
| 243 | 5.6.5.8 | Busbar surface machining |  | 5w | 2013-10-28 | 2013-11-29 | 242SS+1w, 170 | 12d | 0d |  | BB surfacing | 200h | F Savary | arc 12 | TE MSC |
| 244 | 5.6.5.9 | shunt splices installation |  | 5w | 2013-11-04 | 2013-12-06 | 243SS+1w, 171 | 12d | 0d |  | Shunt installation | 200h | F Savary | arc 12 | TE MSC |
| 245 | 5.6.5.10 | QC splices/shunts |  | 5w | 2013-11-06 | 2013-12-11 | 244SS+0.5w | 14.5d | 0d |  | Welding QC | 200h | R Ostojic | arc 12 |  |
| 246 | 5.6.5.11 | Mounting insulation &QC |  | 5w | 2013-11-13 | 2013-12-18 | 245SS+1w, 173 | 14.5d | 0.5d |  | Insulation | 200h | F Savary | arc 12 | TE MSC |
| 247 | 5.6.5.12 | **PAQ HV and continuity test** |  | 60d | 2013-09-30 | 2013-12-20 | 237SS+0.5w | 14d | 0d |  | ELQA | 1440h | K Dahlerup | arc 12 | TE-MPE |
| 248 | 5.6.5.12.1 | Spools BB |  | 12w | 2013-09-30 | 2013-12-20 | 246FF+2d | 14d |  |  | ELQA | 480h | K Dahlerup | arc 12 | TE-MPE |
| 249 | 5.6.5.12.2 | 13 kA BB |  | 12w | 2013-09-30 | 2013-12-20 | 246FF+2d | 14d |  |  | ELQA | 480h | K Dahlerup | arc 12 | TE-MPE |
| 250 | 5.6.5.13 | Welding M sleeves |  | 5w | 2013-11-22 | 2014-01-09 | 177, 253FF+2d | 14d | 0d |  | TIG welding | 200h | S Atieh | arc 12 | EN MME |
| 251 | 5.6.5.14 | Welding QC ( M lines) |  | 5w | 2013-11-26 | 2014-01-14 | 250SS+0.5w | 29d | 0d |  | Welding QC | 200h |  | arc 12 |  |
| 252 | 5.6.6 | PIMs repairing |  | 3w | 2013-11-22 | 2013-12-12 | 229, 250SS | 190.5d | 6d |  | SIT | 120h | N Bourcey | arc 12 | TE MSC |
| 253 | 5.6.7 | IC electrical non conformities (find pb, solution and HV test) |  | 12w | 2013-10-02 | 2014-01-07 | 247FF+2d | 14d | 0d |  | Splice de-resoldering | 480h | F Savary | arc 12 | TE MSC |
| 254 | 5.6.8 | VAC sectors leak test (M lines) clamps system |  | 4w | 2013-12-05 | 2014-01-16 | 250SS+0.5w, 251FF+2d | 171d | 0d |  | Insulation Vacuum | 160h | P Cruikshank | arc 12 | TE VSC |
| 255 | 5.6.9 | Vac leak test beam lines |  | 1w | 2014-01-06 | 2014-01-10 | 252 | 184.5d | 13.5d | start no earlier than 2014-01-06 | Insulation Vacuum | 40h | P Cruikshank | arc 12 | TE VSC |
| 256 | 5.6.10 | IC Non Conformities on M lines (leaks, find pb, solution and new leak test) |  | 3w | 2013-12-19 | 2014-01-23 | 254FF+1w | 171d | 0d |  | SIT | 120h | N Bourcey | arc 12 | TE MSC |
| 257 | 5.6.11 | Ball test |  | 3d | 2014-01-30 | 2014-02-04 | 256FS+1w, 255 | 171d | 0d |  | Insulation Vacuum | 24h | P Cruikshank | arc 12 | TE VSC |
| 258 | 5.6.12 | half shells installation on beam lines |  | 3w | 2014-02-04 | 2014-02-25 | 254, 255, 256, 257 | 171d |  |  | Protection beam line | 120h | C Garion | arc 12 | TE VSC |
| 259 | 5.6.13 | Closure W |  | 4w | 2014-02-24 | 2014-03-24 | 235, 186 | 0d |  |  | Open close | 160h | A. Musso | arc 12 | TE MSC |
| 260 | 5.6.14 | VAC Leak test |  | 7w | 2014-03-03 | 2014-04-23 | 259FF+4w | 132d |  |  | Insulation Vacuum | 280h | P Cruikshank | arc 12 | TE VSC |

Notes:
- 229: According to skeleton
- 230: According to skeleton

| ID | WBS | Task | Type | Duration | Start | Finish | Predecessors | Total slack | Free slack | Constraint | Resources | Work | Location | fla2 | Text1 |
| --- | --- | --- | --- | --- | --- | --- | --- | --- | --- | --- | --- | --- | --- | --- | --- |
| 261 | 5.7 | **BLM & nQPS** |  | 16d | 2014-04-23 | 2014-05-16 |  | 132d |  |  |  | 128h | arc 12 | BE BI |  |
| 262 | 5.7.1 | BLM & nQPS re-installation |  | 8d | 2014-04-23 | 2014-05-06 | 230 | 132d | 0d |  | BLM | 64h | arc 12 | BE BI | S Grishin |
| 263 | 5.7.2 | BLM sources tests (nights) |  | 3d | 2014-05-06 | 2014-05-09 | 262 | 132d | 0d |  | BLM | 24h | arc 12 | BE BI | S Grishin |
| 264 | 5.7.3 | QPS cable replacement/validation |  | 1w | 2014-05-09 | 2014-05-16 | 263 | 132d |  |  | QPS | 40h | arc 12 | TE MPE | K Dahlerup |
| 265 | 5.8 | Final Activities |  | 1d? | 2014-08-27 | 2014-08-27 | 230 | 59.5d |  | finish no earlier than 2014-08-27 |  |  |  |  |  |
| 266 | 6 | **Sector 23** |  | 383d? | 2013-03-13 | 2014-09-29 |  | 37.5d |  |  |  | 9356h | arc 23 |  |  |
| 267 | 6.1 | Preliminary activities |  | 53d | 2013-03-13 | 2013-05-31 |  | 54.5d | 0d | finish no earlier than 2013-05-31 |  |  |  |  |  |
| 268 | 6.2 | Room temperature on the arc, P atm | milestone | 0d | 2013-05-31 | 2013-05-31 | 267 | 367.5d |  |  |  |  | arc 23 |  |  |
| 269 | 6.3 | **Aimants** |  | 45.5d | 2013-09-03 | 2013-11-06 |  | 97d |  |  | SIT MAGNETS | 1568h | arc 23 | TE MSC | N Bourcey |
| 270 | 6.3.1 | opening W and remove thermal insulation |  | 0.5d | 2013-09-03 | 2013-09-03 | 225SS+10d, 267 | 97d | 0d |  | SIT MAGNETS | 4h | arc 23 | TE MSC | N Bourcey |
| 271 | 6.3.2 | **B25R2** |  | 25d | 2013-09-03 | 2013-10-09 |  | 97d |  |  | SIT MAGNETS | 400h | arc 23 | TE MSC | N Bourcey |
| 272 | 6.3.2.1 | deconnection |  | 6d | 2013-09-03 | 2013-09-12 | 270 | 97d | 0d |  | SIT MAGNETS | 48h | arc 23 | TE MSC | N Bourcey |
| 273 | 6.3.2.2 | B25R2 available for transport | milestone | 0d | 2013-09-12 | 2013-09-12 | 272 | 295d |  |  | SIT MAGNETS |  | arc 23 | TE MSC | N Bourcey |
| 274 | 6.3.2.3 | IC repairing |  | 3d | 2013-09-12 | 2013-09-17 | 272 | 276d | 0d |  | SIT MAGNETS | 24h | arc 23 | TE MSC | N Bourcey |
| 275 | 6.3.2.4 | reconnection |  | 16d | 2013-09-17 | 2013-10-09 | 274 | 276d |  |  | SIT MAGNETS | 128h | arc 23 | TE MSC | N Bourcey |
| 276 | 6.3.3 | **C15L3** |  | 25d | 2013-09-18 | 2013-10-23 |  | 97d |  |  | SIT MAGNETS | 400h | arc 23 | TE MSC | N Bourcey |
| 277 | 6.3.3.1 | deconnection |  | 6d | 2013-09-18 | 2013-09-26 | 272SS+10d | 97d | 0d |  | SIT MAGNETS | 48h | arc 23 | TE MSC | N Bourcey |
| 278 | 6.3.3.2 | C15L3 available for transport | milestone | 0d | 2013-09-26 | 2013-09-26 | 277 | 285d |  |  | SIT MAGNETS |  | arc 23 | TE MSC | N Bourcey |
| 279 | 6.3.3.3 | IC repairing |  | 3d | 2013-09-26 | 2013-10-01 | 277 | 266d | 0d |  | SIT MAGNETS | 24h | arc 23 | TE MSC | N Bourcey |
| 280 | 6.3.3.4 | reconnection |  | 16d | 2013-10-01 | 2013-10-23 | 279 | 266d |  |  | SIT MAGNETS | 128h | arc 23 | TE MSC | N Bourcey |
| 281 | 6.3.4 | **A23R2** |  | 25d | 2013-10-02 | 2013-11-06 |  | 97d |  |  | SIT MAGNETS | 400h | arc 23 | TE MSC | N Bourcey |
| 282 | 6.3.4.1 | deconnection |  | 6d | 2013-10-02 | 2013-10-10 | 277SS+10d | 97d | 0d |  | SIT MAGNETS | 48h | arc 23 | TE MSC | N Bourcey |
| 283 | 6.3.4.2 | A23R2 available for transport | milestone | 0d | 2013-10-10 | 2013-10-10 | 282 | 275d |  |  | SIT MAGNETS |  | arc 23 | TE MSC | N Bourcey |
| 284 | 6.3.4.3 | IC repairing |  | 3d | 2013-10-10 | 2013-10-15 | 282 | 256d | 0d |  | SIT MAGNETS | 24h | arc 23 | TE MSC | N Bourcey |
| 285 | 6.3.4.4 | reconnection |  | 16d | 2013-10-15 | 2013-11-06 | 284 | 256d |  |  | SIT MAGNETS | 128h | arc 23 | TE MSC | N Bourcey |

Notes:
- 268: According to skeleton
- 269: According to skeleton

| ID | WBS | Task | Duration | Start | Finish | Predecessors | Total slack | Free slack | Resources | Work | Text1 | Location | fla2 |
| --- | --- | --- | --- | --- | --- | --- | --- | --- | --- | --- | --- | --- | --- |
| 286 | 6.4 | **DN 200** | 37.5d | 2013-06-13 | 2013-08-05 | 267 | 234d |  | DN200 | 1100h | A. Musso | arc 23 | TE MSC |
| 287 | 6.4.1 | Partial opening W | 10d | 2013-06-13 | 2013-06-26 | 152, 267 | 234d | 0d | DN200 | 80h | A. Musso | arc 23 | TE MSC |
| 288 | 6.4.2 | 168 DN200 to install | 6w | 2013-06-17 | 2013-07-29 | 287SS+0.5w | 322d | 0d | DN200 | 240h | A. Musso | arc 23 | TE MSC |
| 289 | 6.4.3 | Welding QC | 6w | 2013-06-20 | 2013-07-31 | 288SS+0.5w | 322d | 0d | Welding QC | 240h |  | arc 23 |  |
| 290 | 6.4.4 | Weldings leak test | 6w | 2013-06-24 | 2013-08-05 | 289SS+0.5w | 322d |  | Insulation Vacuum | 240h | P Cruikshank | arc 23 | TE VSC |
| 291 | 6.5 | Ball test | 3d | 2013-06-03 | 2013-06-05 | 267 | 310.5d | 147d | Insulation Vacuum | 24h | P Cruikshank | arc 23 | TE VSC |
| 292 | 6.6 | **Interconnections activities 23** | 239.5d | 2013-06-03 | 2014-05-22 |  | 54.5d | 0d |  | 6536h |  | arc 23 |  |
| 293 | 6.6.1 | BLM dismounting | 3d | 2013-06-03 | 2013-06-05 | 267 | 348.5d |  | BLM | 24h | S Grishin | arc 23 | BE BI |
| 294 | 6.6.2 | Opening W and remove thermal insulation | 3w | 2013-08-06 | 2013-08-27 | 267, 232 | 8d | 0d | Open close | 120h | A. Musso | arc 23 | TE MSC |
| 295 | 6.6.3 | Inspection beam lines | 3w | 2013-08-07 | 2013-08-27 | 294SS+0.5d | 64d | 52d | QC Open close | 120h | R Ostojic | arc 23 |  |
| 296 | 6.6.4 | Protection beam lines | 3w | 2013-08-07 | 2013-08-27 | 294SS+0.5d | 289.5d |  | Open close | 120h | A. Musso |  | TE MSC |
| 297 | 6.6.5 | **Train 23** | 76d | 2013-10-23 | 2014-02-20 |  | 12d |  | Train | 4648h | JPh Tock | arc 23 | TE MSC |
| 298 | 6.6.5.1 | Cutting M sleeves | 5w | 2013-10-23 | 2013-11-27 | 295SS+0.5w, 236 | 12d | 0d | Sleeves cutting | 200h | F Savary | arc 23 | TE MSC |
| 299 | 6.6.5.2 | Removal of IC splices electrical insulation | 5w | 2013-10-30 | 2013-12-04 | 298SS+1w, 237 | 12d | 0d | Insulation | 200h | F Savary | arc 23 | TE MSC |
| 300 | 6.6.5.3 | QC | 5w | 2013-11-04 | 2013-12-06 | 299SS+0.5w | 12d | 0d | QC Open close | 200h | R Ostojic | arc 23 |  |
| 301 | 6.6.5.4 | Desoldering BB (Hp: 15%) | 5w | 2013-11-11 | 2013-12-13 | 300SS+1w, 239 | 12d | 0d | Splice de-resoldering | 200h | F Savary | arc 23 | TE MSC |
| 302 | 6.6.5.5 | QC | 5w | 2013-11-13 | 2013-12-18 | 301SS+0.5w | 12d | 0d | Welding QC | 200h | R Ostojic | arc 23 |  |
| 303 | 6.6.5.6 | Soldering BB (Hp: 15%) | 5w | 2013-11-20 | 2014-01-08 | 302SS+1w, 241 | 12d | 0d | Splice de-resoldering | 200h | F Savary | arc 23 | TE MSC |
| 304 | 6.6.5.7 | QC | 5w | 2013-11-25 | 2014-01-10 | 303SS+0.5w | 12d | 0d | Welding QC | 200h | R Ostojic | arc 23 |  |
| 305 | 6.6.5.8 | Busbar surface machining | 5w | 2013-12-02 | 2014-01-17 | 304SS+1w, 243 | 12d | 0d | BB surfacing | 200h | F Savary | arc 23 | TE MSC |
| 306 | 6.6.5.9 | shunt splices installation | 5w | 2013-12-09 | 2014-01-24 | 305SS+1w, 244 | 12d | 0d | Shunt installation | 200h | F Savary | arc 23 | TE MSC |
| 307 | 6.6.5.10 | QC splices/shunts | 5w | 2013-12-16 | 2014-01-31 | 306SS+1w | 12d | 0d | Welding QC | 200h | R Ostojic | arc 23 |  |
| 308 | 6.6.5.11 | Mounting & QC insulation | 5w | 2014-01-06 | 2014-02-07 | 307SS+1w, 246 | 12d | 0d | Insulation | 200h | F Savary | arc 23 | TE MSC |
| 309 | 6.6.5.12 | **PAQ HV and continuity test** | 60d | 2013-11-06 | 2014-02-11 | 299SS+0.5w | 12d | 0d | ELQA | 1440h | K Dahlerup | arc 23 | TE-MPE |
| 310 | 6.6.5.12.1 | Spools BB | 12w | 2013-11-06 | 2014-02-11 | 308FF+2d | 12d |  | ELQA | 480h | K Dahlerup | arc 23 | TE-MPE |
| 311 | 6.6.5.12.2 | 13 kA BB | 12w | 2013-11-06 | 2014-02-11 | 308FF+2d | 12d |  | ELQA | 480h | K Dahlerup | arc 23 | TE-MPE |
| 312 | 6.6.5.13 | Welding M sleeves | 5w | 2014-01-14 | 2014-02-17 | 250, 315FF+2d | 12d | 0d | TIG welding | 200h | S Atieh | arc 23 | EN MME |
| 313 | 6.6.5.14 | Welding QC (M lines) | 5w | 2014-01-16 | 2014-02-20 | 312SS+0.5w | 22d | 0d | Welding QC | 200h |  | arc 23 |  |
| 314 | 6.6.6 | PIMS repairing | 3w | 2014-01-14 | 2014-02-03 | 291, 312SS | 163.5d | 0d | SIT | 120h | N Bourcey | arc 23 | TE MSC |
| 315 | 6.6.7 | IC electrical non conformities (find pb, solution and HV test) | 12w | 2013-11-08 | 2014-02-13 | 309FF+2d | 12d | 0d | Splice de-resoldering | 480h | F Savary | arc 23 | TE MSC |
| 316 | 6.6.8 | VAC sectors leak test (M lines) clamps system | 4w | 2014-01-27 | 2014-02-24 | 312SS+0.5w, 313FF+2d | 144d | 0d | Insulation Vacuum | 160h | P Cruikshank | arc 23 | TE VSC |
| 317 | 6.6.9 | Vac leak test beam lines | 1w | 2014-02-04 | 2014-02-10 | 314 | 163.5d | 19.5d | Insulation Vacuum | 40h | P Cruikshank | arc 23 | TE VSC |
| 318 | 6.6.10 | IC Non Conformities on M lines (leaks, find pb, solution and new leak test) | 3w | 2014-02-10 | 2014-03-03 | 316FF+1w | 144d | 0d | SIT | 120h | N Bourcey | arc 23 | TE MSC |
| 319 | 6.6.11 | Ball test | 3d | 2014-03-10 | 2014-03-13 | 318FS+1w, 317 | 144d | 0d | Insulation Vacuum | 24h | P Cruikshank | arc 23 | TE VSC |
| 320 | 6.6.12 | half shells installation on beam lines | 3w | 2014-03-13 | 2014-04-03 | 316, 317, 318, 319 | 144d |  | Protection beam line | 120h | C Garion | arc 23 | TE VSC |
| 321 | 6.6.13 | Closure W | 4w | 2014-03-24 | 2014-04-23 | 297, 259 | 0d |  | Open close | 160h | A. Musso | arc 23 | TE MSC |
| 322 | 6.6.14 | VAC Leak test | 7w | 2014-03-31 | 2014-05-22 | 321FF+4w | 112d |  | Insulation Vacuum | 280h | P Cruikshank | arc 23 | TE VSC |

Notes:
- 286: According to skeleton
- 291: According to skeleton
- 292: According to skeleton

| ID | WBS | Task | Type | Duration | Start | Finish | Predecessors | Total slack | Free slack | Constraint | Resources | Work | Location | fla2 | Text1 |
| --- | --- | --- | --- | --- | --- | --- | --- | --- | --- | --- | --- | --- | --- | --- | --- |
| 323 | 6.7 | **BLM & nQPS** |  | 16d | 2014-05-22 | 2014-06-16 |  | 112d |  |  |  | 128h | arc 23 | BE BI |  |
| 324 | 6.7.1 | BLM & nQPS re-installation |  | 8d | 2014-05-22 | 2014-06-04 | 292 | 112d | 0d |  | BLM | 64h | arc 23 | BE BI | S Grishin |
| 325 | 6.7.2 | BLM sources tests (nights) |  | 3d | 2014-06-04 | 2014-06-09 | 324 | 112d | 0d |  | BLM | 24h | arc 23 | BE BI | S Grishin |
| 326 | 6.7.3 | QPS cable replacement/validation |  | 1w | 2014-06-09 | 2014-06-16 | 325 | 112d |  |  | QPS | 40h | arc 23 | TE MPE | K Dahlerup |
| 327 | 6.8 | Final Activities |  | 1d? | 2014-09-29 | 2014-09-29 | 292 | 37.5d |  | finish no earlier than 2014-09-29 |  |  |  |  |  |
| 328 | 7 | **Sector 34** |  | 415d | 2013-02-25 | 2014-10-27 |  | 17.5d |  |  |  | 9504h | arc 34 |  |  |
| 329 | 7.1 | Preliminary activities |  | 85d | 2013-02-25 | 2013-06-28 |  | 109.5d | 0d | start no earlier than 2013-02-23 |  |  | arc 34 |  |  |
| 330 | 7.2 | Room temperature on the arc, Patm | milestone | 0d | 2013-06-28 | 2013-06-28 | 329 | 347.5d |  |  |  |  | arc 34 |  |  |
| 331 | 7.3 | DN 200: nothing to install on this arc | milestone | 0d | 2013-06-28 | 2013-06-28 | 329 | 347.5d |  |  | DN200 |  | arc 34 | TE MSC | A. Musso |
| 332 | 7.4 | **Aimants** |  | 65.5d | 2013-10-16 | 2014-01-29 |  | 97d |  |  | SIT MAGNETS | 2816h | arc 34 | TE MSC | N Bourcey |
| 333 | 7.4.1 | opening W and remove thermal insulation |  | 0.5d | 2013-10-16 | 2013-10-16 | 282SS+10d, 329 | 97d | 0d |  | SIT MAGNETS | 4h | arc 34 | TE MSC | N Bourcey |
| 334 | 7.4.2 | **Q7R3** |  | 31d | 2013-10-17 | 2013-11-28 |  | 97d |  |  | SIT MAGNETS | 496h | arc 34 | TE MSC | N Bourcey |
| 335 | 7.4.2.1 | deconnection |  | 8d | 2013-10-17 | 2013-10-28 | 333 | 97d | 0d |  | SIT MAGNETS | 64h | arc 34 | TE MSC | N Bourcey |
| 336 | 7.4.2.2 | Q7R3 available for transport | milestone | 0d | 2013-10-28 | 2013-10-28 | 335 | 262.5d |  |  | SIT MAGNETS |  | arc 34 | TE MSC | N Bourcey |
| 337 | 7.4.2.3 | IC repairing |  | 3d | 2013-10-29 | 2013-10-31 | 335 | 239.5d | 0d |  | SIT MAGNETS | 24h | arc 34 | TE MSC | N Bourcey |
| 338 | 7.4.2.4 | reconnection |  | 20d | 2013-11-01 | 2013-11-28 | 337 | 239.5d |  |  | SIT MAGNETS | 160h | arc 34 | TE MSC | N Bourcey |
| 339 | 7.4.3 | **Q23R3** |  | 31d | 2013-10-31 | 2013-12-12 |  | 97d |  |  | SIT MAGNETS | 496h | arc 34 | TE MSC | N Bourcey |
| 340 | 7.4.3.1 | deconnection |  | 8d | 2013-10-31 | 2013-11-11 | 335SS+10d | 97d | 0d |  | SIT MAGNETS | 64h | arc 34 | TE MSC | N Bourcey |
| 341 | 7.4.3.2 | Q23R3 available for transport | milestone | 0d | 2013-11-11 | 2013-11-11 | 340 | 252.5d |  |  | SIT MAGNETS |  | arc 34 | TE MSC | N Bourcey |
| 342 | 7.4.3.3 | IC repairing |  | 3d | 2013-11-12 | 2013-11-14 | 340 | 229.5d | 0d |  | SIT MAGNETS | 24h | arc 34 | TE MSC | N Bourcey |
| 343 | 7.4.3.4 | reconnection |  | 20d | 2013-11-15 | 2013-12-12 | 342 | 229.5d |  |  | SIT MAGNETS | 160h | arc 34 | TE MSC | N Bourcey |
| 344 | 7.4.4 | **A26R3** |  | 25d | 2013-11-14 | 2013-12-18 |  | 97d |  |  | SIT MAGNETS | 400h | arc 34 | TE MSC | N Bourcey |
| 345 | 7.4.4.1 | deconnection |  | 6d | 2013-11-14 | 2013-11-21 | 340SS+10d | 97d | 0d |  | SIT MAGNETS | 48h | arc 34 | TE MSC | N Bourcey |
| 346 | 7.4.4.2 | A23R3 available for transport | milestone | 0d | 2013-11-21 | 2013-11-21 | 345 | 244.5d |  |  | SIT MAGNETS |  | arc 34 | TE MSC | N Bourcey |
| 347 | 7.4.4.3 | IC repairing |  | 3d | 2013-11-22 | 2013-11-26 | 345 | 225.5d | 0d |  | SIT MAGNETS | 24h | arc 34 | TE MSC | N Bourcey |
| 348 | 7.4.4.4 | reconnection |  | 16d | 2013-11-27 | 2013-12-18 | 347 | 225.5d |  |  | SIT MAGNETS | 128h | arc 34 | TE MSC | N Bourcey |

| ID | WBS | Task | Type | Duration | Start | Finish | Predecessors | Total slack | Free slack | Resources | Work | Text1 | Location | fla2 |
| --- | --- | --- | --- | --- | --- | --- | --- | --- | --- | --- | --- | --- | --- | --- |
| 349 | 7.4.5 | **Q27R3** |  | 31d | 2013-11-28 | 2014-01-23 |  | 97d |  | SIT MAGNETS | 496h | N Bourcey | arc 34 | TE MSC |
| 350 | 7.4.5.1 | deconnection |  | 8d | 2013-11-28 | 2013-12-09 | 345SS+10d | 97d | 0d | SIT MAGNETS | 64h | N Bourcey | arc 34 | TE MSC |
| 351 | 7.4.5.2 | Q27R3 available for transport | milestone | 0d | 2013-12-09 | 2013-12-09 | 350 | 232.5d |  | SIT MAGNETS |  | N Bourcey | arc 34 | TE MSC |
| 352 | 7.4.5.3 | IC repairing |  | 3d | 2013-12-10 | 2013-12-12 | 350 | 209.5d | 0d | SIT MAGNETS | 24h | N Bourcey | arc 34 | TE MSC |
| 353 | 7.4.5.4 | reconnection |  | 20d | 2013-12-13 | 2014-01-23 | 352 | 209.5d |  | SIT MAGNETS | 160h | N Bourcey | arc 34 | TE MSC |
| 354 | 7.4.6 | **B32R3** |  | 25d | 2013-12-12 | 2014-01-29 |  | 97d |  | SIT MAGNETS | 400h | N Bourcey | arc 34 | TE MSC |
| 355 | 7.4.6.1 | deconnection |  | 6d | 2013-12-12 | 2013-12-19 | 350SS+10d | 97d | 0d | SIT MAGNETS | 48h | N Bourcey | arc 34 | TE MSC |
| 356 | 7.4.6.2 | B32R3 available for transport | milestone | 0d | 2013-12-19 | 2013-12-19 | 355 | 224.5d |  | SIT MAGNETS |  | N Bourcey | arc 34 | TE MSC |
| 357 | 7.4.6.3 | IC repairing |  | 3d | 2013-12-20 | 2014-01-07 | 355 | 205.5d | 0d | SIT MAGNETS | 24h | N Bourcey | arc 34 | TE MSC |
| 358 | 7.4.6.4 | reconnection |  | 16d | 2014-01-08 | 2014-01-29 | 357 | 205.5d |  | SIT MAGNETS | 128h | N Bourcey | arc 34 | TE MSC |
| 359 | 7.5 | Ball test |  | 3d | 2013-07-01 | 2013-07-03 | 329 | 219.5d | 152d | Insulation Vacuum | 24h | P Cruikshank | arc 34 | TE VSC |
| 360 | 7.6 | **Interconnections activities 34** |  | 239.5d | 2013-07-01 | 2014-06-20 |  | 21d | 0d |  | 6536h |  | arc 34 |  |
| 361 | 7.6.1 | BLM & nQPS dismounting |  | 3d | 2013-07-01 | 2013-07-03 | 329 | 257.5d |  | BLM | 24h | S Grishin | arc 34 | BE BI |
| 362 | 7.6.2 | Opening W and remove thermal insulation |  | 3w | 2013-11-20 | 2013-12-11 | 329, 140 | 8d | 0d | Open close | 120h | A. Musso | arc 34 | TE MSC |
| 363 | 7.6.3 | Inspection beam lines |  | 3w | 2013-11-25 | 2013-12-13 | 362SS+0.5w | 14d | 0d | QC Open close | 120h | R Ostojic | arc 34 |  |
| 364 | 7.6.4 | Protection beam lines |  | 3w | 2013-11-25 | 2013-12-13 | 362SS+0.5w | 141.5d |  | Open close | 120h | A. Musso | arc 34 | TE MSC |
| 365 | 7.6.5 | **Train 34** |  | 76d | 2013-11-27 | 2014-03-27 |  | 14d |  | Train | 4648h | JPh Tock | arc 34 | TE MSC |
| 366 | 7.6.5.1 | Cutting M sleeves |  | 5w | 2013-11-27 | 2014-01-15 | 363SS+0.5w, 298 | 14d | 0d | Sleeves cutting | 200h | F Savary | arc 34 | TE MSC |
| 367 | 7.6.5.2 | Removal of IC splices electrical insulation |  | 5w | 2013-12-04 | 2014-01-22 | 366SS+1w, 299 | 14d | 0d | Insulation | 200h | F Savary | arc 34 | TE MSC |
| 368 | 7.6.5.3 | QC |  | 5w | 2013-12-09 | 2014-01-24 | 367SS+0.5w | 14.5d | 0d | QC Open close | 200h | R Ostojic | arc 34 |  |
| 369 | 7.6.5.4 | Desoldering BB (Hp 15%) |  | 5w | 2013-12-16 | 2014-01-31 | 368SS+1w, 301 | 14.5d | 0d | Splice de-resoldering | 200h | F Savary | arc 34 | TE MSC |
| 370 | 7.6.5.5 | QC |  | 5w | 2013-12-18 | 2014-02-05 | 369SS+0.5w | 14.5d | 0d | Welding QC | 200h | R Ostojic | arc 34 |  |
| 371 | 7.6.5.6 | Soldering BB (Hp: 15%) |  | 5w | 2014-01-08 | 2014-02-12 | 370SS+1w, 303 | 14.5d | 0d | Splice de-resoldering | 200h | F Savary | arc 34 | TE MSC |
| 372 | 7.6.5.7 | QC |  | 5w | 2014-01-13 | 2014-02-14 | 371SS+0.5w | 14.5d | 0d | Welding QC | 200h | R Ostojic | arc 34 |  |
| 373 | 7.6.5.8 | Busbar surface machining |  | 5w | 2014-01-20 | 2014-02-21 | 372SS+1w, 305 | 14.5d | 0d | BB surfacing | 200h | F Savary | arc 34 | TE MSC |
| 374 | 7.6.5.9 | shunt splices installation |  | 5w | 2014-01-27 | 2014-02-28 | 373SS+1w, 306 | 14.5d | 0d | Shunt installation | 200h | F Savary | arc 34 | TE MSC |
| 375 | 7.6.5.10 | QC splices/shunts |  | 5w | 2014-01-29 | 2014-03-05 | 374SS+0.5w | 14.5d | 2.5d | Welding QC | 200h | R Ostojic | arc 34 |  |
| 376 | 7.6.5.11 | Mounting & QC insulation |  | 5w | 2014-02-10 | 2014-03-14 | 375SS+1w, 308 | 12d | 0d | Insulation | 200h | F Savary | arc 34 | TE MSC |

| ID | WBS | Task | Type | Duration | Start | Finish | Predecessors | Total slack | Free slack | Constraint | Resources | Work | Text1 | Location | fla2 |
| --- | --- | --- | --- | --- | --- | --- | --- | --- | --- | --- | --- | --- | --- | --- | --- |
| 377 | 7.6.5.12 | **PAQ HV and continuity test** |  | 60d | 2013-12-11 | 2014-03-18 | 367SS+0.5w | 12d | 0d |  | ELQA | 1440h | K Dahlerup | arc 34 | TE-MPE |
| 378 | 7.6.5.12.1 | Spools BB |  | 12w | 2013-12-11 | 2014-03-18 | 376FF+2d | 12d |  |  | ELQA | 480h | K Dahlerup | arc 34 | TE-MPE |
| 379 | 7.6.5.12.2 | 13 kA BB |  | 12w | 2013-12-11 | 2014-03-18 | 376FF+2d | 12d |  |  | ELQA | 480h | K Dahlerup | arc 34 | TE-MPE |
| 380 | 7.6.5.13 | Welding M sleeves |  | 5w | 2014-02-18 | 2014-03-24 | 312, 383FF+2d | 12d | 0d |  | TIG welding | 200h | S Atieh | arc 34 | EN MME |
| 381 | 7.6.5.14 | Welding QC (M lines) |  | 5w | 2014-02-20 | 2014-03-27 | 380SS+0.5w | 17d | 0d |  | Welding QC | 200h |  | arc 34 |  |
| 382 | 7.6.6 | PIMS repairing |  | 3w | 2014-02-18 | 2014-03-10 | 359, 380SS | 67.5d | 0d |  | SIT | 120h | N Bourcey | arc 34 | TE MSC |
| 383 | 7.6.7 | IC electrical non conformities (find pb, solution and HV test) |  | 12w | 2013-12-13 | 2014-03-20 | 377FF+2d | 12d | 0d |  | Splice de-resoldering | 480h | F Savary | arc 34 | TE MSC |
| 384 | 7.6.8 | VAC sectors leak test (M lines) clamps system |  | 4w | 2014-03-03 | 2014-03-31 | 380SS+0.5w, 381FF+2d | 48d | 0d |  | Insulation Vacuum | 160h | P Cruikshank | arc 34 | TE VSC |
| 385 | 7.6.9 | Vac leak test beam lines |  | 1w | 2014-03-11 | 2014-03-17 | 382 | 67.5d | 19.5d |  | Insulation Vacuum | 40h | P Cruikshank | arc 34 | TE VSC |
| 386 | 7.6.10 | IC Non Conformities on M lines (leaks, find pb, solution and new leak test) |  | 3w | 2014-03-17 | 2014-04-07 | 384FF+1w | 48d | 0d |  | SIT | 120h | N Bourcey | arc 34 | TE MSC |
| 387 | 7.6.11 | Ball test |  | 3d | 2014-04-14 | 2014-04-17 | 386FS+1w, 385 | 48d | 0d |  | Insulation Vacuum | 24h | P Cruikshank | arc 34 | TE VSC |
| 388 | 7.6.12 | half shells installation on beam lines |  | 3w | 2014-04-17 | 2014-05-13 | 384, 385, 386, 387 | 48d |  |  | Protection beam line | 120h | C Garion | arc 34 | TE VSC |
| 389 | 7.6.13 | Closure W |  | 4w | 2014-04-23 | 2014-05-22 | 365, 321 | 0d |  |  | Open close | 160h | A. Musso | arc 34 | TE MSC |
| 390 | 7.6.14 | VAC Leak test |  | 7w | 2014-04-30 | 2014-06-20 | 389FF+4w | 21d |  |  | Insulation Vacuum | 280h | P Cruikshank | arc 34 | TE VSC |
| 391 | 7.7 | **BLM & nQPS** |  | 16d | 2014-06-20 | 2014-07-14 |  | 92d |  |  |  | 128h |  | arc 34 | BE BI |
| 392 | 7.7.1 | BLM & nQPS re-installation |  | 8d | 2014-06-20 | 2014-07-02 | 360 | 92d | 0d |  | BLM | 64h | S Grishin | arc 34 | BE BI |
| 393 | 7.7.2 | BLM sources tests (nights) |  | 3d | 2014-07-02 | 2014-07-07 | 392 | 92d | 0d |  | BLM | 24h | S Grishin | arc 34 | BE BI |
| 394 | 7.7.3 | QPS cable replacement/validation |  | 1w | 2014-07-07 | 2014-07-14 | 393 | 92d |  |  | QPS | 40h | K Dahlerup | arc 34 | TE MPE |
| 395 | 7.8 | Final Activities |  | 87d | 2014-06-26 | 2014-10-27 | 360 | 17.5d |  | start no earlier than 2014-06-26 |  |  |  | arc 34 |  |
| 396 | 8 | **Sector 45** |  | 442.5d | 2013-02-11 | 2014-11-20 |  | 0d |  |  |  | 8516h |  | arc 45 |  |
| 397 | 8.1 | Preliminary Activities |  | 51d | 2013-02-11 | 2013-04-24 |  | 168.5d | 0d | finish no earlier than 2013-04-24 |  |  |  | arc 45 |  |
| 398 | 8.2 | Room temperature on the arc, P atm | milestone | 0d | 2013-04-24 | 2013-04-24 | 397 | 391.5d |  |  |  |  |  | arc 45 |  |
| 399 | 8.3 | **Aimants** |  | 35.5d | 2014-01-09 | 2014-02-27 |  | 97d |  |  | SIT MAGNETS | 1088h |  | arc 45 |  |
| 400 | 8.3.1 | opening W and remove thermal insulation |  | 0.5d | 2014-01-09 | 2014-01-09 | 355SS+10d, 397 | 97d | 0d |  | SIT MAGNETS | 4h | N Bourcey | arc 45 | TE MSC |

Notes:
- 399: According to skeleton

| ID | WBS | Task | Type | Duration | Start | Finish | Predecessors | Total slack | Free slack | Constraint | Resources | Work | Text1 | Location | fla2 |
| --- | --- | --- | --- | --- | --- | --- | --- | --- | --- | --- | --- | --- | --- | --- | --- |
| 401 | 8.3.2 | **C17R4** |  | 25d | 2014-01-09 | 2014-02-13 |  | 97d |  |  | SIT MAGNETS | 400h | N Bourcey | arc 45 | TE MSC |
| 402 | 8.3.2.1 | deconnection |  | 6d | 2014-01-09 | 2014-01-17 | 400 | 97d | 0d |  | SIT MAGNETS | 48h | N Bourcey | arc 45 | TE MSC |
| 403 | 8.3.2.2 | C17R4 available for transport | milestone | 0d | 2014-01-17 | 2014-01-17 | 402 | 126d |  |  | SIT MAGNETS |  | N Bourcey | arc 45 | TE MSC |
| 404 | 8.3.2.3 | IC repairing |  | 3d | 2014-01-17 | 2014-01-22 | 402 | 107d | 0d |  | SIT MAGNETS | 24h | N Bourcey | arc 45 | TE MSC |
| 405 | 8.3.2.4 | reconnection |  | 16d | 2014-01-22 | 2014-02-13 | 404 | 107d |  |  | SIT MAGNETS | 128h | N Bourcey | arc 45 | TE MSC |
| 406 | 8.3.3 | **B31R4** |  | 25d | 2014-01-23 | 2014-02-27 |  | 97d |  |  | SIT MAGNETS | 400h | N Bourcey | arc 45 | TE MSC |
| 407 | 8.3.3.1 | deconnection |  | 6d | 2014-01-23 | 2014-01-31 | 402SS+10d | 97d | 0d |  | SIT MAGNETS | 48h | N Bourcey | arc 45 | TE MSC |
| 408 | 8.3.3.2 | B31R4 available for transport | milestone | 0d | 2014-01-31 | 2014-01-31 | 407 | 116d |  |  | SIT MAGNETS |  | N Bourcey | arc 45 | TE MSC |
| 409 | 8.3.3.3 | IC repairing |  | 3d | 2014-01-31 | 2014-02-05 | 407 | 97d | 0d |  | SIT MAGNETS | 24h | N Bourcey | arc 45 | TE MSC |
| 410 | 8.3.3.4 | reconnection |  | 16d | 2014-02-05 | 2014-02-27 | 409 | 97d | 0d |  | SIT MAGNETS | 128h | N Bourcey | arc 45 | TE MSC |
| 411 | 8.4 | **DN 200** |  | 27.5d | 2013-06-27 | 2013-08-05 |  | 234d |  |  | DN200 | 740h | A. Musso | arc 45 | TE MSC |
| 412 | 8.4.1 | Partial opening W |  | 1w | 2013-06-27 | 2013-07-03 | 287, 397 | 234d | 0d |  | DN200 | 40h | A. Musso | arc 45 | TE MSC |
| 413 | 8.4.2 | 108 DN200 to install |  | 4w | 2013-07-01 | 2013-07-29 | 412SS+0.5w | 234d | 0d |  | DN200 | 160h | A. Musso | arc 45 | TE MSC |
| 414 | 8.4.3 | Welding QC |  | 4w | 2013-07-04 | 2013-07-31 | 413SS+0.5w | 234d | 0d |  | Welding QC | 160h | R Ostojic | arc 45 |  |
| 415 | 8.4.4 | Weldings leak test |  | 4w | 2013-07-08 | 2013-08-05 | 414SS+0.5w | 234d |  |  | Insulation Vacuum | 160h | P Cruikshank | arc 45 | TE VSC |
| 416 | 8.5 | Ball test |  | 3d | 2013-04-25 | 2013-04-29 | 397 | 262.5d | 221d |  | Insulation Vacuum | 24h | P Cruikshank | arc 45 | TE VSC |
| 417 | 8.6 | **Interconnections activities 45** |  | 303.5d | 2013-04-25 | 2014-07-18 |  | 0d |  |  |  | 6536h |  | arc 45 |  |
| 418 | 8.6.1 | BLM dismounting |  | 3d | 2013-04-25 | 2013-04-29 | 397 | 300.5d |  |  | BLM | 24h | S Grishin | arc 45 | BE BI |
| 419 | 8.6.2 | Opening W and remove thermal insulation |  | 3w | 2014-01-06 | 2014-01-27 | 362, 397 | 0d |  | start no earlier than 2014-01-06 | Open close | 120h | A. Musso | arc 45 | TE MSC |
| 420 | 8.6.3 | Inspection beam lines |  | 3w | 2014-01-09 | 2014-01-29 | 419SS+0.5w | 16d | 2d |  | QC Open close | 120h | R Ostojic | arc 45 |  |
| 421 | 8.6.4 | Protection beam lines |  | 3w | 2014-01-09 | 2014-01-29 | 419SS+0.5w | 117.5d |  |  | Open close | 120h | A. Musso | arc 45 | TE MSC |
| 422 | 8.6.5 | **Train 45** |  | 76d | 2014-01-15 | 2014-05-06 |  | 12d |  |  | Train | 4648h | JPh Tock | arc 45 | TE MSC |
| 423 | 8.6.5.1 | Cutting M sleeves |  | 5w | 2014-01-15 | 2014-02-19 | 420SS+0.5w, 366 | 14d | 0d |  | Sleeves cutting | 200h | F Savary | arc 45 | TE MSC |
| 424 | 8.6.5.2 | Removal of IC splices electrical insulation |  | 5w | 2014-01-22 | 2014-02-26 | 423SS+1w, 367 | 14d | 0d |  | Insulation | 200h | F Savary | arc 45 | TE MSC |
| 425 | 8.6.5.3 | QC |  | 5w | 2014-01-27 | 2014-02-28 | 424SS+0.5w | 14.5d | 0d |  | QC Open close | 200h | R Ostojic | arc 45 |  |
| 426 | 8.6.5.4 | Desoldering BB (Hp 15%) |  | 5w | 2014-02-03 | 2014-03-07 | 425SS+1w, 369 | 14.5d | 0d |  | Splice de-resoldering | 200h | F Savary | arc 45 | TE MSC |
| 427 | 8.6.5.5 | QC |  | 5w | 2014-02-05 | 2014-03-12 | 426SS+0.5w | 14.5d | 0d |  | Welding QC | 200h | R Ostojic | arc 45 |  |
| 428 | 8.6.5.6 | Soldering BB (Hp 15%) |  | 5w | 2014-02-12 | 2014-03-19 | 427SS+1w, 371 | 14.5d | 0d |  | Splice de-resoldering | 200h | F Savary | arc 45 | TE MSC |
| 429 | 8.6.5.7 | QC |  | 5w | 2014-02-17 | 2014-03-21 | 428SS+0.5w | 14.5d | 0d |  | Welding QC | 200h | R Ostojic | arc 45 |  |
| 430 | 8.6.5.8 | Busbar surface machining |  | 5w | 2014-02-24 | 2014-03-28 | 429SS+1w, 373 | 14.5d | 0d |  | BB surfacing | 200h | F Savary | arc 45 | TE MSC |
| 431 | 8.6.5.9 | shunt splices installation |  | 5w | 2014-03-03 | 2014-04-04 | 430SS+1w, 374 | 14.5d | 0d |  | Shunt installation | 200h | F Savary | arc 45 | TE MSC |
| 432 | 8.6.5.10 | QC splices/shunts |  | 5w | 2014-03-05 | 2014-04-09 | 431SS+0.5w | 14.5d | 2.5d |  | Welding QC | 200h | R Ostojic | arc 45 |  |
| 433 | 8.6.5.11 | Mounting & QC insulation |  | 5w | 2014-03-17 | 2014-04-22 | 432SS+1w, 376 | 12d | 0d |  | Insulation | 200h | F Savary | arc 45 | TE MSC |

Notes:
- 411: According to skeleton
- 416: According to skeleton
- 417: According to skeleton

| ID | WBS | Task | Duration | Start | Finish | Predecessors | Total slack | Free slack | Constraint | Resources | Work | Text1 | Location | fla2 |
| --- | --- | --- | --- | --- | --- | --- | --- | --- | --- | --- | --- | --- | --- | --- |
| 434 | 8.6.5.12 | **PAQ HV and continuity test** | 60d | 2014-01-29 | 2014-04-24 | 424SS+0.5w | 12d | 0d |  | ELQA | 1440h | K Dahlerup | arc 45 | TE-MPE |
| 435 | 8.6.5.12.1 | Spools BB | 12w | 2014-01-29 | 2014-04-24 | 433FF+2d | 12d |  |  | ELQA | 480h | K Dahlerup | arc 45 | TE-MPE |
| 436 | 8.6.5.12.2 | 13 kA BB | 12w | 2014-01-29 | 2014-04-24 | 433FF+2d | 12d |  |  | ELQA | 480h | K Dahlerup | arc 45 | TE-MPE |
| 437 | 8.6.5.13 | Welding M sleeves | 5w | 2014-03-25 | 2014-04-30 | 380, 440FF+2d | 12d | 0d |  | TIG welding | 200h | S Atieh | arc 45 | EN MME |
| 438 | 8.6.5.14 | Welding QC (M lines) | 5w | 2014-03-27 | 2014-05-06 | 437SS+0.5w | 12d | 0d |  | Welding QC | 200h |  | arc 45 |  |
| 439 | 8.6.6 | PIMS repairing | 3w | 2014-03-25 | 2014-04-14 | 416, 437SS | 41.5d | 0d |  | SIT | 120h | N Bourcey | arc 45 | TE MSC |
| 440 | 8.6.7 | IC electrical non conformities (find pb, solution and HV test) | 12w | 2014-01-31 | 2014-04-28 | 434FF+2d | 12d | 0d |  | Splice de-resoldering | 480h | F Savary | arc 45 | TE MSC |
| 441 | 8.6.8 | VAC sectors leak test (M lines) clamps system | 4w | 2014-04-07 | 2014-05-08 | 437SS+0.5w, 438FF+2d | 22d | 0d |  | Insulation Vacuum | 160h | P Cruikshank | arc 45 | TE VSC |
| 442 | 8.6.9 | Vac leak test beam lines | 1w | 2014-04-15 | 2014-04-23 | 439 | 41.5d | 19.5d |  | Insulation Vacuum | 40h | P Cruikshank | arc 45 | TE VSC |
| 443 | 8.6.10 | IC Non Conformities on M lines (leaks, find pb, solution and new leak test) | 3w | 2014-04-23 | 2014-05-15 | 441FF+1w | 22d | 0d |  | SIT | 120h | N Bourcey | arc 45 | TE MSC |
| 444 | 8.6.11 | Ball test | 3d | 2014-05-22 | 2014-05-27 | 443FS+1w, 442 | 22d | 0d |  | Insulation Vacuum | 24h | P Cruikshank | arc 45 | TE VSC |
| 445 | 8.6.12 | half shells installation on beam lines | 3w | 2014-05-27 | 2014-06-18 | 441, 442, 443, 444 | 22d |  |  | Protection beam line | 120h | C Garion | arc 45 | TE VSC |
| 446 | 8.6.13 | Closure W | 4w | 2014-05-22 | 2014-06-20 | 422, 389 | 0d |  |  | Open close | 160h | A. Musso | arc 45 | TE MSC |
| 447 | 8.6.14 | VAC Leak test | 7w | 2014-05-30 | 2014-07-18 | 446FF+4w | 0d |  |  | Insulation Vacuum | 280h | P Cruikshank | arc 45 | TE VSC |
| 448 | 8.7 | **BLM & nQPS** | 16d | 2014-07-18 | 2014-08-11 |  | 72d |  |  |  | 128h |  | arc 45 | BE BI |
| 449 | 8.7.1 | BLM & nQPS re-installation | 8d | 2014-07-18 | 2014-07-30 | 417 | 72d | 0d |  | BLM | 64h | S Grishin | arc 45 | BE BI |
| 450 | 8.7.2 | BLM sources tests (nights) | 3d | 2014-07-30 | 2014-08-04 | 449 | 72d | 0d |  | BLM | 24h | S Grishin | arc 45 | BE BI |
| 451 | 8.7.3 | QPS cable replacement/validation | 1w | 2014-08-04 | 2014-08-11 | 450 | 72d |  |  | QPS | 40h | K Dahlerup | arc 45 | TE MPE |
| 452 | 8.8 | Final Activities | 88d | 2014-07-18 | 2014-11-20 | 417, 411, 399 | 0d |  | start no earlier than 2014-07-18 |  |  |  | arc 45 |  |
