# IC consolidation

Schedule from MS Project, 2012-11-19 to 2014-11-20.

## Calendars

- Standard: Mon-Fri 08:00-12:00, 13:00-17:00; Sat-Sun off. Exceptions (off unless hours are given): 2012-12-24 to 2013-01-04 (2012 Xmas holidays), 2013-03-29 (2013 Good Friday), 2013-04-01 (2013 Easter Monday), 2013-05-01 (2013 1st May), 2013-05-09 (2013 Ascension day), 2013-05-20 (2013 Whit Monday), 2013-09-05 (2013 Jeune Genevois), 2013-12-23 to 2014-01-03 (2013 Xmas Holidays), 2014-04-18 (2014 Good Friday), 2014-04-21 (2014 Easter Monday), 2014-05-01 (2014 1st May), 2014-05-29 (2014 Ascension day), 2014-06-29 (2014 Whit Monday), 2014-09-04 (2014 jeune genevois).

## Resources

| Resource |
| --- |
| Open close |
| SIT |
| BLM |
| Insulation Vacuum |
| DN200 |
| Train |
| ELQA |
| QPS |
| Sleeves cutting |
| QC Open close |
| Insulation |
| Splice de-resoldering |
| Welding QC |
| BB surfacing |
| Shunt installation |
| TIG welding |
| SIT MAGNETS |
| Protection beam |
| Protection beam line |
| Leak test |

## Schedule

| ID | WBS | Task | Type | Duration | Start | Finish | Predecessors | Total slack | Free slack | Constraint | Resources | Work | Location | Text1 | fla2 |
| --- | --- | --- | --- | --- | --- | --- | --- | --- | --- | --- | --- | --- | --- | --- | --- |
| 1 | 1 | **sector 56** |  | 467d | 2012-11-19 | 2014-10-15 |  | 25.5d |  |  |  | 760h | arc 56 |  |  |
| 2 | 1.1 | Preliminary activities | manual | 46d | 2013-02-11 | 2013-04-17 |  |  |  |  |  |  |  |  |  |
| 3 | 1.2 | BLM and nQPS dismounting |  | 3d | 2013-04-18 | 2013-04-22 | 2 | 350d | 0d |  | BLM | 24h | arc 56 | S Grishin | BE BI |
| 4 | 1.3 | Ball test |  | 3d | 2013-04-18 | 2013-04-22 | 2 | 393.5d |  |  | Insulation Vacuum | 24h | arc 56 | P Cruikshank | TE VSC |
| 5 | 1.4 | **Interconnections activities 56** |  | 205d | 2012-11-19 | 2013-09-23 |  | 194.5d | 0d |  |  | 584h | arc 56 |  |  |
| 6 | 1.4.1 | Opening W and remove thermal insulation |  | 3w | 2013-04-18 | 2013-05-13 | 3SS+0.5d | 350d | 0d |  | Open close | 120h | arc 56 | A. Musso | TE MSC |
| 7 | 1.4.2 | Ball test |  | 3d | 2012-11-19 | 2012-11-21 |  | 473.5d |  |  | Insulation Vacuum | 24h | arc 56 | P Cruikshank | TE VSC |
| 8 | 1.4.3 | Closure W |  | 4w | 2013-07-29 | 2013-08-23 | 156 | 29.5d | 0d |  | Open close | 160h | arc 56 | A. Musso | TE MSC |
| 9 | 1.4.4 | VAC Leak test |  | 7w | 2013-08-05 | 2013-09-23 | 8FF+4w | 271.5d |  |  | Insulation Vacuum | 280h | arc 56 | P Cruikshank | TE VSC |
| 10 | 1.5 | **BLM & nQPS** |  | 16d | 2013-09-24 | 2013-10-15 | 5 | 271.5d |  |  |  | 128h | arc 56 |  | BE BI |
| 11 | 1.5.1 | BLM & nQPS re-installation |  | 8d | 2013-09-24 | 2013-10-03 | 5 | 271.5d | 0d |  | BLM | 64h | arc 56 | S Grishin | BE BI |
| 12 | 1.5.2 | BLM sources tests (nights) |  | 3d | 2013-10-04 | 2013-10-08 | 11 | 271.5d | 0d |  | BLM | 24h | arc 56 | S Grishin | BE BI |
| 13 | 1.5.3 | QPS cable replacement/validation |  | 1w | 2013-10-09 | 2013-10-15 | 12 | 271.5d |  |  | QPS | 40h | arc 56 | K Dahlerup | TE MPE |
| 14 | 1.6 | Final Activities (untill end of powering tests) |  | 241d | 2013-10-23 | 2014-10-15 |  | 25.5d |  | finish no earlier than 2014-10-15 |  |  |  |  |  |
| 15 | 2 | **Sector 67** |  | 420d | 2012-11-19 | 2014-08-08 |  | 72.5d |  |  |  | 760h | arc 67 |  |  |
| 16 | 2.1 | Preliminary activities |  | 55d | 2013-02-15 | 2013-05-07 |  | 352.5d | 0d | finish no earlier than 2013-05-07 |  |  |  |  |  |
| 17 | 2.2 | Ball test |  | 3d | 2013-05-08 | 2013-05-13 | 16 | 380.5d |  |  | Insulation Vacuum | 24h | arc 67 | P Cruikshank | TE VSC |
| 18 | 2.3 | **Interconnections activities 67** |  | 225d | 2012-11-19 | 2013-10-21 |  | 214.5d | 0d |  |  | 608h | arc 67 |  |  |
| 19 | 2.3.1 | BLM and nQPS dismounting |  | 3d | 2013-05-08 | 2013-05-13 | 16 | 364.5d |  |  | BLM | 24h | arc 67 | S Grishin | BE BI |
| 20 | 2.3.2 | Opening W and remove thermal insulation |  | 3w | 2013-05-13 | 2013-06-04 | 6, 16 | 350d |  |  | Open close | 120h | arc 67 | A. Musso | TE MSC |
| 21 | 2.3.3 | Ball test |  | 3d | 2012-11-19 | 2012-11-21 |  | 473.5d |  |  | Insulation Vacuum | 24h | arc 67 | P Cruikshank | TE VSC |
| 22 | 2.3.4 | Closure W |  | 4w | 2013-08-26 | 2013-09-23 | 8 | 29.5d | 0d |  | Open close | 160h | arc 67 | A. Musso | TE MSC |
| 23 | 2.3.5 | VAC Leak test |  | 7w | 2013-09-02 | 2013-10-21 | 22FF+4w | 247.5d | 175d |  | Insulation Vacuum | 280h | arc 67 | P Cruikshank | TE VSC |
| 24 | 2.4 | **BLM & nQPS** |  | 16d | 2013-10-22 | 2013-11-12 | 18 | 251.5d |  |  |  | 128h | arc 67 |  | BE BI |
| 25 | 2.4.1 | BLM & nQPS re-installation |  | 8d | 2013-10-22 | 2013-10-31 | 18 | 251.5d | 0d |  | BLM | 64h | arc 67 | S Grishin | BE BI |
| 26 | 2.4.2 | BLM sources tests (nights) |  | 3d | 2013-11-01 | 2013-11-05 | 25 | 251.5d | 0d |  | BLM | 24h | arc 67 | S Grishin | BE BI |
| 27 | 2.4.3 | QPS cable replacement/validation |  | 1w | 2013-11-06 | 2013-11-12 | 26 | 251.5d |  |  | QPS | 40h | arc 67 | K Dahlerup | TE MPE |
| 28 | 2.5 | Final Activities |  | 4w | 2014-07-14 | 2014-08-08 | 23 | 72.5d |  | finish no earlier than 2014-08-08 |  |  | arc 67 |  |  |

Notes:
- 3: According to skeleton
- 4: According to skeleton
- 5: According to skeleton
- 17: According to skeleton
- 18: According to skeleton

| ID | WBS | Task | Type | Duration | Start | Finish | Predecessors | Total slack | Free slack | Constraint | Resources | Work | Location | Text1 | fla2 |
| --- | --- | --- | --- | --- | --- | --- | --- | --- | --- | --- | --- | --- | --- | --- | --- |
| 29 | 3 | **sector 78** |  | 420d | 2012-11-19 | 2014-08-08 |  | 72.5d |  |  |  | 7128h | arc 78 |  |  |
| 30 | 3.1 | Preliminary activities |  | 59d | 2013-02-15 | 2013-05-14 |  | 97d | 0d | start no earlier than 2013-02-15 |  |  |  |  |  |
| 31 | 3.2 | **Aimants** |  | 327.5d | 2012-11-19 | 2014-03-27 |  | 165d |  |  | SIT MAGNETS | 5388h | arc 78 | N Bourcey | TE MSC |
| 32 | 3.2.1 | opening W and remove thermal insulation |  | 0.5d | 2012-11-19 | 2012-11-19 |  | 212.5d | 115.5d |  | SIT MAGNETS | 4h | arc 78 | N Bourcey | TE MSC |
| 33 | 3.2.2 | **B30R7** |  | 25d | 2013-05-21 | 2013-06-24 |  | 97d |  |  | SIT MAGNETS | 400h | arc 78 | N Bourcey | TE MSC |
| 34 | 3.2.2.1 | deconnecting |  | 6d | 2013-05-21 | 2013-05-28 | 44SS+3d, 32 | 97d | 0d |  | SIT MAGNETS | 48h | arc 78 | N Bourcey | TE MSC |
| 35 | 3.2.2.2 | IC repairing |  | 3d | 2013-05-29 | 2013-05-31 | 34 | 351.5d | 0d |  | SIT MAGNETS | 24h | arc 78 | N Bourcey | TE MSC |
| 36 | 3.2.2.3 | B30R7 disponible pour transport | milestone | 0d | 2013-05-28 | 2013-05-28 | 34 | 370.5d |  |  | SIT MAGNETS |  | arc 78 | N Bourcey | TE MSC |
| 37 | 3.2.2.4 | reconnection |  | 16d | 2013-06-03 | 2013-06-24 | 35 | 351.5d |  |  | SIT MAGNETS | 128h | arc 78 | N Bourcey | TE MSC |
| 38 | 3.2.3 | **B21L8** |  | 25d | 2013-05-24 | 2013-06-27 |  | 97d |  |  | SIT MAGNETS | 400h | arc 78 | N Bourcey | TE MSC |
| 39 | 3.2.3.1 | deconnection |  | 6d | 2013-05-24 | 2013-05-31 | 34SS+3d | 97d | 0d |  | SIT MAGNETS | 48h | arc 78 | N Bourcey | TE MSC |
| 40 | 3.2.3.2 | IC repairing |  | 3d | 2013-06-03 | 2013-06-05 | 39 | 348.5d | 0d |  | SIT MAGNETS | 24h | arc 78 | N Bourcey | TE MSC |
| 41 | 3.2.3.3 | B21L8 disponible pour transport | milestone | 0d | 2013-05-31 | 2013-05-31 | 39 | 367.5d |  |  | SIT MAGNETS |  | arc 78 | N Bourcey | TE MSC |
| 42 | 3.2.3.4 | reconnection |  | 16d | 2013-06-06 | 2013-06-27 | 40 | 348.5d |  |  | SIT MAGNETS | 128h | arc 78 | N Bourcey | TE MSC |
| 43 | 3.2.4 | **Q5L8** |  | 214.5d | 2013-05-15 | 2014-03-27 |  | 97d |  |  | SIT MAGNETS | 1964h | arc 78 | N Bourcey | TE MSC |
| 44 | 3.2.4.1 | deconnection |  | 8d | 2013-05-15 | 2013-05-27 | 30 | 97d | 0d |  | SIT MAGNETS | 64h | arc 78 | N Bourcey | TE MSC |
| 45 | 3.2.4.2 | Q5L8 disponible pour le transport | milestone | 0d | 2013-05-27 | 2013-05-27 | 44 | 371.5d |  |  | SIT MAGNETS |  | arc 78 | N Bourcey | TE MSC |
| 46 | 3.2.4.3 | IC repairing |  | 3d | 2013-05-28 | 2013-05-30 | 44 | 368.5d |  |  | SIT MAGNETS | 24h | arc 78 | N Bourcey | TE MSC |
| 47 | 3.2.4.4 | reconnection |  | 20d | 2014-02-27 | 2014-03-27 | 221 | 165d |  |  | SIT MAGNETS | 160h | arc 78 | N Bourcey | TE MSC |
| 48 | 3.3 | **DN 200** |  | 37.5d | 2012-11-19 | 2013-01-23 |  | 347d |  |  | DN200 | 1100h | arc 78 | A. Musso | TE MSC |
| 49 | 3.3.1 | Partial opening W |  | 10d | 2012-11-19 | 2012-11-30 |  | 347d | 0d |  | DN200 | 80h | arc 78 | A. Musso |  |
| 50 | 3.3.2 | 168 DN200 to install from Q8R7 |  | 6w | 2012-11-21 | 2013-01-16 | 49SS+0.5w | 455d | 0d |  | DN200 | 240h | arc 78 | A. Musso |  |
| 51 | 3.3.3 | Welding QC |  | 6w | 2012-11-26 | 2013-01-18 | 50SS+0.5w | 455d | 0d |  | Welding QC | 240h | arc 78 | R Ostojic |  |
| 52 | 3.3.4 | Weldings leak test |  | 6w | 2012-11-28 | 2013-01-23 | 51SS+0.5w | 455d |  |  | Insulation Vacuum | 240h | arc 78 | P Cruikshank |  |
| 53 | 3.4 | Ball test |  | 3d | 2012-11-19 | 2012-11-21 |  | 489.5d |  |  | Insulation Vacuum | 24h | arc 78 | P Cruikshank | TE VSC |

Notes:
- 31: According to skeleton
- 48: According to skeleton
- 53: According to skeleton

| ID | WBS | Task | Duration | Start | Finish | Predecessors | Total slack | Free slack | Constraint | Resources | Work | Location | Text1 | fla2 |
| --- | --- | --- | --- | --- | --- | --- | --- | --- | --- | --- | --- | --- | --- | --- |
| 54 | 3.5 | **Interconnections activities 78** | 245d | 2012-11-19 | 2013-11-18 |  | 231.5d | 0d |  |  | 488h | arc 78 |  |  |
| 55 | 3.5.1 | BLM & nQPS dismounting | 3d | 2012-11-19 | 2012-11-21 |  | 473.5d |  |  | BLM | 24h | arc 78 | S Grishin | BE BI |
| 56 | 3.5.2 | Ball test | 3d | 2012-11-19 | 2012-11-21 |  | 473.5d |  |  | Insulation Vacuum | 24h | arc 78 | P Cruikshank | TE VSC |
| 57 | 3.5.3 | Closure W | 4w | 2013-09-24 | 2013-10-21 | 22 | 29.5d | 0d |  | Open close | 160h | arc 78 | A. Musso | TE MSC |
| 58 | 3.5.4 | VAC Leak test | 7w | 2013-10-01 | 2013-11-18 | 57FF+4w | 231.5d |  |  | Insulation Vacuum | 280h | arc 78 | P Cruikshank | TE VSC |
| 59 | 3.6 | **BLM & nQPS** | 16d | 2013-11-19 | 2013-12-10 | 54 | 231.5d |  |  |  | 128h |  |  |  |
| 60 | 3.6.1 | BLM & nQPS re-installation | 8d | 2013-11-19 | 2013-11-28 | 54 | 231.5d | 0d |  | BLM | 64h |  |  |  |
| 61 | 3.6.2 | BLM sources tests (nights) | 3d | 2013-11-29 | 2013-12-03 | 60 | 231.5d | 0d |  | BLM | 24h |  |  |  |
| 62 | 3.6.3 | QPS cable replacement/validation | 1w | 2013-12-04 | 2013-12-10 | 61 | 231.5d |  |  | QPS | 40h |  |  |  |
| 63 | 3.7 | Final Activities | 151d | 2014-01-06 | 2014-08-08 |  | 72.5d |  | finish no earlier than 2014-08-08 |  |  |  |  |  |
| 64 | 4 | **Sector 81** | 418d | 2013-02-18 | 2014-10-23 |  |  |  |  |  | 1860h | arc 81 |  |  |
| 65 | 4.1 | Preliminary activities | 61d | 2013-02-19 | 2013-05-21 |  | 29.5d | 0d | finish no earlier than 2013-05-21 |  |  |  |  |  |
| 66 | 4.2 | **DN 200** | 37.5d | 2013-05-22 | 2013-07-12 |  | 240d |  |  | DN200 | 1100h | arc 81 | A. Musso | TE MSC |
| 67 | 4.2.1 | Partial opening W | 10d | 2013-05-22 | 2013-06-04 | 49, 65 | 240d | 0d |  | DN200 | 80h | arc 81 | A. Musso | TE MSC |
| 68 | 4.2.2 | 168 DN200 to install | 6w | 2013-05-24 | 2013-07-05 | 67SS+0.5w | 318.5d | 0d |  | DN200 | 240h | arc 81 | A. Musso | TE MSC |
| 69 | 4.2.3 | Welding QC | 6w | 2013-05-29 | 2013-07-09 | 68SS+0.5w | 318.5d | 0d |  | Welding QC | 240h | arc 81 | R Ostojic |  |
| 70 | 4.2.4 | Weldings leak test | 6w | 2013-05-31 | 2013-07-12 | 69SS+0.5w | 318.5d |  |  | Insulation Vacuum | 240h | arc 81 | P Cruikshank | TE VSC |
| 71 | 4.3 | Ball test | 3d | 2013-05-22 | 2013-05-24 | 65 | 353d |  |  | Insulation Vacuum | 24h | arc 81 | P Cruikshank | TE VSC |
| 72 | 4.4 | **Interconnections activities 81** | 269.5d | 2013-02-18 | 2014-03-24 |  | 91.5d | 0d |  |  | 608h | arc 81 |  |  |
| 73 | 4.4.1 | BLM dismounting | 3d | 2013-05-22 | 2013-05-24 | 65 | 29.5d | 0d |  | BLM | 24h | arc 81 | S Grishin | BE BI |
| 74 | 4.4.2 | Opening W and remove thermal insulation | 3w | 2013-05-27 | 2013-06-14 | 73 | 29.5d | 0d |  | Open close | 120h | arc 81 | A. Musso | TE MSC |
| 75 | 4.4.3 | Ball test | 3d | 2013-02-18 | 2013-02-20 |  | 399d |  |  | Insulation Vacuum | 24h | arc 81 | P Cruikshank | TE VSC |
| 76 | 4.4.4 | Closure W | 4w | 2014-01-27 | 2014-02-24 | 230 | 0d |  |  | Open close | 160h | arc 81 | A. Musso | TE MSC |
| 77 | 4.4.5 | VAC Leak test | 7w | 2014-02-03 | 2014-03-24 | 76FF+4w | 132.5d |  |  | Insulation Vacuum | 280h | arc 81 | P Cruikshank | TE VSC |

Notes:
- 54: According to skeleton
- 66: According to skeleton
- 71: According to skeleton
- 72: According to skeleton

| ID | WBS | Task | Type | Duration | Start | Finish | Predecessors | Total slack | Free slack | Constraint | Resources | Work | Location | fla2 | Text1 |
| --- | --- | --- | --- | --- | --- | --- | --- | --- | --- | --- | --- | --- | --- | --- | --- |
| 78 | 4.5 | **BLM & nQPS** |  | 16d | 2014-03-24 | 2014-04-15 | 72 | 132.5d |  |  |  | 128h | arc 81 | BE BI |  |
| 79 | 4.5.1 | BLM & nQPS re-installation |  | 8d | 2014-03-24 | 2014-04-03 |  | 132.5d | 0d |  | BLM | 64h | arc 81 | BE BI | S Grishin |
| 80 | 4.5.2 | BLM sources tests (nights) |  | 3d | 2014-04-03 | 2014-04-08 | 79 | 132.5d | 0d |  | BLM | 24h | arc 81 | BE BI | S Grishin |
| 81 | 4.5.3 | QPS cable replacement/validation |  | 1w | 2014-04-08 | 2014-04-15 | 80 | 132.5d |  |  | QPS | 40h | arc 81 | TE MPE | K Dahlerup |
| 82 | 4.6 | Final Activities |  | 385.12d | 2014-03-25 | 2014-07-31 |  | 335.38d |  | finish no earlier than 2014-07-31 |  |  | arc 81 |  |  |
| 83 | 5 | **Sector 12** |  | 433d? | 2012-11-19 | 2014-08-27 |  | 59.5d |  |  |  | 3792h | arc 12 |  |  |
| 84 | 5.1 | Preliminary activities |  | 65d | 2013-02-19 | 2013-05-27 |  | 43.5d | 0d | start no earlier than 2013-02-19 |  |  |  |  |  |
| 85 | 5.2 | **Aimants** |  | 77d | 2013-06-07 | 2013-09-24 |  | 97d |  |  | SIT MAGNETS | 3032h | arc 12 | TE MSC | N Bourcey |
| 86 | 5.2.1 | opening W and remove thermal insulation |  | 2d | 2013-06-07 | 2013-06-10 | 39SS+10d, 84 | 97d | 0d |  | SIT MAGNETS | 16h | arc 12 | TE MSC | N Bourcey |
| 87 | 5.2.2 | **C15R1** |  | 25d | 2013-06-11 | 2013-07-15 |  | 97d |  |  | SIT MAGNETS | 400h | arc 12 | TE MSC | N Bourcey |
| 88 | 5.2.2.1 | deconnection |  | 6d | 2013-06-11 | 2013-06-18 | 86 | 97d | 0d |  | SIT MAGNETS | 48h | arc 12 | TE MSC | N Bourcey |
| 89 | 5.2.2.2 | C15R1 available for transport | milestone | 0d | 2013-06-18 | 2013-06-18 | 88 | 336.5d | 0d |  | SIT MAGNETS |  | arc 12 | TE MSC | N Bourcey |
| 90 | 5.2.2.3 | IC repairing |  | 3d | 2013-06-19 | 2013-06-21 | 89 | 336.5d | 0d |  | SIT MAGNETS | 24h | arc 12 | TE MSC | N Bourcey |
| 91 | 5.2.2.4 | reconnection |  | 16d | 2013-06-24 | 2013-07-15 | 90 | 336.5d |  |  | SIT MAGNETS | 128h | arc 12 | TE MSC | N Bourcey |
| 92 | 5.2.3 | **A22R1** |  | 25d | 2013-06-25 | 2013-07-29 |  | 97d |  |  | SIT MAGNETS | 400h | arc 12 | TE MSC | N Bourcey |
| 93 | 5.2.3.1 | deconnection |  | 6d | 2013-06-25 | 2013-07-02 | 88SS+10d | 97d | 0d |  | SIT MAGNETS | 48h | arc 12 | TE MSC | N Bourcey |
| 94 | 5.2.3.2 | A22R1 available for transport | milestone | 0d | 2013-07-02 | 2013-07-02 | 93 | 345.5d |  |  | SIT MAGNETS |  | arc 12 | TE MSC | N Bourcey |
| 95 | 5.2.3.3 | IC repairing |  | 3d | 2013-07-03 | 2013-07-05 | 93 | 326.5d | 0d |  | SIT MAGNETS | 24h | arc 12 | TE MSC | N Bourcey |
| 96 | 5.2.3.4 | reconnection |  | 16d | 2013-07-08 | 2013-07-29 | 95 | 326.5d |  |  | SIT MAGNETS | 128h | arc 12 | TE MSC | N Bourcey |
| 97 | 5.2.4 | **C30R1** |  | 25d | 2013-07-09 | 2013-08-12 |  | 97d |  |  | SIT MAGNETS | 400h | arc 12 | TE MSC | N Bourcey |
| 98 | 5.2.4.1 | deconnection |  | 6d | 2013-07-09 | 2013-07-16 | 93SS+10d | 97d | 0d |  | SIT MAGNETS | 48h | arc 12 | TE MSC | N Bourcey |
| 99 | 5.2.4.2 | C30R1 available for transport | milestone | 0d | 2013-07-16 | 2013-07-16 | 98 | 335.5d |  |  | SIT MAGNETS |  | arc 12 | TE MSC | N Bourcey |
| 100 | 5.2.4.3 | IC repairing |  | 3d | 2013-07-17 | 2013-07-19 | 98 | 316.5d | 0d |  | SIT MAGNETS | 24h | arc 12 | TE MSC | N Bourcey |
| 101 | 5.2.4.4 | reconnection |  | 16d | 2013-07-22 | 2013-08-12 | 100 | 316.5d |  |  | SIT MAGNETS | 128h | arc 12 | TE MSC | N Bourcey |

Notes:
- 85: According to skeleton

| ID | WBS | Task | Type | Duration | Start | Finish | Predecessors | Total slack | Free slack | Constraint | Resources | Work | Text1 | Location | fla2 |
| --- | --- | --- | --- | --- | --- | --- | --- | --- | --- | --- | --- | --- | --- | --- | --- |
| 102 | 5.2.5 | **C33L2** |  | 25d | 2013-07-23 | 2013-08-26 |  | 97d |  |  | SIT MAGNETS | 400h | N Bourcey | arc 12 | TE MSC |
| 103 | 5.2.5.1 | deconnection |  | 6d | 2013-07-23 | 2013-07-30 | 98SS+10d | 97d | 0d |  | SIT MAGNETS | 48h | N Bourcey | arc 12 | TE MSC |
| 104 | 5.2.5.2 | C33L2 available for transport | milestone | 0d | 2013-07-30 | 2013-07-30 | 103 | 325.5d |  |  | SIT MAGNETS |  | N Bourcey | arc 12 | TE MSC |
| 105 | 5.2.5.3 | IC repairing |  | 3d | 2013-07-31 | 2013-08-02 | 103 | 306.5d | 0d |  | SIT MAGNETS | 24h | N Bourcey | arc 12 | TE MSC |
| 106 | 5.2.5.4 | reconnection |  | 16d | 2013-08-05 | 2013-08-26 | 105 | 306.5d |  |  | SIT MAGNETS | 128h | N Bourcey | arc 12 | TE MSC |
| 107 | 5.2.6 | **C33R1** |  | 25d | 2013-08-06 | 2013-09-10 |  | 97d |  |  | SIT MAGNETS | 400h | N Bourcey | arc 12 | TE MSC |
| 108 | 5.2.6.1 | deconnection |  | 6d | 2013-08-06 | 2013-08-13 | 103SS+10d | 97d | 0d |  | SIT MAGNETS | 48h | N Bourcey | arc 12 | TE MSC |
| 109 | 5.2.6.2 | C33R1 available for transport | milestone | 0d | 2013-08-13 | 2013-08-13 | 108 | 315.5d |  |  | SIT MAGNETS |  | N Bourcey | arc 12 | TE MSC |
| 110 | 5.2.6.3 | IC repairing |  | 3d | 2013-08-14 | 2013-08-16 | 108 | 296.5d | 0d |  | SIT MAGNETS | 24h | N Bourcey | arc 12 | TE MSC |
| 111 | 5.2.6.4 | reconnection |  | 16d | 2013-08-19 | 2013-09-10 | 110 | 296.5d |  |  | SIT MAGNETS | 128h | N Bourcey | arc 12 | TE MSC |
| 112 | 5.2.7 | **A29L2** |  | 25d | 2013-08-20 | 2013-09-24 |  | 97d |  |  | SIT MAGNETS | 400h | N Bourcey | arc 12 | TE MSC |
| 113 | 5.2.7.1 | deconnection |  | 6d | 2013-08-20 | 2013-08-27 | 108SS+10d | 97d | 0d |  | SIT MAGNETS | 48h | N Bourcey | arc 12 | TE MSC |
| 114 | 5.2.7.2 | A29L2 available for transport | milestone | 0d | 2013-08-27 | 2013-08-27 | 113 | 305.5d |  |  | SIT MAGNETS |  | N Bourcey | arc 12 | TE MSC |
| 115 | 5.2.7.3 | IC repairing |  | 3d | 2013-08-28 | 2013-08-30 | 113 | 286.5d | 0d |  | SIT MAGNETS | 24h | N Bourcey | arc 12 | TE MSC |
| 116 | 5.2.7.4 | reconnection |  | 16d | 2013-09-02 | 2013-09-24 | 115 | 286.5d |  |  | SIT MAGNETS | 128h | N Bourcey | arc 12 | TE MSC |
| 117 | 5.3 | Ball test |  | 3d | 2013-05-28 | 2013-05-30 | 84 | 368.5d |  |  | Insulation Vacuum | 24h | P Cruikshank | arc 12 | TE VSC |
| 118 | 5.4 | **Interconnections activities 12** |  | 344.5d | 2012-11-19 | 2014-04-23 |  | 132d | 0d |  |  | 608h |  | arc 12 |  |
| 119 | 5.4.1 | BLM & nQPS dismounting |  | 3d | 2013-05-28 | 2013-05-30 | 84 | 352.5d |  |  | BLM | 24h | S Grishin | arc 12 | BE BI |
| 120 | 5.4.2 | Opening W and remove thermal insulation |  | 3w | 2013-06-17 | 2013-07-05 | 74, 84 | 29.5d | 0d |  | Open close | 120h | A. Musso | arc 12 | TE MSC |
| 121 | 5.4.3 | Ball test |  | 3d | 2012-11-19 | 2012-11-21 |  | 473.5d |  |  | Insulation Vacuum | 24h | P Cruikshank | arc 12 | TE VSC |
| 122 | 5.4.4 | Closure W |  | 4w | 2014-02-24 | 2014-03-24 | 76 | 0d |  |  | Open close | 160h | A. Musso | arc 12 | TE MSC |
| 123 | 5.4.5 | VAC Leak test |  | 7w | 2014-03-03 | 2014-04-23 | 122FF+4w | 132d |  |  | Insulation Vacuum | 280h | P Cruikshank | arc 12 | TE VSC |
| 124 | 5.5 | **BLM & nQPS** |  | 16d | 2014-04-23 | 2014-05-16 |  | 132d |  |  |  | 128h |  | arc 12 | BE BI |
| 125 | 5.5.1 | BLM & nQPS re-installation |  | 8d | 2014-04-23 | 2014-05-06 | 118 | 132d | 0d |  | BLM | 64h | S Grishin | arc 12 | BE BI |
| 126 | 5.5.2 | BLM sources tests (nights) |  | 3d | 2014-05-06 | 2014-05-09 | 125 | 132d | 0d |  | BLM | 24h | S Grishin | arc 12 | BE BI |
| 127 | 5.5.3 | QPS cable replacement/validation |  | 1w | 2014-05-09 | 2014-05-16 | 126 | 132d |  |  | QPS | 40h | K Dahlerup | arc 12 | TE MPE |
| 128 | 5.6 | Final Activities |  | 1d? | 2014-08-27 | 2014-08-27 | 118 | 59.5d |  | finish no earlier than 2014-08-27 |  |  |  |  |  |

Notes:
- 117: According to skeleton
- 118: According to skeleton

| ID | WBS | Task | Type | Duration | Start | Finish | Predecessors | Total slack | Free slack | Constraint | Resources | Work | Location | Text1 | fla2 |
| --- | --- | --- | --- | --- | --- | --- | --- | --- | --- | --- | --- | --- | --- | --- | --- |
| 129 | 6 | **Sector 23** |  | 455d? | 2012-11-19 | 2014-09-29 |  | 37.5d |  |  |  | 3428h | arc 23 |  |  |
| 130 | 6.1 | Preliminary activities |  | 53d | 2013-03-13 | 2013-05-31 |  | 54.5d | 0d | finish no earlier than 2013-05-31 |  |  |  |  |  |
| 131 | 6.2 | **Aimants** |  | 45.5d | 2013-09-03 | 2013-11-06 |  | 97d |  |  | SIT MAGNETS | 1568h | arc 23 | N Bourcey | TE MSC |
| 132 | 6.2.1 | opening W and remove thermal insulation |  | 0.5d | 2013-09-03 | 2013-09-03 | 113SS+10d, 130 | 97d | 0d |  | SIT MAGNETS | 4h | arc 23 | N Bourcey | TE MSC |
| 133 | 6.2.2 | **B25R2** |  | 25d | 2013-09-03 | 2013-10-09 |  | 97d |  |  | SIT MAGNETS | 400h | arc 23 | N Bourcey | TE MSC |
| 134 | 6.2.2.1 | deconnection |  | 6d | 2013-09-03 | 2013-09-12 | 132 | 97d | 0d |  | SIT MAGNETS | 48h | arc 23 | N Bourcey | TE MSC |
| 135 | 6.2.2.2 | B25R2 available for transport | milestone | 0d | 2013-09-12 | 2013-09-12 | 134 | 295d |  |  | SIT MAGNETS |  | arc 23 | N Bourcey | TE MSC |
| 136 | 6.2.2.3 | IC repairing |  | 3d | 2013-09-12 | 2013-09-17 | 134 | 276d | 0d |  | SIT MAGNETS | 24h | arc 23 | N Bourcey | TE MSC |
| 137 | 6.2.2.4 | reconnection |  | 16d | 2013-09-17 | 2013-10-09 | 136 | 276d |  |  | SIT MAGNETS | 128h | arc 23 | N Bourcey | TE MSC |
| 138 | 6.2.3 | **C15L3** |  | 25d | 2013-09-18 | 2013-10-23 |  | 97d |  |  | SIT MAGNETS | 400h | arc 23 | N Bourcey | TE MSC |
| 139 | 6.2.3.1 | deconnection |  | 6d | 2013-09-18 | 2013-09-26 | 134SS+10d | 97d | 0d |  | SIT MAGNETS | 48h | arc 23 | N Bourcey | TE MSC |
| 140 | 6.2.3.2 | C15L3 available for transport | milestone | 0d | 2013-09-26 | 2013-09-26 | 139 | 285d |  |  | SIT MAGNETS |  | arc 23 | N Bourcey | TE MSC |
| 141 | 6.2.3.3 | IC repairing |  | 3d | 2013-09-26 | 2013-10-01 | 139 | 266d | 0d |  | SIT MAGNETS | 24h | arc 23 | N Bourcey | TE MSC |
| 142 | 6.2.3.4 | reconnection |  | 16d | 2013-10-01 | 2013-10-23 | 141 | 266d |  |  | SIT MAGNETS | 128h | arc 23 | N Bourcey | TE MSC |
| 143 | 6.2.4 | **A23R2** |  | 25d | 2013-10-02 | 2013-11-06 |  | 97d |  |  | SIT MAGNETS | 400h | arc 23 | N Bourcey | TE MSC |
| 144 | 6.2.4.1 | deconnection |  | 6d | 2013-10-02 | 2013-10-10 | 139SS+10d | 97d | 0d |  | SIT MAGNETS | 48h | arc 23 | N Bourcey | TE MSC |
| 145 | 6.2.4.2 | A23R2 available for transport | milestone | 0d | 2013-10-10 | 2013-10-10 | 144 | 275d |  |  | SIT MAGNETS |  | arc 23 | N Bourcey | TE MSC |
| 146 | 6.2.4.3 | IC repairing |  | 3d | 2013-10-10 | 2013-10-15 | 144 | 256d | 0d |  | SIT MAGNETS | 24h | arc 23 | N Bourcey | TE MSC |
| 147 | 6.2.4.4 | reconnection |  | 16d | 2013-10-15 | 2013-11-06 | 146 | 256d |  |  | SIT MAGNETS | 128h | arc 23 | N Bourcey | TE MSC |
| 148 | 6.3 | **DN 200** |  | 37.5d | 2013-06-05 | 2013-07-26 | 130 | 240d |  |  | DN200 | 1100h | arc 23 | A. Musso | TE MSC |
| 149 | 6.3.1 | Partial opening W |  | 10d | 2013-06-05 | 2013-06-18 | 67, 130 | 240d | 0d |  | DN200 | 80h | arc 23 | A. Musso | TE MSC |
| 150 | 6.3.2 | 168 DN200 to install |  | 6w | 2013-06-07 | 2013-07-19 | 149SS+0.5w | 328d | 0d |  | DN200 | 240h | arc 23 | A. Musso | TE MSC |
| 151 | 6.3.3 | Welding QC |  | 6w | 2013-06-12 | 2013-07-23 | 150SS+0.5w | 328d | 0d |  | Welding QC | 240h | arc 23 |  |  |
| 152 | 6.3.4 | Weldings leak test |  | 6w | 2013-06-14 | 2013-07-26 | 151SS+0.5w | 328d |  |  | Insulation Vacuum | 240h | arc 23 | P Cruikshank | TE VSC |
| 153 | 6.4 | Ball test |  | 3d | 2013-06-03 | 2013-06-05 | 130 | 364.5d |  |  | Insulation Vacuum | 24h | arc 23 | P Cruikshank | TE VSC |

Notes:
- 131: According to skeleton
- 148: According to skeleton
- 153: According to skeleton

| ID | WBS | Task | Type | Duration | Start | Finish | Predecessors | Total slack | Free slack | Constraint | Resources | Work | Location | Text1 | fla2 |
| --- | --- | --- | --- | --- | --- | --- | --- | --- | --- | --- | --- | --- | --- | --- | --- |
| 154 | 6.5 | **Interconnections activities 23** |  | 364.5d | 2012-11-19 | 2014-05-22 |  | 112d | 0d |  |  | 608h | arc 23 |  |  |
| 155 | 6.5.1 | BLM dismounting |  | 3d | 2013-06-03 | 2013-06-05 | 130 | 348.5d |  |  | BLM | 24h | arc 23 | S Grishin | BE BI |
| 156 | 6.5.2 | Opening W and remove thermal insulation |  | 3w | 2013-07-08 | 2013-07-26 | 130, 120 | 29.5d | 0d |  | Open close | 120h | arc 23 | A. Musso | TE MSC |
| 157 | 6.5.3 | Ball test |  | 3d | 2012-11-19 | 2012-11-21 |  | 473.5d |  |  | Insulation Vacuum | 24h | arc 23 | P Cruikshank | TE VSC |
| 158 | 6.5.4 | Closure W |  | 4w | 2014-03-24 | 2014-04-23 | 122 | 0d |  |  | Open close | 160h | arc 23 | A. Musso | TE MSC |
| 159 | 6.5.5 | VAC Leak test |  | 7w | 2014-03-31 | 2014-05-22 | 158FF+4w | 112d |  |  | Insulation Vacuum | 280h | arc 23 | P Cruikshank | TE VSC |
| 160 | 6.6 | **BLM & nQPS** |  | 16d | 2014-05-22 | 2014-06-16 |  | 112d |  |  |  | 128h | arc 23 |  | BE BI |
| 161 | 6.6.1 | BLM & nQPS re-installation |  | 8d | 2014-05-22 | 2014-06-04 | 154 | 112d | 0d |  | BLM | 64h | arc 23 | S Grishin | BE BI |
| 162 | 6.6.2 | BLM sources tests (nights) |  | 3d | 2014-06-04 | 2014-06-09 | 161 | 112d | 0d |  | BLM | 24h | arc 23 | S Grishin | BE BI |
| 163 | 6.6.3 | QPS cable replacement/validation |  | 1w | 2014-06-09 | 2014-06-16 | 162 | 112d |  |  | QPS | 40h | arc 23 | K Dahlerup | TE MPE |
| 164 | 6.7 | Final Activities |  | 1d? | 2014-09-29 | 2014-09-29 | 154 | 37.5d |  | finish no earlier than 2014-09-29 |  |  |  |  |  |
| 165 | 7 | **Sector 34** |  | 475d | 2012-11-19 | 2014-10-27 |  | 17.5d |  |  |  | 3816h | arc 34 |  |  |
| 166 | 7.1 | Preliminary activities |  | 85d | 2013-02-25 | 2013-06-28 |  | 109.5d | 0d | start no earlier than 2013-02-23 |  |  | arc 34 |  |  |
| 167 | 7.2 | **Aimants** |  | 65.5d | 2013-10-16 | 2014-01-29 |  | 97d |  |  | SIT MAGNETS | 2816h | arc 34 | N Bourcey | TE MSC |
| 168 | 7.2.1 | opening W and remove thermal insulation |  | 0.5d | 2013-10-16 | 2013-10-16 | 144SS+10d, 166 | 97d | 0d |  | SIT MAGNETS | 4h | arc 34 | N Bourcey | TE MSC |
| 169 | 7.2.2 | **Q7R3** |  | 31d | 2013-10-17 | 2013-11-28 |  | 97d |  |  | SIT MAGNETS | 496h | arc 34 | N Bourcey | TE MSC |
| 170 | 7.2.2.1 | deconnection |  | 8d | 2013-10-17 | 2013-10-28 | 168 | 97d | 0d |  | SIT MAGNETS | 64h | arc 34 | N Bourcey | TE MSC |
| 171 | 7.2.2.2 | Q7R3 available for transport | milestone | 0d | 2013-10-28 | 2013-10-28 | 170 | 262.5d |  |  | SIT MAGNETS |  | arc 34 | N Bourcey | TE MSC |
| 172 | 7.2.2.3 | IC repairing |  | 3d | 2013-10-29 | 2013-10-31 | 170 | 239.5d | 0d |  | SIT MAGNETS | 24h | arc 34 | N Bourcey | TE MSC |
| 173 | 7.2.2.4 | reconnection |  | 20d | 2013-11-01 | 2013-11-28 | 172 | 239.5d |  |  | SIT MAGNETS | 160h | arc 34 | N Bourcey | TE MSC |
| 174 | 7.2.3 | **Q23R3** |  | 31d | 2013-10-31 | 2013-12-12 |  | 97d |  |  | SIT MAGNETS | 496h | arc 34 | N Bourcey | TE MSC |
| 175 | 7.2.3.1 | deconnection |  | 8d | 2013-10-31 | 2013-11-11 | 170SS+10d | 97d | 0d |  | SIT MAGNETS | 64h | arc 34 | N Bourcey | TE MSC |
| 176 | 7.2.3.2 | Q23R3 available for transport | milestone | 0d | 2013-11-11 | 2013-11-11 | 175 | 252.5d |  |  | SIT MAGNETS |  | arc 34 | N Bourcey | TE MSC |
| 177 | 7.2.3.3 | IC repairing |  | 3d | 2013-11-12 | 2013-11-14 | 175 | 229.5d | 0d |  | SIT MAGNETS | 24h | arc 34 | N Bourcey | TE MSC |
| 178 | 7.2.3.4 | reconnection |  | 20d | 2013-11-15 | 2013-12-12 | 177 | 229.5d |  |  | SIT MAGNETS | 160h | arc 34 | N Bourcey | TE MSC |

Notes:
- 154: According to skeleton

| ID | WBS | Task | Type | Duration | Start | Finish | Predecessors | Total slack | Free slack | Resources | Work | Text1 | Location | fla2 |
| --- | --- | --- | --- | --- | --- | --- | --- | --- | --- | --- | --- | --- | --- | --- |
| 179 | 7.2.4 | **A26R3** |  | 25d | 2013-11-14 | 2013-12-18 |  | 97d |  | SIT MAGNETS | 400h | N Bourcey | arc 34 | TE MSC |
| 180 | 7.2.4.1 | deconnection |  | 6d | 2013-11-14 | 2013-11-21 | 175SS+10d | 97d | 0d | SIT MAGNETS | 48h | N Bourcey | arc 34 | TE MSC |
| 181 | 7.2.4.2 | A23R3 available for transport | milestone | 0d | 2013-11-21 | 2013-11-21 | 180 | 244.5d |  | SIT MAGNETS |  | N Bourcey | arc 34 | TE MSC |
| 182 | 7.2.4.3 | IC repairing |  | 3d | 2013-11-22 | 2013-11-26 | 180 | 225.5d | 0d | SIT MAGNETS | 24h | N Bourcey | arc 34 | TE MSC |
| 183 | 7.2.4.4 | reconnection |  | 16d | 2013-11-27 | 2013-12-18 | 182 | 225.5d |  | SIT MAGNETS | 128h | N Bourcey | arc 34 | TE MSC |
| 184 | 7.2.5 | **Q27R3** |  | 31d | 2013-11-28 | 2014-01-23 |  | 97d |  | SIT MAGNETS | 496h | N Bourcey | arc 34 | TE MSC |
| 185 | 7.2.5.1 | deconnection |  | 8d | 2013-11-28 | 2013-12-09 | 180SS+10d | 97d | 0d | SIT MAGNETS | 64h | N Bourcey | arc 34 | TE MSC |
| 186 | 7.2.5.2 | Q27R3 available for transport | milestone | 0d | 2013-12-09 | 2013-12-09 | 185 | 232.5d |  | SIT MAGNETS |  | N Bourcey | arc 34 | TE MSC |
| 187 | 7.2.5.3 | IC repairing |  | 3d | 2013-12-10 | 2013-12-12 | 185 | 209.5d | 0d | SIT MAGNETS | 24h | N Bourcey | arc 34 | TE MSC |
| 188 | 7.2.5.4 | reconnection |  | 20d | 2013-12-13 | 2014-01-23 | 187 | 209.5d |  | SIT MAGNETS | 160h | N Bourcey | arc 34 | TE MSC |
| 189 | 7.2.6 | **B32R3** |  | 25d | 2013-12-12 | 2014-01-29 |  | 97d |  | SIT MAGNETS | 400h | N Bourcey | arc 34 | TE MSC |
| 190 | 7.2.6.1 | deconnection |  | 6d | 2013-12-12 | 2013-12-19 | 185SS+10d | 97d | 0d | SIT MAGNETS | 48h | N Bourcey | arc 34 | TE MSC |
| 191 | 7.2.6.2 | B32R3 available for transport | milestone | 0d | 2013-12-19 | 2013-12-19 | 190 | 224.5d |  | SIT MAGNETS |  | N Bourcey | arc 34 | TE MSC |
| 192 | 7.2.6.3 | IC repairing |  | 3d | 2013-12-20 | 2014-01-07 | 190 | 205.5d | 0d | SIT MAGNETS | 24h | N Bourcey | arc 34 | TE MSC |
| 193 | 7.2.6.4 | reconnection |  | 16d | 2014-01-08 | 2014-01-29 | 192 | 205.5d |  | SIT MAGNETS | 128h | N Bourcey | arc 34 | TE MSC |
| 194 | 7.3 | Ball test |  | 3d | 2013-07-01 | 2013-07-03 | 166 | 344.5d |  | Insulation Vacuum | 24h | P Cruikshank | arc 34 | TE VSC |
| 195 | 7.4 | **Interconnections activities 34** |  | 384.5d | 2012-11-19 | 2014-06-20 |  | 21d | 0d |  | 848h |  | arc 34 |  |
| 196 | 7.4.1 | BLM & nQPS dismounting |  | 3d | 2013-07-01 | 2013-07-03 | 166 | 257.5d |  | BLM | 24h | S Grishin | arc 34 | BE BI |
| 197 | 7.4.2 | Opening W and remove thermal insulation |  | 3w | 2013-10-22 | 2013-11-11 | 166, 57 | 29.5d | 0d | Open close | 120h | A. Musso | arc 34 | TE MSC |
| 198 | 7.4.3 | Inspection beam lines |  | 3w | 2013-10-24 | 2013-11-14 | 197SS+0.5w | 163d |  | QC Open close | 120h | R Ostojic | arc 34 |  |
| 199 | 7.4.4 | Protection beam lines |  | 3w | 2013-10-24 | 2013-11-14 | 197SS+0.5w | 163d |  | Open close | 120h | A. Musso | arc 34 | TE MSC |
| 200 | 7.4.5 | Ball test |  | 3d | 2012-11-19 | 2012-11-21 |  | 402.5d |  | Insulation Vacuum | 24h | P Cruikshank | arc 34 | TE VSC |
| 201 | 7.4.6 | Closure W |  | 4w | 2014-04-23 | 2014-05-22 | 158 | 0d |  | Open close | 160h | A. Musso | arc 34 | TE MSC |
| 202 | 7.4.7 | VAC Leak test |  | 7w | 2014-04-30 | 2014-06-20 | 201FF+4w | 21d |  | Insulation Vacuum | 280h | P Cruikshank | arc 34 | TE VSC |

| ID | WBS | Task | Type | Duration | Start | Finish | Predecessors | Total slack | Free slack | Constraint | Resources | Work | Location | fla2 | Text1 |
| --- | --- | --- | --- | --- | --- | --- | --- | --- | --- | --- | --- | --- | --- | --- | --- |
| 203 | 7.5 | **BLM & nQPS** |  | 16d | 2014-06-20 | 2014-07-14 |  | 92d |  |  |  | 128h | arc 34 | BE BI |  |
| 204 | 7.5.1 | BLM & nQPS re-installation |  | 8d | 2014-06-20 | 2014-07-02 | 195 | 92d | 0d |  | BLM | 64h | arc 34 | BE BI | S Grishin |
| 205 | 7.5.2 | BLM sources tests (nights) |  | 3d | 2014-07-02 | 2014-07-07 | 204 | 92d | 0d |  | BLM | 24h | arc 34 | BE BI | S Grishin |
| 206 | 7.5.3 | QPS cable replacement/validation |  | 1w | 2014-07-07 | 2014-07-14 | 205 | 92d |  |  | QPS | 40h | arc 34 | TE MPE | K Dahlerup |
| 207 | 7.6 | Final Activities |  | 87d | 2014-06-26 | 2014-10-27 | 195 | 17.5d |  | start no earlier than 2014-06-26 |  |  | arc 34 |  |  |
| 208 | 8 | **Sector 45** |  | 492.5d | 2012-11-19 | 2014-11-20 |  | 0d |  |  |  | 2828h | arc 45 |  |  |
| 209 | 8.1 | Preliminary Activities |  | 51d | 2013-02-11 | 2013-04-24 |  | 168.5d | 0d | finish no earlier than 2013-04-24 |  |  | arc 45 |  |  |
| 210 | 8.2 | **Aimants** |  | 35.5d | 2014-01-09 | 2014-02-27 |  | 97d |  |  | SIT MAGNETS | 1088h | arc 45 |  |  |
| 211 | 8.2.1 | opening W and remove thermal insulation |  | 0.5d | 2014-01-09 | 2014-01-09 | 190SS+10d, 209 | 97d | 0d |  | SIT MAGNETS | 4h | arc 45 | TE MSC | N Bourcey |
| 212 | 8.2.2 | **C17R4** |  | 25d | 2014-01-09 | 2014-02-13 |  | 97d |  |  | SIT MAGNETS | 400h | arc 45 | TE MSC | N Bourcey |
| 213 | 8.2.2.1 | deconnection |  | 6d | 2014-01-09 | 2014-01-17 | 211 | 97d | 0d |  | SIT MAGNETS | 48h | arc 45 | TE MSC | N Bourcey |
| 214 | 8.2.2.2 | C17R4 available for transport | milestone | 0d | 2014-01-17 | 2014-01-17 | 213 | 126d |  |  | SIT MAGNETS |  | arc 45 | TE MSC | N Bourcey |
| 215 | 8.2.2.3 | IC repairing |  | 3d | 2014-01-17 | 2014-01-22 | 213 | 107d | 0d |  | SIT MAGNETS | 24h | arc 45 | TE MSC | N Bourcey |
| 216 | 8.2.2.4 | reconnection |  | 16d | 2014-01-22 | 2014-02-13 | 215 | 107d |  |  | SIT MAGNETS | 128h | arc 45 | TE MSC | N Bourcey |
| 217 | 8.2.3 | **B31R4** |  | 25d | 2014-01-23 | 2014-02-27 |  | 97d |  |  | SIT MAGNETS | 400h | arc 45 | TE MSC | N Bourcey |
| 218 | 8.2.3.1 | deconnection |  | 6d | 2014-01-23 | 2014-01-31 | 213SS+10d | 97d | 0d |  | SIT MAGNETS | 48h | arc 45 | TE MSC | N Bourcey |
| 219 | 8.2.3.2 | B31R4 available for transport | milestone | 0d | 2014-01-31 | 2014-01-31 | 218 | 116d |  |  | SIT MAGNETS |  | arc 45 | TE MSC | N Bourcey |
| 220 | 8.2.3.3 | IC repairing |  | 3d | 2014-01-31 | 2014-02-05 | 218 | 97d | 0d |  | SIT MAGNETS | 24h | arc 45 | TE MSC | N Bourcey |
| 221 | 8.2.3.4 | reconnection |  | 16d | 2014-02-05 | 2014-02-27 | 220 | 97d | 0d |  | SIT MAGNETS | 128h | arc 45 | TE MSC | N Bourcey |
| 222 | 8.3 | **DN 200** |  | 27.5d | 2013-06-19 | 2013-07-26 |  | 240d |  |  | DN200 | 740h | arc 45 | TE MSC | A. Musso |
| 223 | 8.3.1 | Partial opening W |  | 1w | 2013-06-19 | 2013-06-25 | 149, 209 | 240d | 0d |  | DN200 | 40h | arc 45 | TE MSC | A. Musso |
| 224 | 8.3.2 | 108 DN200 to install |  | 4w | 2013-06-21 | 2013-07-19 | 223SS+0.5w | 240d | 0d |  | DN200 | 160h | arc 45 | TE MSC | A. Musso |
| 225 | 8.3.3 | Welding QC |  | 4w | 2013-06-26 | 2013-07-23 | 224SS+0.5w | 240d | 0d |  | Welding QC | 160h | arc 45 |  | R Ostojic |
| 226 | 8.3.4 | Weldings leak test |  | 4w | 2013-06-28 | 2013-07-26 | 225SS+0.5w | 240d |  |  | Insulation Vacuum | 160h | arc 45 | TE VSC | P Cruikshank |
| 227 | 8.4 | Ball test |  | 3d | 2013-04-25 | 2013-04-29 | 209 | 388.5d |  |  | Insulation Vacuum | 24h | arc 45 | TE VSC | P Cruikshank |

Notes:
- 210: According to skeleton
- 222: According to skeleton
- 227: According to skeleton

| ID | WBS | Task | Duration | Start | Finish | Predecessors | Total slack | Free slack | Constraint | Resources | Work | Location | Text1 | fla2 |
| --- | --- | --- | --- | --- | --- | --- | --- | --- | --- | --- | --- | --- | --- | --- |
| 228 | 8.5 | **Interconnections activities 45** | 404.5d | 2012-11-19 | 2014-07-18 |  | 0d |  |  |  | 848h | arc 45 |  |  |
| 229 | 8.5.1 | BLM dismounting | 3d | 2013-04-25 | 2013-04-29 | 209 | 300.5d |  |  | BLM | 24h | arc 45 | S Grishin | BE BI |
| 230 | 8.5.2 | Opening W and remove thermal insulation | 3w | 2014-01-06 | 2014-01-27 | 197, 209 | 0d |  | start no earlier than 2014-01-06 | Open close | 120h | arc 45 | A. Musso | TE MSC |
| 231 | 8.5.3 | Inspection beam lines | 3w | 2014-01-09 | 2014-01-29 | 230SS+0.5w | 117.5d |  |  | QC Open close | 120h | arc 45 | R Ostojic |  |
| 232 | 8.5.4 | Protection beam lines | 3w | 2014-01-09 | 2014-01-29 | 230SS+0.5w | 117.5d |  |  | Open close | 120h | arc 45 | A. Musso | TE MSC |
| 233 | 8.5.5 | Ball test | 3d | 2012-11-19 | 2012-11-21 |  | 401.5d |  |  | Insulation Vacuum | 24h | arc 45 | P Cruikshank | TE VSC |
| 234 | 8.5.6 | Closure W | 4w | 2014-05-22 | 2014-06-20 | 201 | 0d |  |  | Open close | 160h | arc 45 | A. Musso | TE MSC |
| 235 | 8.5.7 | VAC Leak test | 7w | 2014-05-30 | 2014-07-18 | 234FF+4w | 0d |  |  | Insulation Vacuum | 280h | arc 45 | P Cruikshank | TE VSC |
| 236 | 8.6 | **BLM & nQPS** | 16d | 2014-07-18 | 2014-08-11 |  | 72d |  |  |  | 128h | arc 45 |  | BE BI |
| 237 | 8.6.1 | BLM & nQPS re-installation | 8d | 2014-07-18 | 2014-07-30 | 228 | 72d | 0d |  | BLM | 64h | arc 45 | S Grishin | BE BI |
| 238 | 8.6.2 | BLM sources tests (nights) | 3d | 2014-07-30 | 2014-08-04 | 237 | 72d | 0d |  | BLM | 24h | arc 45 | S Grishin | BE BI |
| 239 | 8.6.3 | QPS cable replacement/validation | 1w | 2014-08-04 | 2014-08-11 | 238 | 72d |  |  | QPS | 40h | arc 45 | K Dahlerup | TE MPE |
| 240 | 8.7 | Final Activities | 88d | 2014-07-18 | 2014-11-20 | 228, 222, 210 | 0d |  | start no earlier than 2014-07-18 |  |  | arc 45 |  |  |

Notes:
- 228: According to skeleton
