Schedule from MS Project, 2012-11-17 to 2015-05-05.

## Calendars

- Standard: Mon-Fri 08:00-12:00, 13:00-17:00; Sat-Sun off. Exceptions (off unless hours are given): 2012-12-24 to 2013-01-04 (Xmas holidays 2012), 2013-03-29 (2013 - Good Friday), 2013-04-01 (2013 - Easter Monday), 2013-05-01 (2013 - 1st May), 2013-05-09 (2013 - Ascension Day), 2013-05-20 (2013 - Whit Monday), 2013-09-05 (2013 - Jeunes Genevois), 2013-12-23 to 2014-01-03 (Xmas holidays 2013), 2014-04-18 08:00-12:00, 13:00-17:00, 2014-04-21 (2014 - Easter Monday), 2014-05-01 (2014 - 1st May), 2014-05-29 (2014 - Ascension Day), 2014-06-29 (2014 - Whit Monday), 2014-09-04 (2014 - Jeunes Genevois).

## Resources

| Resource |
| --- |
| Powering Tests |
| ELQA |
| Leak test |

## Schedule

| ID | WBS | Task | Type | Duration | Start | Finish | Predecessors | Baseline start | Baseline finish | Baseline duration | Total slack | Free slack | Constraint | Resources | Work | Text1 | Location | fla2 |
| --- | --- | --- | --- | --- | --- | --- | --- | --- | --- | --- | --- | --- | --- | --- | --- | --- | --- | --- |
| 1 | 1 | **Start of Access in Service Areas** |  | 9d? | 2013-02-15 | 2013-02-27 |  | 2012-11-21 | 2012-11-29 | 7d? | 549d |  |  |  |  |  |  |  |
| 2 | 1.1 | Start of work at P1,2 |  | 1d? | 2013-02-25 | 2013-02-25 | 287 | 2012-11-26 | 2012-11-26 | 1d? | 551d |  |  |  |  |  |  |  |
| 3 | 1.2 | Start of work at P3 |  | 1d? | 2013-02-27 | 2013-02-27 | 57 | 2012-11-29 | 2012-11-29 | 1d? | 549d |  |  |  |  |  |  |  |
| 4 | 1.3 | Start of work at P4,5,6,7,8 |  | 1d? | 2013-02-15 | 2013-02-15 | 166 | 2012-11-21 | 2012-11-21 | 1d? | 557d |  |  |  |  |  |  |  |
| 5 | 2 | **End of Access** |  | 191d? | 2014-08-11 | 2015-05-05 |  | 2012-11-19 | 2014-03-28 | 329d? | 0d |  |  |  |  |  |  |  |
| 6 | 2.1 | End of access at P1 |  | 1d? | 2015-02-24 | 2015-02-24 | 53, 322 | 2014-03-28 | 2014-03-28 | 1d? | 50d |  |  |  |  |  |  |  |
| 7 | 2.2 | End of access at P2 |  | 1d? | 2015-03-31 | 2015-03-31 | 53, 89, 125 | 2014-03-28 | 2014-03-28 | 1d? | 25d |  |  |  |  |  |  |  |
| 8 | 2.3 | End of access at P3 |  | 1d? | 2015-03-31 | 2015-03-31 | 89, 125 | 2012-11-19 | 2012-11-19 | 1d? | 25d |  |  |  |  |  |  |  |
| 9 | 2.4 | End of access at P4 |  | 1d? | 2015-05-05 | 2015-05-05 | 89, 125, 164, 202 | 2013-12-20 | 2013-12-20 | 1d? | 0d |  |  |  |  |  |  |  |
| 10 | 2.5 | End of access at P5 |  | 1d? | 2015-05-05 | 2015-05-05 | 164, 202 | 2013-12-20 | 2013-12-20 | 1d? | 0d |  |  |  |  |  |  |  |
| 11 | 2.6 | End of access at P6 |  | 1d? | 2015-05-05 | 2015-05-05 | 164, 202, 244, 283 | 2014-01-24 | 2014-01-24 | 1d? | 0d |  |  |  |  |  |  |  |
| 12 | 2.7 | End of access at P7 |  | 1d? | 2014-08-11 | 2014-08-11 | 244, 283 | 2014-01-24 | 2014-01-24 | 1d? | 190d |  |  |  |  |  |  |  |
| 13 | 2.8 | End of access at P8 |  | 1d? | 2015-02-24 | 2015-02-24 | 244, 283, 322 | 2014-01-24 | 2014-01-24 | 1d? | 50d |  |  |  |  |  |  |  |
| 14 | 3 | **Point 18** |  | 30d? | 2013-06-04 | 2013-07-15 |  | 2013-02-21 | 2013-12-13 | 206d | 0d |  |  |  |  |  |  |  |
| 15 | 3.1 | Helium control |  | 6w | 2013-06-04 | 2013-07-15 | 204SS+1mo | 2013-02-21 | 2013-04-05 | 6w | 456d |  |  |  |  | S Claudet | P18 | TE-CRG |
| 16 | 3.2 | Cryo maintenance | manual | 1d? | 2013-06-04 | 2013-06-04 |  | 2013-03-26 | 2013-12-13 | 183d |  |  |  |  |  | S Claudet | P18 | TE-CRG |
| 17 | 4 | **Sector 12** |  | 408d | 2013-02-19 | 2014-10-09 |  | 2012-11-25 | 2014-03-28 | 324d? | 148d |  |  |  | 648h |  |  |  |
| 18 | 4.1 | Powering Tests |  | 4ed | 2013-02-19 | 2013-02-23 | 246 | 2012-11-25 | 2012-11-29 | 4ed | 2007d | 0d |  | Powering Tests | 96h |  | Arc 12 | BE-OP |
| 19 | 4.2 | RP survey |  | 0.5d | 2013-02-25 | 2013-02-25 | 18 | 2012-11-29 | 2012-11-29 | 0.5d | 551.5d |  |  |  |  | C Tromel | Arc 12 | HSE-RP |
| 20 | 4.3 | ELQA |  | 9d | 2013-03-13 | 2013-03-25 | 18, 248 | 2012-12-03 | 2012-12-13 | 9d | 445d | 0d |  | ELQA | 72h | G D'Angelo | Arc 12 | TE-MPE |
| 21 | 4.4 | Identification Cryo |  | 2d | 2013-03-26 | 2013-03-27 | 20 | 2012-12-13 | 2012-12-15 | 2ed | 487d | 0d |  |  |  | S Claudet | Arc 12 | TE-CRG |
| 22 | 4.5 | Installation materiel VSC- beam vacuum&insulation vacuum |  | 1d | 2013-03-26 | 2013-03-27 | 21SS+0.5d |  |  |  | 529.5d |  |  |  |  | P Cruikshank | Arc 12 | TE-VSC |
| 23 | 4.6 | Warm-up (1.9-5K) |  | 4ed | 2013-03-27 | 2013-03-31 | 21 | 2012-12-15 | 2012-12-19 | 4ed | 2134.88d | 0d |  |  |  | S Claudet | Arc 12 | TE-CRG |
| 24 | 4.7 | Warm-up (5-80K) |  | 1ew | 2013-03-31 | 2013-04-07 | 23 | 2012-12-19 | 2012-12-26 | 1ew | 2134.88d | 1.88d |  |  |  | S Claudet | Arc 12 | TE-CRG |
| 25 | 4.8 | Leak test identification under vacuum (80K) |  | 3d | 2013-04-08 | 2013-04-10 | 24 | 2013-01-14 | 2013-01-16 | 3d | 491d | 0d |  | Leak test | 24h | P Cruikshank | Arc 12 | TE-VSC |
| 26 | 4.9 | Warm-up (80-300K) |  | 2ew | 2013-04-10 | 2013-04-24 | 25 | 2012-12-26 | 2013-01-09 | 2ew | 2140.88d | 1.88d |  |  |  | S Claudet | Arc 12 | TE-CRG |
| 27 | 4.10 | Vacuum degradation |  | 1d | 2013-04-25 | 2013-04-25 | 25, 26 | 2013-01-16 | 2013-01-17 | 1ed | 491d | 8d |  |  |  | P Cruikshank | Arc 12 | TE-VSC |
| 28 | 4.11 | ELQA |  | 8d | 2013-05-10 | 2013-05-22 | 27, 256 | 2013-01-18 | 2013-01-29 | 8d | 483d | 0d |  | ELQA | 64h | G D'Angelo | Arc 12 | TE-MPE |
| 29 | 4.12 | Measurement of the splices (nQPS) |  | 2d | 2013-05-21 | 2013-05-22 | 28FF | 2013-01-28 | 2013-01-29 | 2d | 494d |  |  |  |  | K Dahlerup | Arc 12 | TE-MPE |
| 30 | 4.13 | Leak test (300K-5Bar)- MSC support |  | 3d | 2013-05-23 | 2013-05-27 | 28 | 2013-01-22 | 2013-01-24 | 3d | 491d | 0d |  | Leak test | 24h | P Cruikshank | Arc 12 | TE-VSC |
| 31 | 4.14 | Arc 12 | milestone | 0d | 2013-05-27 | 2013-05-27 | 30 | 2013-01-29 | 2013-01-29 | 0d | 491d |  |  |  |  | ARC | Arc 12 |  |
| 32 | 4.15 | Start opening of the W bellow (train) | milestone | 0d | 2013-07-15 | 2013-07-15 | 301FS+3w | 2013-04-10 | 2013-04-10 | 0d | 441d | 0d |  |  |  | A Musso | Arc 12 | TE-MSC |
| 33 | 4.16 | Validation of the leak test (W) | milestone | 0d | 2014-04-23 | 2014-04-23 |  | 2013-11-27 | 2013-11-27 | 1d? | 125d | 0d | start no earlier than 2014-04-23 |  |  | P Cruikshank | Arc 12 | TE-VSC |
| 34 | 4.17 | Constraint R2E: End access commissioning | milestone | 0d | 2014-07-09 | 2014-07-09 |  |  |  |  | 97d | 0d | start no earlier than 2014-07-09 |  |  |  | Arc 12 |  |
| 35 | 4.18 | Constraint R2E: End Power converter recommissioning | milestone | 0d | 2014-05-26 | 2014-05-26 |  |  |  |  | 219d | 72d | start no earlier than 2014-05-26 |  |  |  | Arc 12 |  |
| 36 | 4.19 | Constraint R2E: End cryo commissioning | milestone | 0d | 2014-01-20 | 2014-01-20 |  |  |  |  | 216d | 119d | start no earlier than 2014-01-20 |  |  |  | Arc 12 |  |
| 37 | 4.20 | Preparation of the pressure test |  | 3d | 2014-04-23 | 2014-04-25 | 33 | 2013-11-28 | 2013-12-02 | 3d | 125d | 0d |  |  |  | S Claudet | Arc 12 | TE-CRG |
| 38 | 4.21 | Pressure Test |  | 1ed | 2014-04-25 | 2014-04-26 | 37 | 2013-12-02 | 2013-12-03 | 1ed | 541.88d | 4.88d |  |  |  | S Claudet | Arc 12 | TE-CRG |
| 39 | 4.22 | Leak test identification (300K-10bar) |  | 2d | 2014-04-28 | 2014-04-29 | 38 | 2013-12-04 | 2013-12-05 | 2d | 126d | 0d |  | Leak test | 16h | P Cruikshank | Arc 12 | TE-VSC |
| 40 | 4.23 | Safety valves installation and Purge |  | 5d | 2014-04-30 | 2014-05-07 | 39 | 2013-12-06 | 2013-12-12 | 5d | 126d | 0d |  |  |  | S Claudet | Arc 12 | TE-CRG |
| 41 | 4.24 | ELQA |  | 7d | 2014-04-30 | 2014-05-09 | 40SS | 2013-12-13 | 2014-01-06 | 7d | 126d | 0d |  | ELQA | 56h | G D'Angelo | Arc 12 | TE-MPE |
| 42 | 4.25 | Measurement of the splices (nQPS) |  | 2d | 2014-05-08 | 2014-05-09 | 41FF | 2013-12-20 | 2014-01-06 | 2d | 255d |  |  |  |  | K Dahlerup | Arc 12 | TE-MPE |
| 43 | 4.26 | Flushing |  | 2w | 2014-05-12 | 2014-05-23 | 41 | 2014-01-07 | 2014-01-20 | 2w | 126d | 0d |  |  |  | S Claudet | Arc 12 | TE-CRG |
| 44 | 4.27 | ELQA |  | 2d | 2014-05-26 | 2014-05-27 | 43 | 2014-01-21 | 2014-01-22 | 2d | 126d | 29d |  | ELQA | 16h | G D'Angelo | Arc 12 | BE-ABP |
| 45 | 4.28 | Measurement of the magnets |  | 2w | 2014-07-24 | 2014-08-06 | 47, 275 | 2014-02-07 | 2014-02-20 | 2w | 97d | 0d |  |  |  | JF Fuchs | Arc 12 | BE-ABP |
| 46 | 4.29 | Alignment of the magnets |  | 3w | 2014-08-07 | 2014-08-27 | 45 | 2014-02-21 | 2014-03-13 | 3w | 97d | 0d |  |  |  | JF Fuchs | Arc 12 | BE-ABP |
| 47 | 4.30 | Cool-down Arc (300-80K) |  | 15ed | 2014-07-09 | 2014-07-24 | 44, 34, 36 | 2014-01-22 | 2014-02-06 | 15ed | 414d | 0d |  |  |  | S Claudet | Arc 12 | TE-CRG |
| 48 | 4.31 | Cool-down Arc (80-20K) |  | 8ed | 2014-07-24 | 2014-08-01 | 47 | 2014-02-06 | 2014-02-14 | 8ed | 642d | 0d |  |  |  | S Claudet | Arc 12 | TE-CRG |
| 49 | 4.32 | Cool-down Arc (20-4.5K) |  | 4ed | 2014-08-01 | 2014-08-05 | 48 | 2014-02-14 | 2014-02-18 | 4ed | 642d | 0d |  |  |  | S Claudet | Arc 12 | TE-CRG |
| 50 | 4.33 | Cool-down Arc (4.5-1.9K) |  | 3ed | 2014-08-05 | 2014-08-08 | 49 | 2014-02-18 | 2014-02-21 | 3ed | 642d | 0d |  |  |  | S Claudet | Arc 12 | TE-CRG |
| 51 | 4.34 | Cryo tuning |  | 1w | 2014-08-08 | 2014-08-14 | 50 | 2014-02-24 | 2014-02-28 | 1w | 151d | 4d |  |  |  | S Claudet | Arc 12 | TE-CRG |
| 52 | 4.35 | ELQA |  | 10d | 2014-08-21 | 2014-09-03 | 51, 46FS-5d | 2014-03-14 | 2014-03-27 | 10d | 147d | 0d |  | ELQA | 80h | G D'Angelo | Arc 12 | TE-MPE |
| 53 | 4.36 | Powering Tests |  | 5w | 2014-09-05 | 2014-10-09 | 52, 34, 35 | 2014-03-28 | 2014-03-28 | 1d? | 147d | 97d |  | Powering Tests | 200h |  | Arc 12 | BE-OP |

Notes:
- 20: DC cables disconnection...
- 28: DC cables disconnection...
- 37: depends on the end of IC activities
- 38: depends on the end of IC activities
- 40: depends on the end of IC activities
- 41: ELQA TP4-A (300K)...
- 44: ELQA TP4-C (installation of the monitoring)...
- 52: ELQA TP4-C (removal of the monitoring)...

| ID | WBS | Task | Type | Duration | Start | Finish | Predecessors | Baseline start | Baseline finish | Baseline duration | Total slack | Free slack | Constraint | Resources | Work | Text1 | Location | fla2 |
| --- | --- | --- | --- | --- | --- | --- | --- | --- | --- | --- | --- | --- | --- | --- | --- | --- | --- | --- |
| 54 | 5 | **Point 2** |  | 1d? | 2012-11-17 | 2012-11-17 |  | 2013-01-30 | 2013-06-11 | 90d |  |  |  |  |  |  |  |  |
| 55 | 5.1 | Cryo maintenance | manual | 1d? | 2012-11-17 | 2012-11-17 |  | 2013-01-30 | 2013-06-11 | 18w |  |  | finish no earlier than 2013-06-11 |  |  | S Claudet | P2 | TE-CRG |
| 56 | 6 | **Sector 23** |  | 526d | 2013-02-23 | 2015-03-30 |  | 2012-11-25 | 2014-04-22 | 339d? | 26d |  |  |  | 648h |  |  |  |
| 57 | 6.1 | Powering Tests |  | 4ed | 2013-02-23 | 2013-02-27 | 287 | 2012-11-25 | 2012-11-29 | 4ed | 1809d | 0d |  | Powering Tests | 96h |  | Arc 23 | BE-OP |
| 58 | 6.2 | RP survey |  | 0.5d | 2013-02-27 | 2013-02-27 | 57 | 2012-11-29 | 2012-11-29 | 0.5d | 549.5d |  |  |  |  | C Tromel | Arc 23 | HSE-RP |
| 59 | 6.3 | ELQA |  | 9d | 2013-03-26 | 2013-04-09 | 57, 289 | 2012-12-03 | 2012-12-13 | 9d | 392d | 0d |  | ELQA | 72h | G D'Angelo | Arc 23 | TE-MPE |
| 60 | 6.4 | Identification Cryo |  | 2d | 2013-04-10 | 2013-04-11 | 59 | 2012-12-13 | 2012-12-15 | 2ed | 488d | 0d |  |  |  | S Claudet | Arc 23 | TE-CRG |
| 61 | 6.5 | Installation materiel VSC- beam vacuum&insulation vacuum |  | 1d | 2013-04-10 | 2013-04-11 | 60SS+0.5d |  |  |  | 520.5d |  |  |  |  | P Cruikshank | Arc 23 | TE-VSC |
| 62 | 6.6 | Warm-up (1.9-5K) |  | 4ed | 2013-04-11 | 2013-04-15 | 60 | 2012-12-15 | 2012-12-19 | 4ed | 2125.88d | 0d |  |  |  | S Claudet | Arc 23 | TE-CRG |
| 63 | 6.7 | Warm-up (5-80K) |  | 1ew | 2013-04-15 | 2013-04-22 | 62 | 2012-12-19 | 2012-12-26 | 1ew | 2125.88d | 1.88d |  |  |  | S Claudet | Arc 23 | TE-CRG |
| 64 | 6.8 | Warm-up (80-300K) |  | 2ew | 2013-04-25 | 2013-05-09 | 63, 65 | 2012-12-26 | 2013-01-09 | 2ew | 2131.88d | 1.88d |  |  |  | S Claudet | Arc 23 | TE-CRG |
| 65 | 6.9 | Leak test identification under vacuum (>80K) |  | 3d | 2013-04-23 | 2013-04-25 | 63 | 2013-01-14 | 2013-01-16 | 3d | 488d | 0d |  | Leak test | 24h | P Cruikshank | Arc 23 | TE-VSC |
| 66 | 6.10 | Vacuum degradation |  | 1d | 2013-05-10 | 2013-05-10 | 64 | 2013-01-16 | 2013-01-17 | 1ed | 490d | 3d |  |  |  | P Cruikshank | Arc 23 | TE-VSC |
| 67 | 6.11 | ELQA |  | 8d | 2013-05-16 | 2013-05-28 | 66, 297 | 2013-01-18 | 2013-01-29 | 8d | 487d | 0d |  | ELQA | 64h | G D'Angelo | Arc 23 | TE-MPE |
| 68 | 6.12 | Measurement of the splices (nQPS) |  | 2d | 2013-05-27 | 2013-05-28 | 67FF | 2013-01-28 | 2013-01-29 | 2d | 490d |  |  |  |  | K Dahlerup | Arc 23 | TE-MPE |
| 69 | 6.13 | Leak test (300K-5Bar)- MSC support |  | 3d | 2013-05-29 | 2013-05-31 | 67 | 2013-01-30 | 2013-02-01 | 3d | 487d | 0d |  | Leak test | 24h | P Cruikshank | Arc 23 | TE-VSC |
| 70 | 6.14 | Arc 23 | milestone | 0d | 2013-05-31 | 2013-05-31 | 69 | 2013-02-01 | 2013-02-01 | 0d | 487d |  |  |  |  | ARC | Arc 23 |  |
| 71 | 6.15 | Start opening of the W bellow (train) | milestone | 0d | 2013-08-05 | 2013-08-05 | 32FS+3w | 2013-05-02 | 2013-05-02 | 0d | 441d |  |  |  |  | A Musso | Arc 23 | TE-MSC |
| 72 | 6.16 | Validation of the leak test (W) | milestone | 0d | 2014-05-22 | 2014-05-22 |  | 2013-12-18 | 2013-12-18 | 1d? | 13d | 0d | start no earlier than 2014-05-22 |  |  | P Cruikshank | Arc 23 | TE-VSC |
| 73 | 6.17 | Preparation of the pressure test |  | 3d | 2014-05-22 | 2014-05-26 | 72 | 2013-12-19 | 2014-01-06 | 3d | 13d | 0d |  |  |  | S Claudet | Arc 23 | TE-CRG |
| 74 | 6.18 | Pressure Test |  | 1ed | 2014-05-26 | 2014-05-27 | 73 | 2014-01-06 | 2014-01-07 | 1ed | 58.88d | 1.88d |  |  |  | S Claudet | Arc 23 | TE-CRG |
| 75 | 6.19 | Leak test identification (300K-10bar) |  | 2d | 2014-05-28 | 2014-05-30 | 74 | 2014-01-08 | 2014-01-09 | 2d | 12d | 0d |  | Leak test | 16h | P Cruikshank | Arc 23 | TE-VSC |
| 76 | 6.20 | Safety valves installation and Purge |  | 5d | 2014-06-02 | 2014-06-06 | 75 | 2014-01-10 | 2014-01-16 | 5d | 12d | 0d |  |  |  | S Claudet | Arc 23 | TE-CRG |
| 77 | 6.21 | ELQA |  | 7d | 2014-06-02 | 2014-06-10 | 76SS | 2014-01-17 | 2014-01-27 | 7d | 12d | 0d |  | ELQA | 56h | G D'Angelo | Arc 23 | TE-MPE |
| 78 | 6.22 | Measurement of the splices (nQPS) |  | 2d | 2014-06-09 | 2014-06-10 | 77FF | 2014-01-24 | 2014-01-27 | 2d | 234d |  |  |  |  | K Dahlerup | Arc 23 | TE-MPE |
| 79 | 6.23 | Flushing |  | 2w | 2014-06-11 | 2014-06-24 | 77 | 2014-01-28 | 2014-02-10 | 2w | 12d | 0d |  |  |  | S Claudet | Arc 23 | TE-CRG |
| 80 | 6.24 | ELQA |  | 2d | 2014-06-25 | 2014-06-26 | 79 | 2014-02-11 | 2014-02-12 | 2d | 12d | 0d |  | ELQA | 16h | G D'Angelo | Arc 23 | BE-ABP |
| 81 | 6.25 | Measurement of the magnets |  | 2w | 2015-01-13 | 2015-01-26 | 83, 315 | 2014-02-28 | 2014-03-13 | 2w | -118d | 0d |  |  |  | JF Fuchs | Arc 23 | BE-ABP |
| 82 | 6.26 | Alignment of the magnets |  | 3w | 2015-01-27 | 2015-02-16 | 81 | 2014-03-14 | 2014-04-03 | 3w | -118d | 0d |  |  |  | JF Fuchs | Arc 23 | BE-ABP |
| 83 | 6.27 | Cool-down Arc (300-80K) |  | 15ed | 2014-06-26 | 2014-07-11 | 80 | 2014-02-12 | 2014-02-27 | 15ed | 55.88d | 0d |  |  |  | S Claudet | Arc 23 | TE-CRG |
| 84 | 6.28 | Cool-down Arc (80-20K) |  | 8ed | 2014-07-11 | 2014-07-19 | 83 | 2014-02-27 | 2014-03-07 | 8ed | 679.88d | 0d |  |  |  | S Claudet | Arc 23 | TE-CRG |
| 85 | 6.29 | Cool-down Arc (20-4.5K) |  | 4ed | 2014-07-19 | 2014-07-23 | 84 | 2014-03-07 | 2014-03-11 | 4ed | 679.88d | 0d |  |  |  | S Claudet | Arc 23 | TE-CRG |
| 86 | 6.30 | Cool-down Arc (4.5-1.9K) |  | 3ed | 2014-07-23 | 2014-07-26 | 85 | 2014-03-11 | 2014-03-14 | 3ed | 679.88d | 4.88d |  |  |  | S Claudet | Arc 23 | TE-CRG |
| 87 | 6.31 | Cryo tuning |  | 1w | 2014-07-28 | 2014-08-01 | 86 | 2014-03-17 | 2014-03-21 | 1w | 160d | 135d |  |  |  | S Claudet | Arc 23 | TE-CRG |
| 88 | 6.32 | ELQA |  | 10d | 2015-02-10 | 2015-02-23 | 87, 82FS-5d | 2014-04-04 | 2014-04-17 | 10d | 25d | 0d |  | ELQA | 80h | G D'Angelo | Arc 23 | TE-MPE |
| 89 | 6.33 | Powering Tests |  | 5w | 2015-02-24 | 2015-03-30 | 88 | 2014-04-22 | 2014-04-22 | 1d? | 25d | 0d |  | Powering Tests | 200h |  | Arc 23 | BE-OP |

Notes:
- 59: DC cables disconnection...
- 67: DC cables disconnection...
- 73: depends on the end of IC activities
- 74: depends on the end of IC activities
- 76: depends on the end of IC activities
- 77: ELQA TP4-A (300K)...
- 80: ELQA TP4-C (installation of the monitoring)...
- 88: ELQA TP4-C (removal of the monitoring)...

| ID | WBS | Task | Type | Duration | Start | Finish | Predecessors | Baseline start | Baseline finish | Baseline duration | Total slack | Free slack | Constraint | Resources | Work | Location | fla2 | Text1 |
| --- | --- | --- | --- | --- | --- | --- | --- | --- | --- | --- | --- | --- | --- | --- | --- | --- | --- | --- |
| 90 | 7 | **Sector 34** |  | 454d | 2013-02-23 | 2014-12-18 |  | 2012-11-29 | 2014-05-14 | 351d? | 98d |  |  |  | 728h |  |  |  |
| 91 | 7.1 | Powering Tests |  | 4ed | 2013-02-23 | 2013-02-27 | 18 | 2012-11-29 | 2012-12-03 | 4ed | 2178d | 0d |  | Powering Tests | 96h | Arc 34 | BE-OP |  |
| 92 | 7.2 | RP survey |  | 0.5d | 2013-02-27 | 2013-02-27 | 91 | 2012-12-03 | 2012-12-03 | 0.5d | 549.5d |  |  |  |  | Arc 34 | HSE-RP | C Tromel |
| 93 | 7.3 | ELQA |  | 9d | 2013-04-15 | 2013-04-25 | 91, 176 | 2012-12-10 | 2012-12-20 | 9d | 467d | 0d |  | ELQA | 72h | Arc 34 | TE-MPE | G D'Angelo |
| 94 | 7.4 | Identification Cryo |  | 2d | 2013-04-26 | 2013-04-29 | 93 | 2012-12-20 | 2012-12-22 | 2ed | 467d | 0d |  |  |  | Arc 34 | TE-CRG | S Claudet |
| 95 | 7.5 | Installation materiel VSC- beam vacuum&insulation vacuum |  | 1d | 2013-04-26 | 2013-04-29 | 94SS+0.5d |  |  |  | 508.5d |  |  |  |  | Arc 34 | TE-VSC | P Cruikshank |
| 96 | 7.6 | Warm-up (1.9-5K) |  | 4ed | 2013-04-29 | 2013-05-03 | 94 | 2013-01-07 | 2013-01-11 | 4ed | 2038.88d | 0d |  |  |  | Arc 34 | TE-CRG | S Claudet |
| 97 | 7.7 | Warm-up (5-20K) |  | 2ed | 2013-05-03 | 2013-05-05 | 96 | 2013-01-11 | 2013-01-13 | 2ed | 2038.88d | 1.88d |  |  |  | Arc 34 | TE-CRG | S Claudet |
| 98 | 7.8 | Tests CSCM @ 20K |  | 2w | 2013-05-06 | 2013-05-21 | 97 | 2013-01-14 | 2013-01-25 | 2w | 468d | 0d |  | Powering Tests | 80h |  | BE-OP |  |
| 99 | 7.9 | Warm-up (20-80K) |  | 3ed | 2013-05-21 | 2013-05-24 | 98 | 2013-01-25 | 2013-01-28 | 3ed | 2029.88d | 7.88d |  |  |  | Arc 34 | TE-CRG | S Claudet |
| 100 | 7.10 | Leak test identification under vacuum (80K) |  | 3d | 2013-05-27 | 2013-05-29 | 99 | 2013-01-29 | 2013-01-31 | 3d | 467d | 0d |  | Leak test | 24h | Arc 34 | TE-VSC | P Cruikshank |
| 101 | 7.11 | Warm-up (80-300K) |  | 2ew | 2013-05-29 | 2013-06-12 | 100 | 2013-01-31 | 2013-02-14 | 2ew | 2029.88d | 1.88d |  |  |  | Arc 34 | TE-CRG | S Claudet |
| 102 | 7.12 | Vacuum degradation |  | 1d | 2013-06-13 | 2013-06-13 | 101 | 2013-02-14 | 2013-02-15 | 1ed | 467d | 0d |  |  |  | Arc 34 | TE-VSC | P Cruikshank |
| 103 | 7.13 | ELQA |  | 8d | 2013-06-14 | 2013-06-25 | 102, 28 | 2013-02-18 | 2013-02-27 | 8d | 467d | 0d |  | ELQA | 64h | Arc 34 | TE-MPE | G D'Angelo |
| 104 | 7.14 | Measurement of the splices (nQPS) |  | 2d | 2013-06-24 | 2013-06-25 | 103FF | 2013-02-26 | 2013-02-27 | 2d | 470d |  |  |  |  | Arc 34 | TE-MPE | K Dahlerup |
| 105 | 7.15 | Leak test (300K-5Bar)- MSC support |  | 3d | 2013-06-26 | 2013-06-28 | 103 | 2013-02-28 | 2013-03-04 | 3d | 467d | 0d |  | Leak test | 24h | Arc 34 | TE-VSC | P Cruikshank |
| 106 | 7.16 | Arc 34 | milestone | 0d | 2013-06-28 | 2013-06-28 | 105 | 2013-03-04 | 2013-03-04 | 0d | 467d |  |  |  |  | Arc 34 |  | ARC |
| 107 | 7.17 | Start opening of the W bellow (train) | milestone | 0d | 2013-08-20 | 2013-08-20 |  | 2013-05-27 | 2013-05-27 | 0d | 416d | 0d | start no earlier than 2013-08-20 |  |  | Arc 34 | TE-MSC | A Musso |
| 108 | 7.18 | Validation of the leak test (W) | milestone | 0d | 2014-06-20 | 2014-06-20 |  | 2014-01-22 | 2014-01-22 | 1d? | 135d | 0d | start no earlier than 2014-06-20 |  |  | Arc 34 | TE-VSC | P Cruikshank |
| 109 | 7.19 | Preparation of the pressure test |  | 3d | 2014-06-20 | 2014-06-24 | 108 | 2014-01-23 | 2014-01-27 | 3d | 135d | 0d |  |  |  | Arc 34 | TE-CRG | S Claudet |
| 110 | 7.20 | Pressure Test |  | 1ed | 2014-06-24 | 2014-06-25 | 109 | 2014-01-27 | 2014-01-28 | 1ed | 571.88d | 1.88d |  |  |  | Arc 34 | TE-CRG | S Claudet |
| 111 | 7.21 | Leak test identification (300K-10bar) |  | 2d | 2014-06-26 | 2014-06-27 | 110 | 2014-01-29 | 2014-01-30 | 2d | 135d | 0d |  | Leak test | 16h | Arc 34 | TE-VSC | P Cruikshank |
| 112 | 7.22 | Safety valves installation and Purge |  | 5d | 2014-06-30 | 2014-07-04 | 111 | 2014-01-31 | 2014-02-06 | 5d | 135d | 0d |  |  |  | Arc 34 | TE-CRG | S Claudet |
| 113 | 7.23 | ELQA |  | 7d | 2014-06-30 | 2014-07-08 | 112SS | 2014-02-07 | 2014-02-17 | 7d | 135d | 0d |  | ELQA | 56h | Arc 34 | TE-MPE | G D'Angelo |
| 114 | 7.24 | Measurement of the splices (nQPS) |  | 2d | 2014-07-07 | 2014-07-08 | 113FF | 2014-02-14 | 2014-02-17 | 2d | 214d |  |  |  |  | Arc 34 | TE-MPE | K Dahlerup |
| 115 | 7.25 | Flushing |  | 2w | 2014-07-09 | 2014-07-22 | 113 | 2014-02-18 | 2014-03-03 | 2w | 135d | 0d |  |  |  | Arc 34 | TE-CRG | S Claudet |
| 116 | 7.26 | ELQA |  | 2d | 2014-07-23 | 2014-07-24 | 115 | 2014-03-04 | 2014-03-05 | 2d | 135d | 0d |  | ELQA | 16h | Arc 34 | BE-ABP | G D'Angelo |
| 117 | 7.27 | Measurement of the magnets |  | 2w | 2014-10-03 | 2014-10-16 | 119, 194 | 2014-03-21 | 2014-04-03 | 2w | 97d | 0d |  |  |  | Arc 34 | BE-ABP | JF Fuchs |
| 118 | 7.28 | Alignment of the magnets |  | 3w | 2014-10-17 | 2014-11-06 | 117 | 2014-04-04 | 2014-04-28 | 3w | 97d | 0d |  |  |  | Arc 34 | BE-ABP | JF Fuchs |
| 119 | 7.29 | Cool-down Arc (300-80K) |  | 15ed | 2014-07-24 | 2014-08-08 | 116 | 2014-03-05 | 2014-03-20 | 15ed | 577.88d | 0d |  |  |  | Arc 34 | TE-CRG | S Claudet |
| 120 | 7.30 | Cool-down Arc (80-20K) |  | 8ed | 2014-08-08 | 2014-08-16 | 119 | 2014-03-20 | 2014-03-28 | 8ed | 595.88d | 0d |  |  |  | Arc 34 | TE-CRG | S Claudet |
| 121 | 7.31 | Cool-down Arc (20-4.5K) |  | 4ed | 2014-08-16 | 2014-08-20 | 120 | 2014-03-28 | 2014-04-01 | 4ed | 595.88d | 0d |  |  |  | Arc 34 | TE-CRG | S Claudet |
| 122 | 7.32 | Cool-down Arc (4.5-1.9K) |  | 3ed | 2014-08-20 | 2014-08-23 | 121 | 2014-04-01 | 2014-04-04 | 3ed | 595.88d | 4.88d |  |  |  | Arc 34 | TE-CRG | S Claudet |
| 123 | 7.33 | Cryo tuning |  | 1w | 2014-08-25 | 2014-08-29 | 122 | 2014-04-07 | 2014-04-11 | 1w | 140d | 43d |  |  |  | Arc 34 | TE-CRG | S Claudet |
| 124 | 7.34 | ELQA |  | 10d | 2014-10-31 | 2014-11-13 | 123, 118FS-5d | 2014-04-29 | 2014-05-13 | 10d | 97d | 0d |  | ELQA | 80h | Arc 34 | TE-MPE | G D'Angelo |
| 125 | 7.35 | Powering Tests |  | 5w | 2014-11-14 | 2014-12-18 | 124 | 2014-05-14 | 2014-05-14 | 1d? | 97d | 72d |  | Powering Tests | 200h | Arc 34 | BE-OP |  |

Notes:
- 93: DC cables disconnection...
- 103: DC cables disconnection...
- 109: depends on the end of IC activities
- 110: depends on the end of IC activities
- 112: depends on the end of IC activities
- 113: ELQA TP4-A (300K)...
- 116: ELQA TP4-C (installation of the monitoring)...
- 124: ELQA TP4-C (removal of the monitoring)...

| ID | WBS | Task | Type | Duration | Start | Finish | Predecessors | Baseline start | Baseline finish | Baseline duration | Total slack | Free slack | Constraint | Resources | Work | Text1 | Location | fla2 |
| --- | --- | --- | --- | --- | --- | --- | --- | --- | --- | --- | --- | --- | --- | --- | --- | --- | --- | --- |
| 126 | 8 | **Point 4** |  | 1d? | 2012-11-17 | 2012-11-17 |  | 2013-02-28 | 2013-07-10 | 90d |  |  |  |  |  |  |  |  |
| 127 | 8.1 | Cryo maintenance | manual | 1d? | 2012-11-17 | 2012-11-17 |  | 2013-02-28 | 2013-07-10 | 18w |  |  | finish no earlier than 2013-07-10 |  |  | S Claudet | P4 | TE-CRG |
| 128 | 9 | **Sector 45** |  | 443d | 2013-02-11 | 2014-11-19 |  | 2012-11-29 | 2014-06-05 | 366d? |  |  |  |  | 648h |  |  |  |
| 129 | 9.1 | Powering Tests |  | 4ed | 2013-02-11 | 2013-02-15 |  | 2012-11-29 | 2012-12-03 | 4ed | 0d |  | must start on 2013-02-11 | Powering Tests | 96h |  | Arc 45 | BE-OP |
| 130 | 9.2 | RP survey |  | 0.5d | 2013-02-15 | 2013-02-15 | 129 | 2012-12-03 | 2012-12-03 | 0.5d | 438.5d |  |  |  |  | C Tromel | Arc 45 | HSE-RP |
| 131 | 9.3 | ELQA |  | 9d | 2013-02-15 | 2013-02-27 | 129 | 2012-12-10 | 2012-12-20 | 9d | 392d | 0d |  | ELQA | 72h | G D'Angelo | Arc 45 | TE-MPE |
| 132 | 9.4 | Identification Cryo |  | 2ed | 2013-02-27 | 2013-03-01 | 131 | 2012-12-20 | 2012-12-22 | 2ed | 1747.88d | 0d |  |  |  | S Claudet | Arc 45 | TE-CRG |
| 133 | 9.5 | Installation materiel VSC- beam vacuum&insulation vacuum |  | 1ed | 2013-02-28 | 2013-03-01 | 132SS+0.5d |  |  |  | 1884.62d |  |  |  |  | P Cruikshank | Arc 45 | TE-VSC |
| 134 | 9.6 | Warm-up (1.9-5K) |  | 4ed | 2013-03-01 | 2013-03-05 | 132 | 2013-01-07 | 2013-01-11 | 4ed | 1747.88d | 0d |  |  |  | S Claudet | Arc 45 | TE-CRG |
| 135 | 9.7 | Warm-up (5-80K) |  | 1ew | 2013-03-05 | 2013-03-12 | 134 | 2013-01-11 | 2013-01-18 | 1ew | 1747.88d | 1.88d |  |  |  | S Claudet | Arc 45 | TE-CRG |
| 136 | 9.8 | Leak test identification under vacuum (80K) |  | 3d | 2013-03-13 | 2013-03-15 | 135 | 2013-02-01 | 2013-02-05 | 3d | 396d | 0d |  | Leak test | 24h | P Cruikshank | Arc 45 | TE-VSC |
| 137 | 9.9 | Warm-up (80-300K) |  | 2ew | 2013-03-15 | 2013-03-29 | 136 | 2013-01-18 | 2013-02-01 | 2ew | 1753.88d | 10.88d |  |  |  | S Claudet | Arc 45 | TE-CRG |
| 138 | 9.10 | Vacuum degradation |  | 1d | 2013-04-02 | 2013-04-02 | 136, 137 | 2013-02-05 | 2013-02-06 | 1ed | 397d | 5d |  |  |  | P Cruikshank | Arc 45 | TE-VSC |
| 139 | 9.11 | ELQA |  | 8d | 2013-04-10 | 2013-04-19 | 138, 59 | 2013-02-07 | 2013-02-18 | 8d | 392d | 0d |  | ELQA | 64h | G D'Angelo | Arc 45 | TE-MPE |
| 140 | 9.12 | Measurement of the splices (nQPS) |  | 2d | 2013-04-18 | 2013-04-19 | 139FF | 2013-02-15 | 2013-02-18 | 2d | 395d |  |  |  |  | K Dahlerup | Arc 45 | TE-MPE |
| 141 | 9.13 | Leak test (300K-5Bar)- MSC support |  | 3d | 2013-04-22 | 2013-04-24 | 139 | 2013-02-19 | 2013-02-21 | 3d | 392d | 0d |  | Leak test | 24h | P Cruikshank | Arc 45 | TE-VSC |
| 142 | 9.14 | Arc 45 | milestone | 0d | 2013-04-24 | 2013-04-24 | 141 | 2013-02-21 | 2013-02-21 | 0d | 392d |  |  |  |  | ARC | Arc 45 |  |
| 143 | 9.15 | Start opening of the W bellow (train) | milestone | 0d | 2013-09-10 | 2013-09-10 | 107FS+3w | 2013-06-17 | 2013-06-17 | 0d | 416d |  | start no earlier than 2013-09-03 |  |  | A Musso | Arc 45 | TE-MSC |
| 144 | 9.16 | Validation of the leak test (W) | milestone | 0d | 2014-07-18 | 2014-07-18 |  | 2014-02-12 | 2014-02-12 | 1d? | -2d | 0d | start no earlier than 2014-07-18 |  |  | P Cruikshank | Arc 45 | TE-VSC |
| 145 | 9.17 | Constraint R2E: End access commissioning | milestone | 0d | 2014-06-23 | 2014-06-23 |  |  |  |  | 41d |  | start no earlier than 2014-06-23 |  |  |  | Arc 45 |  |
| 146 | 9.18 | Constraint R2E: End Power converter recommissioning | milestone | 0d | 2014-07-02 | 2014-07-02 |  |  |  |  | 34d |  | start no earlier than 2014-07-02 |  |  |  | Arc 45 |  |
| 147 | 9.19 | Constraint R2E: End cryo commissioning | milestone | 0d | 2014-07-09 | 2014-07-09 |  |  |  |  | 29d |  | start no earlier than 2014-07-09 |  |  |  | Arc 45 |  |
| 148 | 9.20 | Preparation of the pressure test |  | 3d | 2014-07-18 | 2014-07-22 | 144 | 2014-02-13 | 2014-02-17 | 3d | -2d | 0d |  |  |  | S Claudet | Arc 45 | TE-CRG |
| 149 | 9.21 | Pressure Test |  | 1ed | 2014-07-22 | 2014-07-23 | 148 | 2014-02-17 | 2014-02-18 | 1ed | -7.12d | 0d |  |  |  | S Claudet | Arc 45 | TE-CRG |
| 150 | 9.22 | Leak test identification (300K-10bar) |  | 2d | 2014-07-24 | 2014-07-25 | 149 | 2014-02-19 | 2014-02-20 | 2d | -3d | 0d |  | Leak test | 16h | P Cruikshank | Arc 45 | TE-VSC |
| 151 | 9.23 | Safety valves installation and Purge |  | 5d | 2014-07-28 | 2014-08-01 | 150 | 2014-02-21 | 2014-02-27 | 5d | -3d | 0d |  |  |  | S Claudet | Arc 45 | TE-CRG |
| 152 | 9.24 | ELQA |  | 7d | 2014-07-28 | 2014-08-05 | 151SS | 2014-02-28 | 2014-03-10 | 7d | -3d | 0d |  | ELQA | 56h | G D'Angelo | Arc 45 | TE-MPE |
| 153 | 9.25 | Measurement of the splices (nQPS) |  | 2d | 2014-08-04 | 2014-08-05 | 152FF | 2014-03-07 | 2014-03-10 | 2d | 75d |  |  |  |  | K Dahlerup | Arc 45 | TE-MPE |
| 154 | 9.26 | Flushing |  | 2ew | 2014-08-05 | 2014-08-19 | 152 | 2014-03-11 | 2014-03-24 | 2w | -13.12d | 0d |  |  |  | S Claudet | Arc 45 | TE-CRG |
| 155 | 9.27 | ELQA |  | 2d | 2014-08-20 | 2014-08-21 | 154 | 2014-03-25 | 2014-03-26 | 2d | -3d | 0d |  | ELQA | 16h | G D'Angelo | Arc 45 | BE-ABP |
| 156 | 9.28 | Measurement of the magnets |  | 2w | 2015-02-17 | 2015-03-02 | 158, 82 | 2014-04-11 | 2014-04-28 | 2w | -118d | 0d |  |  |  | JF Fuchs | Arc 45 | BE-ABP |
| 157 | 9.29 | Alignment of the magnets |  | 3w | 2015-03-03 | 2015-03-23 | 156 | 2014-04-29 | 2014-05-20 | 3w | -118d | 0d |  |  |  | JF Fuchs | Arc 45 | BE-ABP |
| 158 | 9.30 | Cool-down Arc (300-80K) |  | 15ed | 2014-08-21 | 2014-09-05 | 155, 145, 146, 147 | 2014-03-26 | 2014-04-10 | 15ed | -7.12d | 0d |  |  |  | S Claudet | Arc 45 | TE-CRG |
| 159 | 9.31 | Cool-down Arc (80-20K) |  | 8ed | 2014-09-05 | 2014-09-13 | 158 | 2014-04-10 | 2014-04-18 | 8ed | 13.88d | 0d |  |  |  | S Claudet | Arc 45 | TE-CRG |
| 160 | 9.32 | Cool-down Arc (20-4.5K) |  | 4ed | 2014-09-13 | 2014-09-17 | 159 | 2014-04-18 | 2014-04-22 | 4ed | 13.88d | 0d |  |  |  | S Claudet | Arc 45 | TE-CRG |
| 161 | 9.33 | Cool-down Arc (4.5-1.9K) |  | 3ed | 2014-09-17 | 2014-09-20 | 160 | 2014-04-22 | 2014-04-25 | 3ed | 13.88d | 4.88d |  |  |  | S Claudet | Arc 45 | TE-CRG |
| 162 | 9.34 | Cryo tuning |  | 1w | 2014-09-22 | 2014-09-26 | 161 | 2014-04-28 | 2014-05-05 | 1w | 3d |  |  |  |  | S Claudet | Arc 45 | TE-CRG |
| 163 | 9.35 | ELQA |  | 10d | 2015-03-17 | 2015-03-30 | 162, 157FS-5d | 2014-05-21 | 2014-06-04 | 10d | -118d | 0d |  | ELQA | 80h | G D'Angelo | Arc 45 | TE-MPE |
| 164 | 9.36 | Powering Tests |  | 5w | 2015-03-31 | 2015-05-04 | 163 | 2014-06-05 | 2014-06-05 | 1d? | -118d | 0d |  | Powering Tests | 200h |  | Arc 45 | BE-OP |

Notes:
- 131: DC cables disconnection...
- 139: DC cables disconnection...
- 148: depends on the end of IC activities
- 149: depends on the end of IC activities
- 151: depends on the end of IC activities
- 152: ELQA TP4-A (300K)...
- 155: ELQA TP4-C (installation of the monitoring)...
- 163: ELQA TP4-C (removal of the monitoring)...

| ID | WBS | Task | Type | Duration | Start | Finish | Predecessors | Baseline start | Baseline finish | Baseline duration | Total slack | Free slack | Constraint | Resources | Work | Location | fla2 | Text1 |
| --- | --- | --- | --- | --- | --- | --- | --- | --- | --- | --- | --- | --- | --- | --- | --- | --- | --- | --- |
| 165 | 10 | **Sector 56** |  | 439d | 2013-02-11 | 2014-11-13 |  | 2012-11-17 | 2013-12-20 | 269d? | 0d |  |  |  | 632h |  |  |  |
| 166 | 10.1 | Powering Tests |  | 4ed | 2013-02-11 | 2013-02-15 |  | 2012-11-17 | 2012-11-21 | 4ed | 0d |  | must start on 2013-02-11 | Powering Tests | 96h | Arc 56 | BE-OP |  |
| 167 | 10.2 | RP survey |  | 0.5d | 2013-02-15 | 2013-02-15 | 166 | 2012-11-21 | 2012-11-21 | 0.5d | 557.5d |  |  |  |  | Arc 56 | HSE-RP | C Tromel |
| 168 | 10.3 | ELQA |  | 9d | 2013-02-15 | 2013-02-27 | 166 | 2012-11-21 | 2012-11-30 | 9ed | 440d | 0d |  | ELQA | 72h | Arc 56 | TE-MPE | G D'Angelo |
| 169 | 10.4 | Identification Cryo |  | 2d | 2013-02-28 | 2013-03-01 | 168 | 2012-11-30 | 2012-12-02 | 2ed | 440d | 0d |  |  |  | Arc 56 | TE-CRG | S Claudet |
| 170 | 10.5 | Installation materiel VSC- beam vacuum&insulation vacuum |  | 1d | 2013-02-28 | 2013-03-01 | 169SS+0.5d |  |  |  | 547.5d |  |  |  |  | Arc 56 |  |  |
| 171 | 10.6 | Warm-up (1.9-5K) |  | 4ed | 2013-03-01 | 2013-03-05 | 169 | 2012-12-02 | 2012-12-06 | 4ed | 1933.88d | 0d |  |  |  | Arc 56 | TE-CRG | S Claudet |
| 172 | 10.7 | Warm-up (5-80K) |  | 1ew | 2013-03-05 | 2013-03-12 | 171 | 2012-12-06 | 2012-12-13 | 1ew | 1933.88d | 1.88d |  |  |  | Arc 56 | TE-CRG | S Claudet |
| 173 | 10.8 | Leak test identification under vacuum (80K) |  | 3d | 2013-03-13 | 2013-03-15 | 172 | 2012-12-13 | 2012-12-17 | 3d | 440d | 0d |  | Leak test | 24h | Arc 56 | TE-VSC | P Cruikshank |
| 174 | 10.9 | Warm-up (80-300K) |  | 2ew | 2013-03-15 | 2013-03-29 | 173 | 2012-12-17 | 2012-12-31 | 2ew | 1939.88d | 10.88d |  |  |  | Arc 56 | TE-CRG | S Claudet |
| 175 | 10.10 | Vacuum degradation |  | 1d | 2013-04-02 | 2013-04-02 | 174 | 2013-01-04 | 2013-01-05 | 1ed | 441d | 0d |  |  |  | Arc 56 | TE-VSC | P Cruikshank |
| 176 | 10.11 | ELQA |  | 8d | 2013-04-03 | 2013-04-12 | 175, 20 | 2013-01-07 | 2013-01-15 | 8ed | 441d | 0d |  | ELQA | 64h | Arc 56 | TE-MPE | G D'Angelo |
| 177 | 10.12 | Measurement of the splices (nQPS) |  | 2d | 2013-04-11 | 2013-04-12 | 176FF | 2013-01-11 | 2013-01-15 | 2d | 519d |  |  |  |  | Arc 56 | TE-MPE | K Dahlerup |
| 178 | 10.13 | Leak test (300K-5Bar)- MSC support |  | 3d | 2013-04-15 | 2013-04-17 | 176 | 2013-01-09 | 2013-01-11 | 3d | 441d | 0d |  | Leak test | 24h | Arc 56 | TE-VSC | P Cruikshank |
| 179 | 10.14 | Arc 56 | milestone | 0d | 2013-04-17 | 2013-04-17 | 178 |  |  |  | 516d |  |  |  |  | Arc 56 |  | ARC |
| 180 | 10.15 | Start opening of the W bellow (train) | milestone | 0d | 2013-04-17 | 2013-04-17 | 176, 178 | 2013-01-15 | 2013-01-15 | 0d | 441d | 0d |  |  |  | Arc 56 | TE-MSC | A Musso |
| 181 | 10.16 | Validation of the leak test (W) | milestone | 0d | 2013-10-23 | 2013-10-23 |  | 2013-09-03 | 2013-09-03 | 1d? | 266d | 0d | start no earlier than 2013-10-23 |  |  | Arc 56 | TE-VSC | P Cruikshank |
| 182 | 10.17 | Constraint R2E: End access commissioning | milestone | 0d | 2014-06-23 | 2014-06-23 |  |  |  |  | 226d |  | start no earlier than 2014-06-23 |  |  | Arc 56 |  |  |
| 183 | 10.18 | Constraint R2E: End Power converter recommissioning | milestone | 0d | 2014-07-02 | 2014-07-02 |  |  |  |  | 219d |  | start no earlier than 2014-07-02 |  |  | Arc 56 |  |  |
| 184 | 10.19 | Constraint R2E: End cryo commissioning | milestone | 0d | 2014-07-09 | 2014-07-09 |  |  |  |  | 118d | 0d | start no earlier than 2014-07-09 |  |  | Arc 56 |  |  |
| 185 | 10.20 | Preparation of the pressure test |  | 3d | 2013-10-23 | 2013-10-25 | 181 | 2013-09-04 | 2013-09-09 | 3d | 266d | 0d |  |  |  | Arc 56 | TE-CRG | S Claudet |
| 186 | 10.21 | Pressure Test |  | 1ed | 2013-10-25 | 2013-10-26 | 185 | 2013-09-09 | 2013-09-10 | 1ed | 1180.88d | 4.88d |  |  |  | Arc 56 | TE-CRG | S Claudet |
| 187 | 10.22 | Leak test identification 300K-10bar) |  | 2d | 2013-10-28 | 2013-10-29 | 186 | 2013-09-11 | 2013-09-12 | 2d | 266d | 0d |  | Leak test | 16h | Arc 56 | TE-VSC | P Cruikshank |
| 188 | 10.23 | Safety valves installation and Purge |  | 5d | 2013-10-30 | 2013-11-05 | 187 | 2013-09-13 | 2013-09-19 | 5d | 266d | 0d |  |  |  | Arc 56 | TE-CRG | S Claudet |
| 189 | 10.24 | ELQA |  | 7d | 2013-10-30 | 2013-11-07 | 188SS | 2013-09-20 | 2013-09-30 | 7d | 266d | 0d |  | ELQA | 56h | Arc 56 | TE-MPE | G D'Angelo |
| 190 | 10.25 | Measurement of the splices (nQPS) |  | 2d | 2013-11-06 | 2013-11-07 | 189FF | 2013-09-27 | 2013-09-30 | 2d | 374d |  |  |  |  | Arc 56 | TE-MPE | K Dahlerup |
| 191 | 10.26 | Flushing |  | 2w | 2013-11-08 | 2013-11-21 | 189 | 2013-10-01 | 2013-10-14 | 2w | 266d | 0d |  |  |  | Arc 56 | TE-CRG | S Claudet |
| 192 | 10.27 | ELQA |  | 2d | 2013-11-22 | 2013-11-25 | 191 | 2013-10-15 | 2013-10-16 | 2d | 266d | 148d |  |  |  | Arc 56 | BE-ABP | G D'Angelo |
| 193 | 10.28 | Measurement of the magnets |  | 2w | 2014-08-28 | 2014-09-11 | 196, 46 | 2013-11-01 | 2013-11-14 | 2w | 97d | 0d |  |  |  | Arc 56 | BE-ABP | JF Fuchs |
| 194 | 10.29 | Alignment of the magnets |  | 3w | 2014-09-12 | 2014-10-02 | 193 | 2013-11-15 | 2013-12-05 | 3w | 97d | 0d |  |  |  | Arc 56 | BE-ABP | JF Fuchs |
| 195 | 10.30 | ELQA |  | 1w | 2014-07-02 | 2014-07-08 | 196SS-1w |  |  |  | 214d |  |  |  |  | Arc 56 | BE-ABP | G D'Angelo |
| 196 | 10.31 | Cool-down Arc (300-80K) |  | 21ed | 2014-07-09 | 2014-07-30 | 192, 184 | 2013-10-16 | 2013-10-31 | 15ed | 501d | 0d |  |  |  | Arc 56 | TE-CRG | S Claudet |
| 197 | 10.32 | Cool-down Arc (80-20K) |  | 8ed | 2014-07-30 | 2014-08-07 | 196 | 2013-10-31 | 2013-11-08 | 8ed | 624d | 0d |  |  |  | Arc 56 | TE-CRG | S Claudet |
| 198 | 10.33 | Cool-down Arc (20-4.5K) |  | 4ed | 2014-08-07 | 2014-08-11 | 197 | 2013-11-08 | 2013-11-12 | 4ed | 624d | 0d |  |  |  | Arc 56 | TE-CRG | S Claudet |
| 199 | 10.34 | Cool-down Arc (4.5-1.9K) |  | 3ed | 2014-08-11 | 2014-08-14 | 198 | 2013-11-12 | 2013-11-15 | 3ed | 624d | 0d |  |  |  | Arc 56 | TE-CRG | S Claudet |
| 200 | 10.35 | Cryo tuning |  | 1w | 2014-08-14 | 2014-08-20 | 199 | 2013-11-18 | 2013-11-22 | 1w | 147d | 25d |  |  |  | Arc 56 | TE-CRG | S Claudet |
| 201 | 10.36 | ELQA |  | 10d | 2014-09-26 | 2014-10-09 | 200, 194FS-5d | 2013-12-06 | 2013-12-19 | 10d | 122d | 0d |  | ELQA | 80h | Arc 56 | TE-MPE | G D'Angelo |
| 202 | 10.37 | Powering Tests |  | 5w | 2014-10-10 | 2014-11-13 | 201 | 2013-12-20 | 2013-12-20 | 1d? | 122d |  |  | Powering Tests | 200h | Arc 56 | BE-OP |  |

Notes:
- 168: DC cables disconnection...
- 176: DC cables disconnection...
- 185: depends on the end of IC activities
- 186: depends on the end of IC activities
- 188: depends on the end of IC activities
- 189: ELQA TP4-A (300K)...
- 192: ELQA TP4-C (installation of the monitoring)...
- 201: ELQA TP4-C (removal of the monitoring)...

| ID | WBS | Task | Type | Duration | Start | Finish | Predecessors | Baseline start | Baseline finish | Baseline duration | Total slack | Free slack | Constraint | Resources | Work | Text1 | Location | fla2 |
| --- | --- | --- | --- | --- | --- | --- | --- | --- | --- | --- | --- | --- | --- | --- | --- | --- | --- | --- |
| 203 | 11 | **Point 6** |  | 30d? | 2013-05-03 | 2013-06-17 |  | 2013-01-24 | 2013-07-26 | 127d | 0d |  |  |  |  |  |  |  |
| 204 | 11.1 | Helium control |  | 6w | 2013-05-03 | 2013-06-17 | 176, 217 | 2013-01-24 | 2013-03-06 | 6w | 476d | 0d | finish no earlier than 2013-03-06 |  |  | S Claudet | P6 | TE-CRG |
| 205 | 11.2 | Cryo maintenance | manual | 1d? | 2013-05-03 | 2013-05-03 |  | 2013-03-04 | 2013-07-26 | 100d |  |  | finish no earlier than 2013-07-26 |  |  | S Claudet | P6 | TE-CRG |
| 206 | 12 | **Sector 67** |  | 364d | 2013-02-15 | 2014-08-05 |  | 2012-11-17 | 2014-01-24 | 284d? | 194d |  |  |  | 648h |  |  |  |
| 207 | 12.1 | Powering Tests |  | 4ed | 2013-02-15 | 2013-02-19 | 129 | 2012-11-17 | 2012-11-21 | 4ed | 1761d | 0d |  | Powering Tests | 96h |  | Arc 67 | BE-OP |
| 208 | 12.2 | RP survey |  | 0.5d | 2013-02-19 | 2013-02-19 | 207 | 2012-11-21 | 2012-11-21 | 0.5d | 555.5d |  |  |  |  | C Tromel | Arc 67 | HSE-RP |
| 209 | 12.3 | ELQA |  | 9d | 2013-02-28 | 2013-03-12 | 207, 131 | 2012-11-21 | 2012-11-30 | 9ed | 392d | 0d |  | ELQA | 72h | G D'Angelo | Arc 67 | TE-MPE |
| 210 | 12.4 | Identification Cryo |  | 2d | 2013-03-13 | 2013-03-14 | 209 | 2012-11-30 | 2012-12-02 | 2ed | 479d | 0d |  |  |  | S Claudet | Arc 67 | TE-CRG |
| 211 | 12.5 | Installation materiel VSC- beam vacuum&insulation vacuum |  | 1d | 2013-03-13 | 2013-03-14 | 210SS+0.5d |  |  |  | 538.5d |  |  |  |  | P Cruikshank | Arc 67 | TE-VSC |
| 212 | 12.6 | Warm-up (1.9-5K) |  | 4ed | 2013-03-14 | 2013-03-18 | 210 | 2012-12-02 | 2012-12-06 | 4ed | 2098.88d | 0d |  |  |  | S Claudet | Arc 67 | TE-CRG |
| 213 | 12.7 | Warm-up (5-80K) |  | 1ew | 2013-03-18 | 2013-03-25 | 212 | 2012-12-06 | 2012-12-13 | 1ew | 2098.88d | 1.88d |  |  |  | S Claudet | Arc 67 | TE-CRG |
| 214 | 12.8 | Leak test identification under vacuum (80K) |  | 3d | 2013-03-26 | 2013-03-28 | 213 | 2012-12-13 | 2012-12-17 | 3d | 479d | 0d |  | Leak test | 24h | P Cruikshank | Arc 67 | TE-VSC |
| 215 | 12.9 | Warm-up (80-300K) |  | 2ew | 2013-03-28 | 2013-04-11 | 214 | 2012-12-17 | 2012-12-31 | 2ew | 2098.88d | 1.88d |  |  |  | S Claudet | Arc 67 | TE-CRG |
| 216 | 12.10 | Vacuum degradation |  | 1d | 2013-04-12 | 2013-04-12 | 215 | 2013-01-04 | 2013-01-05 | 1ed | 481d | 5d |  |  |  | P Cruikshank | Arc 67 | TE-VSC |
| 217 | 12.11 | ELQA |  | 8d | 2013-04-22 | 2013-05-02 | 216, 139 | 2013-01-14 | 2013-01-23 | 8d | 476d | 0d |  | ELQA | 64h | G D'Angelo | Arc 67 | TE-MPE |
| 218 | 12.12 | Measurement of the splices (nQPS) |  | 2d | 2013-04-30 | 2013-05-02 | 217FF | 2013-01-22 | 2013-01-23 | 2d | 506d |  |  |  |  | K Dahlerup | Arc 67 | TE-MPE |
| 219 | 12.13 | Leak test (300K-5Bar)- MSC support |  | 3d | 2013-05-03 | 2013-05-07 | 217 | 2013-01-24 | 2013-01-28 | 3d | 503d | 0d |  | Leak test | 24h | P Cruikshank | Arc 67 | TE-VSC |
| 220 | 12.14 | Arc 67 | milestone | 0d | 2013-05-07 | 2013-05-07 | 219 | 2013-01-28 | 2013-01-28 | 0d | 503d |  |  |  |  | ARC | Arc 67 |  |
| 221 | 12.15 | Start opening of the W bellow (train) | milestone | 0d | 2013-05-10 | 2013-05-10 | 180FS+3w | 2013-02-04 | 2013-02-04 | 0d | 441d | 0d |  |  |  | A Musso | Arc 67 | TE-MSC |
| 222 | 12.16 | Validation of the leak test (W) | milestone | 0d | 2013-11-20 | 2013-11-20 |  | 2013-09-25 | 2013-09-25 | 1d? | 81d | 0d | start no earlier than 2013-11-20 |  |  | P Cruikshank | Arc 67 | TE-VSC |
| 223 | 12.17 | Constraint R2E: End access commissioning | milestone | 0d | 2014-04-30 | 2014-04-30 |  |  |  |  | 262d |  | start no earlier than 2014-04-30 |  |  |  | Arc 67 |  |
| 224 | 12.18 | Constraint R2E: End Power converter recommissioning | milestone | 0d | 2014-05-07 | 2014-05-07 |  |  |  |  | 258d |  | start no earlier than 2014-05-07 |  |  |  | Arc 67 |  |
| 225 | 12.19 | Constraint R2E: End cryo commissioning | milestone | 0d | 2014-04-18 | 2014-04-18 |  |  |  |  | 9d |  | start no earlier than 2014-04-18 |  |  |  | Arc 67 |  |
| 226 | 12.20 | Constraint R2E: End vacuum commissioning | milestone | 0d | 2014-05-05 | 2014-05-05 |  |  |  |  | 0d |  | start no earlier than 2014-05-05 |  |  |  | Arc 67 |  |
| 227 | 12.21 | Preparation of the pressure test |  | 3d | 2013-11-20 | 2013-11-22 | 222 | 2013-09-26 | 2013-09-30 | 3d | 81d | 0d |  |  |  | S Claudet | Arc 67 | TE-CRG |
| 228 | 12.22 | Pressure Test |  | 1ed | 2013-11-22 | 2013-11-23 | 227 | 2013-09-30 | 2013-10-01 | 1ed | 388.88d | 4.88d |  |  |  | S Claudet | Arc 67 | TE-CRG |
| 229 | 12.23 | Leak test identification (300K-10bar) |  | 2d | 2013-11-25 | 2013-11-26 | 228 | 2013-10-02 | 2013-10-03 | 2d | 82d | 0d |  | Leak test | 16h | P Cruikshank | Arc 67 | TE-VSC |
| 230 | 12.24 | Safety valves installation and Purge |  | 5d | 2013-11-27 | 2013-12-03 | 229 | 2013-10-04 | 2013-10-10 | 5d | 82d | 0d |  |  |  | S Claudet | Arc 67 | TE-CRG |
| 231 | 12.25 | ELQA |  | 7d | 2013-11-27 | 2013-12-05 | 230SS | 2013-10-11 | 2013-10-21 | 7d | 82d | 0d |  | ELQA | 56h | G D'Angelo | Arc 67 | TE-MPE |
| 232 | 12.26 | Measurement of the splices (nQPS) |  | 2d | 2013-12-04 | 2013-12-05 | 231FF | 2013-10-18 | 2013-10-21 | 2d | 354d |  |  |  |  | K Dahlerup | Arc 67 | TE-MPE |
| 233 | 12.27 | Flushing |  | 2w | 2014-01-06 | 2014-01-17 | 231 | 2013-10-22 | 2013-11-04 | 2w | 71d | 0d | start no earlier than 2014-01-06 |  |  | S Claudet | Arc 67 | TE-CRG |
| 234 | 12.28 | ELQA |  | 2d | 2014-01-20 | 2014-01-21 | 233 | 2013-11-05 | 2013-11-06 | 2d | 71d |  |  | ELQA | 16h | G D'Angelo | Arc 67 | BE-ABP |
| 235 | 12.29 | Measurement of the magnets |  | 2w | 2014-05-20 | 2014-06-03 | 238 | 2013-11-22 | 2013-12-05 | 2w | 0d |  |  |  |  | JF Fuchs | Arc 67 | BE-ABP |
| 236 | 12.30 | Alignment of the magnets |  | 3w | 2014-06-04 | 2014-06-24 | 235 | 2013-12-06 | 2014-01-09 | 3w | 0d |  |  |  |  | JF Fuchs | Arc 67 | BE-ABP |
| 237 | 12.31 | ELQA |  | 1w | 2014-04-25 | 2014-05-02 | 238SS-1w |  |  |  | 260d |  |  |  |  |  | Arc 67 |  |
| 238 | 12.32 | Cool-down Arc (300-80K) |  | 15ed | 2014-05-05 | 2014-05-20 | 234, 225, 226 | 2013-11-06 | 2013-11-21 | 15ed | 0d |  |  |  |  | S Claudet | Arc 67 | TE-CRG |
| 239 | 12.33 | Cool-down Arc (80-20K) |  | 8d | 2014-05-20 | 2014-05-30 | 238 | 2013-11-21 | 2013-11-29 | 8ed | 195d | 0d |  |  |  | S Claudet | Arc 67 | TE-CRG |
| 240 | 12.34 | Cool-down Arc (20-4.5K) |  | 4ed | 2014-05-30 | 2014-06-03 | 239 | 2013-11-29 | 2013-12-03 | 4ed | 829.88d | 0d |  |  |  | S Claudet | Arc 67 | TE-CRG |
| 241 | 12.35 | Cool-down Arc (4.5-1.9K) |  | 3ed | 2014-06-03 | 2014-06-06 | 240 | 2013-12-03 | 2013-12-06 | 3ed | 829.88d | 7.88d |  |  |  | S Claudet | Arc 67 | TE-CRG |
| 242 | 12.36 | Cryo tuning |  | 1w | 2014-06-09 | 2014-06-13 | 241 | 2013-12-09 | 2013-12-13 | 1w | 195d | 2d |  |  |  | S Claudet | Arc 67 | TE-CRG |
| 243 | 12.37 | ELQA |  | 10d | 2014-06-18 | 2014-07-01 | 242, 236FS-5d | 2014-01-10 | 2014-01-23 | 10d | 193d | 0d |  | ELQA | 80h | G D'Angelo | Arc 67 | TE-MPE |
| 244 | 12.38 | Powering Tests |  | 5w | 2014-07-02 | 2014-08-05 | 243 | 2014-01-24 | 2014-01-24 | 1d? | 193d | 3d |  | Powering Tests | 200h |  | Arc 67 | BE-OP |

Notes:
- 209: DC cables disconnection...
- 217: DC cables disconnection...
- 227: depends on the end of IC activities
- 228: depends on the end of IC activities
- 230: depends on the end of IC activities
- 231: ELQA TP4-A (300K)...
- 234: ELQA TP4-C (installation of the monitoring)...
- 243: ELQA TP4-C (removal of the monitoring)...

| ID | WBS | Task | Type | Duration | Start | Finish | Predecessors | Baseline start | Baseline finish | Baseline duration | Total slack | Free slack | Constraint | Resources | Work | Location | fla2 | Text1 |
| --- | --- | --- | --- | --- | --- | --- | --- | --- | --- | --- | --- | --- | --- | --- | --- | --- | --- | --- |
| 245 | 13 | **Sector 78** |  | 367d | 2013-02-15 | 2014-08-08 |  | 2012-11-21 | 2014-02-14 | 297d? | 191d |  |  |  | 656h |  |  |  |
| 246 | 13.1 | Powering Tests |  | 4ed | 2013-02-15 | 2013-02-19 | 166 | 2012-11-21 | 2012-11-25 | 4ed | 1980d | 0d |  | Powering Tests | 96h | Arc 78 | BE-OP |  |
| 247 | 13.2 | RP survey |  | 0.5d | 2013-02-19 | 2013-02-19 | 246 | 2012-11-26 | 2012-11-26 | 0.5d | 555.5d |  |  |  |  | Arc 78 | HSE-RP | C Tromel |
| 248 | 13.3 | ELQA |  | 9d | 2013-02-28 | 2013-03-12 | 246, 168 | 2012-11-26 | 2012-12-06 | 9d | 445d | 0d |  | ELQA | 72h | Arc 78 | TE-MPE | G D'Angelo |
| 249 | 13.4 | Identification Cryo |  | 2d | 2013-03-13 | 2013-03-14 | 248 | 2012-12-06 | 2012-12-08 | 2ed | 491d | 0d |  |  |  | Arc 78 | TE-CRG | S Claudet |
| 250 | 13.5 | Installation materiel VSC- beam vacuum&insulation vacuum |  | 1d | 2013-03-13 | 2013-03-14 | 249SS+0.5d |  |  |  | 538.5d |  |  |  |  | Arc 78 | TE-VSC | P Cruikshank |
| 251 | 13.6 | Warm-up (1.9-5K) |  | 3ed | 2013-03-14 | 2013-03-17 | 249 | 2012-12-08 | 2012-12-11 | 3ed | 2149.88d | 0d |  |  |  | Arc 78 | TE-CRG | S Claudet |
| 252 | 13.7 | Warm-up (5-80K) |  | 1ew | 2013-03-17 | 2013-03-24 | 251 | 2012-12-11 | 2012-12-18 | 1ew | 2149.88d | 1.88d |  |  |  | Arc 78 | TE-CRG | S Claudet |
| 253 | 13.8 | Leak test identification under vacuum (80K) |  | 2d | 2013-03-25 | 2013-03-26 | 252 | 2012-12-19 | 2012-12-21 | 3d | 492d | 0d |  | Leak test [200%] | 32h | Arc 78 | TE-VSC | P Cruikshank |
| 254 | 13.9 | Warm-up (80-300K) |  | 2ew | 2013-03-26 | 2013-04-09 | 253 | 2012-12-21 | 2013-01-04 | 2ew | 2149.88d | 1.88d |  |  |  | Arc 78 | TE-CRG | S Claudet |
| 255 | 13.10 | Vacuum degradation |  | 1d | 2013-04-10 | 2013-04-10 | 254 | 2013-01-04 | 2013-01-05 | 1ed | 494d | 11d |  |  |  | Arc 78 | TE-VSC | P Cruikshank |
| 256 | 13.11 | ELQA |  | 8d | 2013-04-26 | 2013-05-08 | 255, 254, 93 | 2013-01-07 | 2013-01-15 | 8ed | 483d | 0d |  | ELQA | 64h | Arc 78 | TE-MPE | G D'Angelo |
| 257 | 13.12 | Measurement of the splices (nQPS) |  | 2d | 2013-05-07 | 2013-05-08 | 256FF | 2013-01-11 | 2013-01-15 | 2d | 502d |  |  |  |  | Arc 78 | TE-MPE | K Dahlerup |
| 258 | 13.13 | Leak test (300K-5Bar)- MSC support |  | 3d | 2013-05-10 | 2013-05-14 | 256 | 2013-01-09 | 2013-01-11 | 3d | 499d | 0d |  | Leak test | 24h | Arc 78 | TE-VSC | P Cruikshank |
| 259 | 13.14 | Arc 78 | milestone | 0d | 2013-05-14 | 2013-05-14 | 258 | 2013-01-15 | 2013-01-15 | 0d | 499d |  |  |  |  | Arc 78 |  | ARC |
| 260 | 13.15 | Start opening of the W bellow (train) | milestone | 0d | 2013-06-03 | 2013-06-03 | 221FS+3w | 2013-02-25 | 2013-02-25 | 0d | 441d | 0d |  |  |  | Arc 78 | TE-MSC | A Musso |
| 261 | 13.16 | Validation of the leak test (W) | milestone | 0d | 2013-12-18 | 2013-12-18 |  | 2013-10-16 | 2013-10-16 | 1d? | 179d | 3d | start no earlier than 2013-12-18 |  |  | Arc 78 | TE-VSC | P Cruikshank |
| 262 | 13.17 | Constraint R2E: End access commissioning | milestone | 0d | 2014-04-30 | 2014-04-30 |  |  |  |  | 262d |  | start no earlier than 2014-04-30 |  |  | Arc 78 |  |  |
| 263 | 13.18 | Constraint R2E: End Power converter recommissioning | milestone | 0d | 2014-05-07 | 2014-05-07 |  |  |  |  | 258d |  | start no earlier than 2014-05-07 |  |  | Arc 78 |  |  |
| 264 | 13.19 | Constraint R2E: End cryo commissioning | milestone | 0d | 2014-04-18 | 2014-04-18 |  |  |  |  | 127d | 12d | start no earlier than 2014-04-18 |  |  | Arc 78 |  |  |
| 265 | 13.20 | Constraint R2E: End vacuum commissioning | milestone | 0d | 2014-05-08 | 2014-05-08 |  |  |  |  | 115d | 0d | start no earlier than 2014-05-08 |  |  | Arc 78 |  |  |
| 266 | 13.21 | Preparation of the pressure test |  | 3d | 2014-01-06 | 2014-01-08 | 261 | 2013-10-17 | 2013-10-21 | 3d | 176d | 0d | start no earlier than 2014-01-06 |  |  | Arc 78 | TE-CRG | S Claudet |
| 267 | 13.22 | Pressure Test |  | 1ed | 2014-01-08 | 2014-01-09 | 266 | 2013-10-21 | 2013-10-22 | 1ed | 757.88d | 1.88d |  |  |  | Arc 78 | TE-CRG | S Claudet |
| 268 | 13.23 | Leak test identification (300K-10bar) |  | 2d | 2014-01-10 | 2014-01-13 | 267 | 2013-10-23 | 2013-10-24 | 2d | 176d | 0d |  | Leak test | 16h | Arc 78 | TE-VSC | P Cruikshank |
| 269 | 13.24 | Safety valves installation and Purge |  | 5d | 2014-01-14 | 2014-01-20 | 268 | 2013-10-25 | 2013-10-31 | 5d | 176d | 0d |  |  |  | Arc 78 | TE-CRG | S Claudet |
| 270 | 13.25 | ELQA |  | 7d | 2014-01-14 | 2014-01-22 | 269SS | 2013-11-01 | 2013-11-11 | 7d | 176d | 0d |  | ELQA | 56h | Arc 78 | TE-MPE | G D'Angelo |
| 271 | 13.26 | Measurement of the splices (nQPS) |  | 2d | 2014-01-21 | 2014-01-22 | 270FF | 2013-11-08 | 2013-11-11 | 2d | 330d |  |  |  |  | Arc 78 | TE-MPE | K Dahlerup |
| 272 | 13.27 | Flushing |  | 2w | 2014-01-23 | 2014-02-05 | 270 | 2013-11-12 | 2013-11-25 | 2w | 176d | 0d |  |  |  | Arc 78 | TE-CRG | S Claudet |
| 273 | 13.28 | ELQA |  | 2d | 2014-02-06 | 2014-02-07 | 272 | 2013-11-26 | 2013-11-27 | 2d | 176d | 61d |  | ELQA | 16h | Arc 78 | BE-ABP | G D'Angelo |
| 274 | 13.29 | Measurement of the magnets |  | 2w | 2014-05-23 | 2014-06-06 | 277 | 2013-12-13 | 2014-01-09 | 2w | 115d | 0d |  |  |  | Arc 78 | BE-ABP | JF Fuchs |
| 275 | 13.30 | Alignment of the magnets |  | 3w | 2014-06-09 | 2014-06-27 | 274 | 2014-01-10 | 2014-01-30 | 3w | 115d | 0d |  |  |  | Arc 78 | BE-ABP | JF Fuchs |
| 276 | 13.31 | ELQA |  | 1w | 2014-04-30 | 2014-05-07 | 277SS-1w |  |  |  | 257d |  |  |  |  | Arc 78 | BE-ABP | G D'Angelo |
| 277 | 13.32 | Cool-down Arc (300-80K) |  | 15ed | 2014-05-08 | 2014-05-23 | 273, 264, 265 | 2013-11-27 | 2013-12-12 | 15ed | 495d | 0d |  |  |  | Arc 78 | TE-CRG | S Claudet |
| 278 | 13.33 | Cool-down Arc (80-20K) |  | 8ed | 2014-05-23 | 2014-05-31 | 277 | 2013-12-12 | 2013-12-20 | 8ed | 828d | 0d |  |  |  | Arc 78 | TE-CRG | S Claudet |
| 279 | 13.34 | Cool-down Arc (20-4.5K) |  | 4ed | 2014-05-31 | 2014-06-04 | 278 | 2013-12-20 | 2013-12-24 | 4ed | 828d | 0d |  |  |  | Arc 78 | TE-CRG | S Claudet |
| 280 | 13.35 | Cool-down Arc (4.5-1.9K) |  | 3ed | 2014-06-04 | 2014-06-07 | 279 | 2013-12-24 | 2013-12-27 | 3ed | 828d | 6d |  |  |  | Arc 78 | TE-CRG | S Claudet |
| 281 | 13.36 | Cryo tuning |  | 1w | 2014-06-09 | 2014-06-13 | 280 | 2014-01-06 | 2014-01-10 | 1w | 195d | 5d |  |  |  | Arc 78 | TE-CRG | S Claudet |
| 282 | 13.37 | ELQA |  | 10d | 2014-06-23 | 2014-07-04 | 281, 275FS-5d | 2014-01-31 | 2014-02-13 | 10d | 190d | 0d |  | ELQA | 80h | Arc 78 | TE-MPE | G D'Angelo |
| 283 | 13.38 | Powering Tests |  | 5w | 2014-07-07 | 2014-08-08 | 282 | 2014-02-14 | 2014-02-14 | 1d? | 190d | 0d |  | Powering Tests | 200h | Arc 78 | BE-OP |  |

Notes:
- 248: DC cables disconnection...
- 253: Ressources à 200% pour reduire la duree à 2j vs 3j.
- 256: DC cables disconnection...
- 266: depends on the end of IC activities
- 267: depends on the end of IC activities
- 269: depends on the end of IC activities
- 270: ELQA TP4-A (300K)...
- 273: ELQA TP4-C (installation of the monitoring)...
- 282: ELQA TP4-C (removal of the monitoring)...

| ID | WBS | Task | Type | Duration | Start | Finish | Predecessors | Baseline start | Baseline finish | Baseline duration | Total slack | Free slack | Constraint | Resources | Work | Text1 | Location | fla2 |
| --- | --- | --- | --- | --- | --- | --- | --- | --- | --- | --- | --- | --- | --- | --- | --- | --- | --- | --- |
| 284 | 14 | **Point 8** |  | 1d? | 2012-11-17 | 2012-11-17 |  | 2013-02-28 | 2013-07-10 | 90d |  |  |  |  |  |  |  |  |
| 285 | 14.1 | Cryo maintenance | manual | 1d? | 2012-11-17 | 2012-11-17 |  | 2013-02-28 | 2013-07-10 | 18w |  |  | finish no earlier than 2013-07-10 |  |  | S Claudet | P8 | TE-CRG |
| 286 | 15 | **Sector 81** |  | 505d | 2013-02-19 | 2015-02-23 |  | 2012-11-21 | 2014-02-24 | 303d? | 51d |  |  |  | 648h |  |  |  |
| 287 | 15.1 | Powering Tests |  | 4ed | 2013-02-19 | 2013-02-23 | 207 | 2012-11-21 | 2012-11-25 | 4ed | 1782d | 0d |  | Powering Tests | 96h |  | Arc 81 | BE-OP |
| 288 | 15.2 | RP survey |  | 0.5d | 2013-02-25 | 2013-02-25 | 287 | 2012-11-26 | 2012-11-26 | 0.5d | 551.5d |  |  |  |  | C Tromel | Arc 81 | HSE-RP |
| 289 | 15.3 | ELQA |  | 9d | 2013-03-13 | 2013-03-25 | 287, 209 | 2012-11-26 | 2012-12-06 | 9d | 392d | 0d |  | ELQA | 72h | G D'Angelo | Arc 81 | TE-MPE |
| 290 | 15.4 | Identification Cryo |  | 2d | 2013-03-26 | 2013-03-27 | 289 | 2012-12-06 | 2012-12-08 | 2ed | 487d | 0d |  |  |  | S Claudet | Arc 81 | TE-CRG |
| 291 | 15.5 | Installation materiel VSC- beam vacuum&insulation vacuum |  | 1d | 2013-03-26 | 2013-03-27 | 290SS+0.5d |  |  |  | 529.5d |  |  |  |  | P Cruikshank | Arc 81 | TE-VSC |
| 292 | 15.6 | Warm-up (1.9-5K) |  | 4ed | 2013-03-27 | 2013-03-31 | 290, 251 | 2012-12-11 | 2012-12-14 | 3ed | 2134.88d | 0d |  |  |  | S Claudet | Arc 81 | TE-CRG |
| 293 | 15.7 | Warm-up (5-80K) |  | 1ew | 2013-03-31 | 2013-04-07 | 292 | 2012-12-14 | 2012-12-21 | 1ew | 2134.88d | 0d |  |  |  | S Claudet | Arc 81 | TE-CRG |
| 294 | 15.8 | Warm-up (80-300K) |  | 2ew | 2013-04-07 | 2013-04-21 | 293 | 2012-12-21 | 2013-01-04 | 2ew | 2134.88d | 1.88d |  |  |  | S Claudet | Arc 81 | TE-CRG |
| 295 | 15.9 | Leak test identification under vacuum (80K) |  | 3d | 2013-04-22 | 2013-04-24 | 294 | 2013-01-17 | 2013-01-21 | 3d | 491d | 0d |  | Leak test | 24h | P Cruikshank | Arc 81 | TE-VSC |
| 296 | 15.10 | Vacuum degradation |  | 1d | 2013-04-25 | 2013-04-25 | 295 | 2013-01-21 | 2013-01-22 | 1ed | 491d | 4d |  |  |  | P Cruikshank | Arc 81 | TE-VSC |
| 297 | 15.11 | ELQA |  | 8d | 2013-05-03 | 2013-05-15 | 296, 217 | 2013-01-23 | 2013-02-01 | 8d | 487d | 0d |  | ELQA | 64h | G D'Angelo | Arc 81 | TE-MPE |
| 298 | 15.12 | Measurement of the splices (nQPS) |  | 2d | 2013-05-14 | 2013-05-15 | 297FF | 2013-01-31 | 2013-02-01 | 2d | 498d |  |  |  |  | K Dahlerup | Arc 81 | TE-MPE |
| 299 | 15.13 | Leak test (300K-5Bar)- MSC support |  | 3d | 2013-05-16 | 2013-05-21 | 297 | 2013-02-04 | 2013-02-06 | 3d | 495d | 0d |  | Leak test | 24h | P Cruikshank | Arc 81 | TE-VSC |
| 300 | 15.14 | Arc 81 | milestone | 0d | 2013-05-21 | 2013-05-21 | 299 | 2013-02-06 | 2013-02-06 | 0d | 495d |  |  |  |  | ARC | Arc 81 |  |
| 301 | 15.15 | Start opening of the W bellow (train) | milestone | 0d | 2013-06-24 | 2013-06-24 | 260FS+3w | 2013-03-18 | 2013-03-18 | 0d | 441d | 0d |  |  |  | A Musso | Arc 81 | TE-MSC |
| 302 | 15.16 | Validation of the leak test (W) | milestone | 0d | 2014-03-25 | 2014-03-25 |  | 2013-11-06 | 2013-11-06 | 1d? | 27d | 0d | start no earlier than 2014-03-25 |  |  | P Cruikshank | Arc 81 | TE-VSC |
| 303 | 15.17 | Constraint R2E: End access commissioning | milestone | 0d | 2014-05-28 | 2014-05-28 |  |  |  |  | 217d | 167d | start no earlier than 2014-05-28 |  |  |  | Arc 81 |  |
| 304 | 15.18 | Constraint R2E: End Power converter recommissioning | milestone | 0d | 2014-04-14 | 2014-04-14 |  |  |  |  | 273d |  | start no earlier than 2014-04-14 |  |  |  | Arc 81 |  |
| 305 | 15.19 | Constraint R2E: End cryo commissioning | milestone | 0d | 2014-11-24 | 2014-11-24 |  |  |  |  | -118d | 0d | start no earlier than 2014-11-24 |  |  |  | Arc 81 |  |
| 306 | 15.20 | Preparation of the pressure test |  | 3d | 2014-03-25 | 2014-03-27 | 302 | 2013-11-07 | 2013-11-11 | 3d | 27d | 0d |  |  |  | S Claudet | Arc 81 | TE-CRG |
| 307 | 15.21 | Pressure Test |  | 1ed | 2014-03-27 | 2014-03-28 | 306 | 2013-11-11 | 2013-11-12 | 1ed | 124.88d | 7.88d |  |  |  | S Claudet | Arc 81 | TE-CRG |
| 308 | 15.22 | Leak test identification (300K-10bar) |  | 2d | 2014-03-31 | 2014-04-01 | 307 | 2013-11-13 | 2013-11-14 | 2d | 27d | 0d |  | Leak test | 16h | P Cruikshank | Arc 81 | TE-VSC |
| 309 | 15.23 | Safety valves installation and Purge |  | 5d | 2014-04-02 | 2014-04-08 | 308 | 2013-11-15 | 2013-11-21 | 5d | 27d | 0d |  |  |  | S Claudet | Arc 81 | TE-CRG |
| 310 | 15.24 | ELQA |  | 7d | 2014-04-02 | 2014-04-10 | 309SS | 2013-11-22 | 2013-12-02 | 7d | 27d | 0d |  | ELQA | 56h | G D'Angelo | Arc 81 | TE-MPE |
| 311 | 15.25 | Measurement of the splices (nQPS) |  | 2d | 2014-04-09 | 2014-04-10 | 310FF | 2013-11-29 | 2013-12-02 | 2d | 274d |  |  |  |  | K Dahlerup | Arc 81 | TE-MPE |
| 312 | 15.26 | Flushing |  | 2w | 2014-04-11 | 2014-04-25 | 310 | 2013-12-03 | 2013-12-16 | 2w | 27d | 0d |  |  |  | S Claudet | Arc 81 | TE-CRG |
| 313 | 15.27 | ELQA |  | 2d | 2014-04-28 | 2014-04-29 | 312 | 2013-12-17 | 2013-12-18 | 2d | 27d |  |  | ELQA | 16h | G D'Angelo | Arc 81 | BE-ABP |
| 314 | 15.28 | Measurement of the magnets |  | 2w | 2014-12-09 | 2014-12-22 | 316, 236 | 2014-01-06 | 2014-01-17 | 2w | -118d | 0d |  |  |  | JF Fuchs | Arc 81 | BE-ABP |
| 315 | 15.29 | Alignment of the magnets |  | 3w | 2014-12-23 | 2015-01-12 | 314 | 2014-01-20 | 2014-02-07 | 3w | -118d | 0d |  |  |  | JF Fuchs | Arc 81 | BE-ABP |
| 316 | 15.30 | Cool-down Arc (300-80K) |  | 15ed | 2014-11-24 | 2014-12-09 | 313, 305 | 2013-12-18 | 2014-01-02 | 15ed | -501d | 0d |  |  |  | S Claudet | Arc 81 | TE-CRG |
| 317 | 15.31 | Cool-down Arc (80-20K) |  | 8ed | 2014-12-09 | 2014-12-17 | 316 | 2014-01-02 | 2014-01-10 | 8ed | 228d | 0d |  |  |  | S Claudet | Arc 81 | TE-CRG |
| 318 | 15.32 | Cool-down Arc (20-4.5K) |  | 4ed | 2014-12-17 | 2014-12-21 | 317 | 2014-01-10 | 2014-01-14 | 4ed | 228d | 0d |  |  |  | S Claudet | Arc 81 | TE-CRG |
| 319 | 15.33 | Cool-down Arc (4.5-1.9K) |  | 3ed | 2014-12-21 | 2014-12-24 | 318 | 2014-01-14 | 2014-01-17 | 3ed | 228d | 0d |  |  |  | S Claudet | Arc 81 | TE-CRG |
| 320 | 15.34 | Cryo tuning |  | 1w | 2014-12-24 | 2014-12-30 | 319 | 2014-01-20 | 2014-01-24 | 1w | 54d | 4d |  |  |  | S Claudet | Arc 81 | TE-CRG |
| 321 | 15.35 | ELQA |  | 10d | 2015-01-06 | 2015-01-19 | 320, 315FS-5d | 2014-02-10 | 2014-02-21 | 10d | 50d | 0d |  | ELQA | 80h | G D'Angelo | Arc 81 | TE-MPE |
| 322 | 15.36 | Powering Tests |  | 5w | 2015-01-20 | 2015-02-23 | 321, 303 | 2014-02-24 | 2014-02-24 | 1d? | 50d | 0d |  | Powering Tests | 200h |  | Arc 81 | BE-OP |

Notes:
- 289: DC cables disconnection...
- 297: DC cables disconnection...
- 306: depends on the end of IC activities
- 307: depends on the end of IC activities
- 309: depends on the end of IC activities
- 310: ELQA TP4-A (300K)...
- 313: ELQA TP4-C (installation of the monitoring)...
- 321: ELQA TP4-C (removal of the monitoring)...
