# IC consolidation

Schedule from MS Project, 2013-04-17 to 2014-05-06.

## Calendars

- Standard: Mon-Fri 08:00-12:00, 13:00-17:00; Sat-Sun off. Exceptions (off unless hours are given): 2013-05-01 (2013 1st May), 2013-05-09 (2013 Ascension day), 2013-05-20 (2013 Whit Monday), 2013-09-05 (2013 Jeune Genevois), 2013-12-23 to 2014-01-03 (2013 Xmas Holidays), 2014-04-18 (2014 Good Friday), 2014-04-21 (2014 Easter Monday), 2014-05-01 (2014 1st May).

## Resources

| Resource |
| --- |
| Open close |
| SIT |
| BLM |
| Insulation Vacuum |
| DN200 |
| Train |
| ELQA |
| QPS |
| Sleeves cutting |
| QC Open close |
| Insulation |
| Splice de-resoldering |
| Welding QC |
| BB surfacing |
| Shunt installation |
| TIG welding |
| SIT MAGNETS |
| Protection beam |
| Protection beam line |
| Leak test |
| CRG |
| EM1 |
| EM2 |
| Greg |
| M4 |
| M6 |
| M1 |
| M3 |
| EM3 |
| EM4 |
| Transport |
| W1 |
| M5 |
| Survey |
| M2 |
| W2 |
| QA |
| VSC |
| QC |
| M% |

## Schedule

| ID | WBS | Task | Type | Duration | Start | Finish | Predecessors | Total slack | Free slack | Constraint | Resources | Work | Location | fla2 |
| --- | --- | --- | --- | --- | --- | --- | --- | --- | --- | --- | --- | --- | --- | --- |
| 1 | 1 | **sector 56** |  | 81d | 2013-04-17 08:00 | 2013-08-12 17:00 |  | 177d |  |  |  | 600h | arc 56 |  |
| 2 | 1.1 | Aimants: nothing to replace in this arc | milestone | 0d | 2013-04-17 08:00 | 2013-04-17 08:00 |  | 258d |  | start no earlier than 2013-04-17 08:00 |  |  | arc 56 | TE MSC |
| 3 | 1.2 | Train |  | 75d | 2013-04-25 08:00 | 2013-08-12 17:00 |  | 177d |  | start no earlier than 2013-04-25 08:00 | Train | 600h |  |  |
| 4 | 1.3 | Mounting insulation start | milestone | 0d | 2013-06-21 08:00 | 2013-06-21 08:00 |  | 214d |  | start no earlier than 2013-06-21 08:00 |  |  |  |  |
| 5 | 2 | **Sector 67** |  | 93d | 2013-05-07 08:00 | 2013-09-17 17:00 |  | 152d |  |  |  | 600h | arc 67 |  |
| 6 | 2.1 | Aimants: nothing to replace in this arc | milestone | 0d | 2013-05-07 08:00 | 2013-05-07 08:00 |  | 245d |  | start no earlier than 2013-05-07 08:00 |  |  | arc 67 | TE MSC |
| 7 | 2.2 | Train |  | 75d | 2013-06-04 08:00 | 2013-09-17 17:00 |  | 152d |  | start no earlier than 2013-06-04 08:00 | Train | 600h |  |  |
| 8 | 2.3 | Mounting insulation start | milestone | 0d | 2013-07-30 08:00 | 2013-07-30 08:00 |  | 187d |  | start no earlier than 2013-07-30 08:00 |  |  |  |  |
| 9 | 3 | **sector 78** |  | 183.5d | 2013-05-15 08:00 | 2014-02-12 12:00 |  | 0d |  |  |  | 2244h | arc 78 |  |
| 10 | 3.1 | Train |  | 75d | 2013-07-09 08:00 | 2013-10-22 17:00 |  | 127d |  | start no earlier than 2013-07-09 08:00 | Train | 600h |  |  |
| 11 | 3.2 | Mounting insulation start | milestone | 0d | 2013-09-03 08:00 | 2013-09-03 08:00 |  | 162d |  | start no earlier than 2013-09-03 08:00 |  |  |  |  |
| 12 | 3.3 | **Aimants** |  | 183.5d | 2013-05-15 08:00 | 2014-02-12 12:00 |  |  |  | start no earlier than 2013-01-15 08:00 |  | 1644h | arc 78 | TE MSC |
| 13 | 3.3.1 | **Q5L8** |  | 36d | 2013-05-15 08:00 | 2013-07-04 17:00 |  | 65d |  |  |  | 548h | arc 78 | TE MSC |
| 14 | 3.3.1.1 | **deconnection** |  | 6d | 2013-05-15 08:00 | 2013-05-23 17:00 |  | 65d | 0d |  |  | 144h | arc 78 | TE MSC |
| 15 | 3.3.1.1.1 | Remove thermometer wires+QC+Open |  | 2d | 2013-05-15 08:00 | 2013-05-16 17:00 |  | 65d | 0d |  | QC; CRG; Open close | 48h | arc 78 |  |
| 16 | 3.3.1.1.2 | Cut V1, V2, N line sleeves |  | 1.5d | 2013-05-15 13:00 | 2013-05-16 17:00 | 15SS+0.5d | 65d | 0d |  | M3; M1 | 24h | arc 78 |  |
| 17 | 3.3.1.1.3 | Cut E, K, C', X, Y, N, M1, M2 and M3 |  | 2d | 2013-05-16 13:00 | 2013-05-21 12:00 | 16FS-0.5d | 65d | 0d |  | M4; M6 | 32h | arc 78 |  |
| 18 | 3.3.1.1.4 | Remove N line insulation+Nline connection box+ Open N line connection box and disconnect wires + remove N line cable |  | 1.5d | 2013-05-21 13:00 | 2013-05-22 17:00 | 17 | 66d | 0d |  | EM1; EM2 | 24h | arc 78 |  |
| 19 | 3.3.1.1.5 | Disconnect spools and de-braze busbar |  | 1d | 2013-05-23 08:00 | 2013-05-23 17:00 | 18 | 67d | 1d |  | EM3; EM4 | 16h | arc 78 |  |
| 20 | 3.3.1.2 | Q5L8 disponible pour le transport | milestone | 0d | 2013-05-23 17:00 | 2013-05-23 17:00 | 14 | 177.5d |  |  |  |  | arc 78 | TE MSC |
| 21 | 3.3.1.3 | **IC repairing** |  | 3d | 2013-05-30 08:00 | 2013-06-03 17:00 | 14 | 65d | 0d |  |  | 100h | arc 78 | TE MSC |
| 22 | 3.3.1.3.1 | Stabilization cables of adjacent magnets+ replacement of flanges |  | 3d | 2013-05-30 08:00 | 2013-06-03 17:00 | 93 | 65d | 0d |  | EM3; EM4; W1; M5 | 96h | arc 78 |  |
| 23 | 3.3.1.3.2 | Endoscopic inspection of adiacent PIM |  | 0.5d | 2013-06-03 13:00 | 2013-06-03 17:00 | 22FS-0.5d | 147.5d |  |  | Welding QC | 4h | arc 78 |  |
| 24 | 3.3.1.4 | **reconnection** |  | 23d | 2013-06-03 17:00 | 2013-07-04 17:00 |  | 147.5d |  |  |  | 304h | arc 78 | TE MSC |
| 25 | 3.3.1.4.1 | Install cryodipole | milestone | 0d | 2013-06-03 17:00 | 2013-06-03 17:00 | 21 | 147.5d | 0d |  | Transport |  | arc 78 |  |
| 26 | 3.3.1.4.2 | Alignement |  | 1d | 2013-06-04 08:00 | 2013-06-04 17:00 | 25 | 147.5d | 0d |  | Survey | 8h | arc 78 |  |
| 27 | 3.3.1.4.3 | Insertion N line cable, Braze Y, Visual inspection Y |  | 1d | 2013-06-05 08:00 | 2013-06-05 17:00 | 26, 715 | 147.5d | 0d |  | M2; W2; QA | 24h | arc 78 |  |
| 28 | 3.3.1.4.4 | Install PIM and weld PIM |  | 0.5d | 2013-06-06 08:00 | 2013-06-06 12:00 | 27 | 147.5d | 0d |  | W1; VSC; M5 | 12h | arc 78 |  |
| 29 | 3.3.1.4.5 | Weld X, E, K, C' sleeves |  | 2d | 2013-06-06 13:00 | 2013-06-10 12:00 | 28, 27 | 147.5d | 0d |  | W1; M2 | 32h | arc 78 |  |
| 30 | 3.3.1.4.6 | Leak test X,E, K, C', V and visual inspection |  | 2.5d | 2013-06-10 13:00 | 2013-06-12 17:00 | 29 | 147.5d | 0d |  | VSC; QA | 40h | arc 78 |  |
| 31 | 3.3.1.4.7 | Braze busbars, visual inspection, US check of BB, shunt installation |  | 3d | 2013-06-13 08:00 | 2013-06-17 17:00 | 30 | 147.5d | 0d |  | Train | 24h | arc 78 |  |
| 32 | 3.3.1.4.8 | Connect spools |  | 1d | 2013-06-18 08:00 | 2013-06-18 17:00 | 31, 725 | 147.5d | 0d |  | EM1; EM2 | 16h | arc 78 |  |
| 33 | 3.3.1.4.9 | Visual inspection of spool connections |  | 0.5d | 2013-06-18 13:00 | 2013-06-18 17:00 | 32SS+0.5d | 159.5d |  |  | QC | 4h | arc 78 |  |
| 34 | 3.3.1.4.10 | Connection of N line cable |  | 1d | 2013-06-19 08:00 | 2013-06-19 17:00 | 32 | 147.5d | 0d |  | EM1; EM2 | 16h | arc 78 |  |
| 35 | 3.3.1.4.11 | Visual inspection of connections |  | 0.5d | 2013-06-19 13:00 | 2013-06-19 17:00 | 34SS+0.5d | 147.5d | 0d |  | QC | 4h | arc 78 |  |
| 36 | 3.3.1.4.12 | MPAQ + AIV1 test |  | 1d | 2013-06-20 08:00 | 2013-06-20 17:00 | 34, 35 | 147.5d | 0d |  | ELQA | 8h | arc 78 |  |
| 37 | 3.3.1.4.13 | Weld N line wires |  | 2d | 2013-06-21 08:00 | 2013-06-24 17:00 | 36 | 147.5d | 0d |  | EM1; EM2 | 32h | arc 78 |  |
| 38 | 3.3.1.4.14 | AIV2 test |  | 1d | 2013-06-25 08:00 | 2013-06-25 17:00 | 37 | 147.5d | 0d |  | ELQA | 8h | arc 78 |  |
| 39 | 3.3.1.4.15 | Close N line connection box |  | 2d | 2013-06-26 08:00 | 2013-06-27 17:00 | 38 | 147.5d | 0d |  | EM1; EM2 | 32h | arc 78 |  |
| 40 | 3.3.1.4.16 | Weld N (139mm) sleeves |  | 0.5d | 2013-06-28 08:00 | 2013-06-28 12:00 | 39 | 147.5d | 0d |  | W1; M5 | 8h | arc 78 |  |
| 41 | 3.3.1.4.17 | Insulate busbars and spools |  | 0.5d | 2013-06-28 13:00 | 2013-06-28 17:00 | 40 | 147.5d | 0d |  | Train | 4h | arc 78 |  |
| 42 | 3.3.1.4.18 | Weld M1, M2, M3 and N (71mm) sleeves |  | 0.5d | 2013-07-01 08:00 | 2013-07-01 12:00 | 41 | 147.5d | 0d |  | Train | 4h | arc 78 |  |
| 43 | 3.3.1.4.19 | Visual inspection of welds |  | 0.5d | 2013-07-01 13:00 | 2013-07-01 17:00 | 42 | 147.5d | 0d |  | QA | 4h | arc 78 |  |
| 44 | 3.3.1.4.20 | Leak test M1, M2, M3 and N line welds |  | 0.5d | 2013-07-02 08:00 | 2013-07-02 12:00 | 43 | 147.5d | 0d |  | VSC | 4h | arc 78 |  |
| 45 | 3.3.1.4.21 | Install thermometers wires |  | 0.5d | 2013-07-02 13:00 | 2013-07-02 17:00 | 44 | 147.5d | 0d |  | CRG | 4h | arc 78 |  |
| 46 | 3.3.1.4.22 | General inspection before closure |  | 0.5d | 2013-07-03 08:00 | 2013-07-03 12:00 | 45 | 147.5d | 0d |  | Train | 4h | arc 78 |  |
| 47 | 3.3.1.4.23 | Install screens and MLI |  | 0.5d | 2013-07-03 13:00 | 2013-07-03 17:00 | 46 | 147.5d | 0d |  | Train | 4h | arc 78 |  |
| 48 | 3.3.1.4.24 | Close W bellows |  | 0.5d | 2013-07-04 08:00 | 2013-07-04 12:00 | 47 | 147.5d | 0d |  | Train | 4h | arc 78 |  |
| 49 | 3.3.1.4.25 | Leak test Vac sector |  | 0.5d | 2013-07-04 13:00 | 2013-07-04 17:00 | 48 | 147.5d |  |  | VSC | 4h | arc 78 |  |

Notes:
- 2: According to skeleton
- 6: According to skeleton
- 12: According to skeleton

| ID | WBS | Task | Type | Duration | Start | Finish | Predecessors | Total slack | Free slack | Resources | Work | Location | fla2 |
| --- | --- | --- | --- | --- | --- | --- | --- | --- | --- | --- | --- | --- | --- |
| 50 | 3.3.2 | **B30R7** |  | 37d | 2013-05-17 08:00 | 2013-07-09 17:00 |  | 65d |  |  | 548h | arc 78 | TE MSC |
| 51 | 3.3.2.1 | **deconnecting** |  | 6d | 2013-05-17 08:00 | 2013-05-27 17:00 |  | 65d | 0d |  | 144h | arc 78 | TE MSC |
| 52 | 3.3.2.1.1 | Remove thermometer wires+QC+Open |  | 2d | 2013-05-17 08:00 | 2013-05-21 17:00 | 15 | 65d | 0d | QC; CRG; Open close | 48h | arc 78 |  |
| 53 | 3.3.2.1.2 | Cut V1, V2, N line sleeves |  | 1.5d | 2013-05-17 13:00 | 2013-05-21 17:00 | 52SS+0.5d, 16 | 65d | 0d | M3; M1 | 24h | arc 78 |  |
| 54 | 3.3.2.1.3 | Cut E, K, C', X, Y, N, M1, M2 and M3 |  | 2d | 2013-05-21 13:00 | 2013-05-23 12:00 | 53FS-0.5d, 17 | 65d | 0d | M4; M6 | 32h | arc 78 |  |
| 55 | 3.3.2.1.4 | Remove N line insulation+Nline connection box+ Open N line connection box and disconnect wires + remove N line cable |  | 1.5d | 2013-05-23 13:00 | 2013-05-24 17:00 | 54, 18 | 65.5d | 0d | EM1; EM2 | 24h | arc 78 |  |
| 56 | 3.3.2.1.5 | Disconnect spools and de-braze busbar |  | 1d | 2013-05-27 08:00 | 2013-05-27 17:00 | 55, 19 | 66d | 1d | EM3; EM4 | 16h | arc 78 |  |
| 57 | 3.3.2.2 | B30R7 disponible pour transport | milestone | 0d | 2013-05-27 17:00 | 2013-05-27 17:00 | 51 | 175.5d |  | Transport |  | arc 78 | TE MSC |
| 58 | 3.3.2.3 | **IC repairing** |  | 3d | 2013-06-04 08:00 | 2013-06-06 17:00 | 51 | 65d | 0d |  | 100h | arc 78 | TE MSC |
| 59 | 3.3.2.3.1 | Stabilization cables of adjacent magnets+ replacement of flanges |  | 3d | 2013-06-04 08:00 | 2013-06-06 17:00 | 22 | 65d | 0d | EM3; EM4; W1; M5 | 96h | arc 78 |  |
| 60 | 3.3.2.3.2 | Endoscopic inspection of adiacent PIM |  | 0.5d | 2013-06-06 13:00 | 2013-06-06 17:00 | 59FS-0.5d | 65d |  | Welding QC | 4h | arc 78 |  |
| 61 | 3.3.2.4 | **reconnection** |  | 23d | 2013-06-06 17:00 | 2013-07-09 17:00 | 58 | 65d |  |  | 304h | arc 78 | TE MSC |
| 62 | 3.3.2.4.1 | Install cryodipole | milestone | 0d | 2013-06-06 17:00 | 2013-06-06 17:00 |  | 65d | 0d | Transport |  | arc 78 |  |
| 63 | 3.3.2.4.2 | Alignement |  | 1d | 2013-06-07 08:00 | 2013-06-07 17:00 | 62 | 65d | 0d | Survey | 8h | arc 78 |  |
| 64 | 3.3.2.4.3 | Insertion N line cable, Braze Y, Visual inspection Y |  | 1d | 2013-06-10 08:00 | 2013-06-10 17:00 | 63 | 65d | 0d | M2; W2; QA | 24h | arc 78 |  |
| 65 | 3.3.2.4.4 | Install PIM and weld PIM |  | 0.5d | 2013-06-11 08:00 | 2013-06-11 12:00 | 64 | 65d | 0d | W1; VSC; M5 | 12h | arc 78 |  |
| 66 | 3.3.2.4.5 | Weld X, E, K, C' sleeves |  | 2d | 2013-06-11 13:00 | 2013-06-13 12:00 | 65, 64 | 65d | 0d | W1; M2 | 32h | arc 78 |  |
| 67 | 3.3.2.4.6 | Leak test X,E, K, C', V and visual inspection |  | 2.5d | 2013-06-13 13:00 | 2013-06-17 17:00 | 66 | 65d | 0d | VSC; QA | 40h | arc 78 |  |
| 68 | 3.3.2.4.7 | Braze busbars, visual inspection, US check of BB, shunt installation |  | 3d | 2013-06-18 08:00 | 2013-06-20 17:00 | 67 | 65d | 0d | Train | 24h | arc 78 |  |
| 69 | 3.3.2.4.8 | Connect spools |  | 1d | 2013-06-21 08:00 | 2013-06-21 17:00 | 68, 322 | 65d | 0d | EM1; EM2 | 16h | arc 78 |  |
| 70 | 3.3.2.4.9 | Visual inspection of spool connections |  | 0.5d | 2013-06-21 13:00 | 2013-06-21 17:00 | 69SS+0.5d | 156.5d |  | QC | 4h | arc 78 |  |
| 71 | 3.3.2.4.10 | Connection of N line cable |  | 1d | 2013-06-24 08:00 | 2013-06-24 17:00 | 69 | 65d | 0d | EM1; EM2 | 16h | arc 78 |  |
| 72 | 3.3.2.4.11 | Visual inspection of connections |  | 0.5d | 2013-06-24 13:00 | 2013-06-24 17:00 | 71SS+0.5d | 65d | 0d | QC | 4h | arc 78 |  |
| 73 | 3.3.2.4.12 | MPAQ + AIV1 test |  | 1d | 2013-06-25 08:00 | 2013-06-25 17:00 | 71, 72 | 65d | 0d | ELQA | 8h | arc 78 |  |
| 74 | 3.3.2.4.13 | Weld N line wires |  | 2d | 2013-06-26 08:00 | 2013-06-27 17:00 | 73 | 65d | 0d | EM1; EM2 | 32h | arc 78 |  |
| 75 | 3.3.2.4.14 | AIV2 test |  | 1d | 2013-06-28 08:00 | 2013-06-28 17:00 | 74 | 65d | 0d | ELQA | 8h | arc 78 |  |
| 76 | 3.3.2.4.15 | Close N line connection box |  | 2d | 2013-07-01 08:00 | 2013-07-02 17:00 | 75 | 65d | 0d | EM1; EM2 | 32h | arc 78 |  |
| 77 | 3.3.2.4.16 | Weld N (139mm) sleeves |  | 0.5d | 2013-07-03 08:00 | 2013-07-03 12:00 | 76 | 144.5d | 0d | W1; M5 | 8h | arc 78 |  |
| 78 | 3.3.2.4.17 | Insulate busbars and spools |  | 0.5d | 2013-07-03 13:00 | 2013-07-03 17:00 | 77 | 144.5d | 0d | Train | 4h | arc 78 |  |
| 79 | 3.3.2.4.18 | Weld M1, M2, M3 and N (71mm) sleeves |  | 0.5d | 2013-07-04 08:00 | 2013-07-04 12:00 | 78 | 144.5d | 0d | Train | 4h | arc 78 |  |
| 80 | 3.3.2.4.19 | Visual inspection of welds |  | 0.5d | 2013-07-04 13:00 | 2013-07-04 17:00 | 79 | 144.5d | 0d | QA | 4h | arc 78 |  |
| 81 | 3.3.2.4.20 | Leak test M1, M2, M3 and N line welds |  | 0.5d | 2013-07-05 08:00 | 2013-07-05 12:00 | 80 | 144.5d | 0d | VSC | 4h | arc 78 |  |
| 82 | 3.3.2.4.21 | Install thermometers wires |  | 0.5d | 2013-07-05 13:00 | 2013-07-05 17:00 | 81 | 144.5d | 0d | CRG | 4h | arc 78 |  |
| 83 | 3.3.2.4.22 | General inspection before closure |  | 0.5d | 2013-07-08 08:00 | 2013-07-08 12:00 | 82 | 144.5d | 0d | Train | 4h | arc 78 |  |
| 84 | 3.3.2.4.23 | Install screens and MLI |  | 0.5d | 2013-07-08 13:00 | 2013-07-08 17:00 | 83 | 144.5d | 0d | Train | 4h | arc 78 |  |
| 85 | 3.3.2.4.24 | Close W bellows |  | 0.5d | 2013-07-09 08:00 | 2013-07-09 12:00 | 84 | 144.5d | 0d | Train | 4h | arc 78 |  |
| 86 | 3.3.2.4.25 | Leak test Vac sector |  | 0.5d | 2013-07-09 13:00 | 2013-07-09 17:00 | 85 | 144.5d |  | VSC | 4h | arc 78 |  |

| ID | WBS | Task | Type | Duration | Start | Finish | Predecessors | Total slack | Free slack | Resources | Work | Location | fla2 |
| --- | --- | --- | --- | --- | --- | --- | --- | --- | --- | --- | --- | --- | --- |
| 87 | 3.3.3 | **B21L8** |  | 43d | 2013-05-22 08:00 | 2013-07-19 17:00 |  | 65d |  |  | 548h | arc 78 | TE MSC |
| 88 | 3.3.3.1 | **deconnecting** |  | 6d | 2013-05-22 08:00 | 2013-05-29 17:00 |  | 65d | 0d |  | 144h | arc 78 | TE MSC |
| 89 | 3.3.3.1.1 | Remove thermometer wires+QC+Open |  | 2d | 2013-05-22 08:00 | 2013-05-23 17:00 | 52 | 65d | 0d | QC; CRG; Open close | 48h | arc 78 |  |
| 90 | 3.3.3.1.2 | Cut V1, V2, N line sleeves |  | 1.5d | 2013-05-22 13:00 | 2013-05-23 17:00 | 53, 89SS+0.5d | 65d | 0d | M3; M1 | 24h | arc 78 |  |
| 91 | 3.3.3.1.3 | Cut E, K, C', X, Y, N, M1, M2 and M3 |  | 2d | 2013-05-23 13:00 | 2013-05-27 12:00 | 90FS-0.5d, 54 | 65d | 0d | M4; M6 | 32h | arc 78 |  |
| 92 | 3.3.3.1.4 | Remove N line insulation+Nline connection box+ Open N line connection box and disconnect wires + remove N line cable |  | 1.5d | 2013-05-27 13:00 | 2013-05-28 17:00 | 91, 55 | 65d | 0d | EM1; EM2 | 24h | arc 78 |  |
| 93 | 3.3.3.1.5 | Disconnect spools and de-braze busbar |  | 1d | 2013-05-29 08:00 | 2013-05-29 17:00 | 92, 56 | 65d | 0d | EM3; EM4 | 16h | arc 78 |  |
| 94 | 3.3.3.2 | B21L8 disponible pour transport | milestone | 0d | 2013-05-29 17:00 | 2013-05-29 17:00 | 88 | 173.5d |  | Transport |  | arc 78 | TE MSC |
| 95 | 3.3.3.3 | **IC repairing** |  | 3d | 2013-06-07 08:00 | 2013-06-11 17:00 | 88 | 69d | 0d |  | 100h | arc 78 | TE MSC |
| 96 | 3.3.3.3.1 | Stabilization cables of adjacent magnets+ replacement of flanges |  | 3d | 2013-06-07 08:00 | 2013-06-11 17:00 | 59 | 69d | 0d | EM3; EM4; W1; M5 | 96h | arc 78 |  |
| 97 | 3.3.3.3.2 | Endoscopic inspection of adiacent PIM |  | 0.5d | 2013-06-11 13:00 | 2013-06-11 17:00 | 96FS-0.5d | 70d |  | Welding QC | 4h | arc 78 |  |
| 98 | 3.3.3.4 | **reconnection** |  | 28d | 2013-06-11 17:00 | 2013-07-19 17:00 | 95 | 70d |  |  | 304h | arc 78 | TE MSC |
| 99 | 3.3.3.4.1 | Install cryodipole | milestone | 0d | 2013-06-11 17:00 | 2013-06-11 17:00 |  | 70d | 0d | Transport |  | arc 78 |  |
| 100 | 3.3.3.4.2 | Alignement |  | 1d | 2013-06-12 08:00 | 2013-06-12 17:00 | 99 | 70d | 0.5d | Survey | 8h | arc 78 |  |
| 101 | 3.3.3.4.3 | Insertion N line cable, Braze Y, Visual inspection Y |  | 1d | 2013-06-13 13:00 | 2013-06-14 12:00 | 100, 66 | 69.5d | 0d | M2; W2; QA | 24h | arc 78 |  |
| 102 | 3.3.3.4.4 | Install PIM and weld PIM |  | 0.5d | 2013-06-14 13:00 | 2013-06-14 17:00 | 101 | 69.5d | 0d | W1; VSC; M5 | 12h | arc 78 |  |
| 103 | 3.3.3.4.5 | Weld X, E, K, C' sleeves |  | 2d | 2013-06-17 08:00 | 2013-06-18 17:00 | 102, 101 | 69.5d | 0d | W1; M2 | 32h | arc 78 |  |
| 104 | 3.3.3.4.6 | Leak test X,E, K, C', V and visual inspection |  | 2.5d | 2013-06-19 08:00 | 2013-06-21 12:00 | 103 | 69.5d | 0d | VSC; QA | 40h | arc 78 |  |
| 105 | 3.3.3.4.7 | Braze busbars, visual inspection, US check of BB, shunt installation |  | 3d | 2013-06-21 13:00 | 2013-06-26 12:00 | 104 | 69.5d | 4.5d | Train | 24h | arc 78 |  |
| 106 | 3.3.3.4.8 | Connect spools |  | 1d | 2013-07-03 08:00 | 2013-07-03 17:00 | 105, 76 | 65d | 0d | EM1; EM2 | 16h | arc 78 |  |
| 107 | 3.3.3.4.9 | Visual inspection of spool connections |  | 0.5d | 2013-07-03 13:00 | 2013-07-03 17:00 | 106SS+0.5d | 148.5d |  | QC | 4h | arc 78 |  |
| 108 | 3.3.3.4.10 | Connection of N line cable |  | 1d | 2013-07-04 08:00 | 2013-07-04 17:00 | 106 | 65d | 0d | EM1; EM2 | 16h | arc 78 |  |
| 109 | 3.3.3.4.11 | Visual inspection of connections |  | 0.5d | 2013-07-04 13:00 | 2013-07-04 17:00 | 108SS+0.5d | 65d | 0d | QC | 4h | arc 78 |  |
| 110 | 3.3.3.4.12 | MPAQ + AIV1 test |  | 1d | 2013-07-05 08:00 | 2013-07-05 17:00 | 108, 109 | 65d | 0d | ELQA | 8h | arc 78 |  |
| 111 | 3.3.3.4.13 | Weld N line wires |  | 2d | 2013-07-08 08:00 | 2013-07-09 17:00 | 110 | 65d | 0d | EM1; EM2 | 32h | arc 78 |  |
| 112 | 3.3.3.4.14 | AIV2 test |  | 1d | 2013-07-10 08:00 | 2013-07-10 17:00 | 111 | 65d | 0d | ELQA | 8h | arc 78 |  |
| 113 | 3.3.3.4.15 | Close N line connection box |  | 2d | 2013-07-11 08:00 | 2013-07-12 17:00 | 112 | 65d | 0d | EM1; EM2 | 32h | arc 78 |  |
| 114 | 3.3.3.4.16 | Weld N (139mm) sleeves |  | 0.5d | 2013-07-15 08:00 | 2013-07-15 12:00 | 113 | 136.5d | 0d | W1; M5 | 8h | arc 78 |  |
| 115 | 3.3.3.4.17 | Insulate busbars and spools |  | 0.5d | 2013-07-15 13:00 | 2013-07-15 17:00 | 114 | 136.5d | 0d | Train | 4h | arc 78 |  |
| 116 | 3.3.3.4.18 | Weld M1, M2, M3 and N (71mm) sleeves |  | 0.5d | 2013-07-16 08:00 | 2013-07-16 12:00 | 115 | 136.5d | 0d | Train | 4h | arc 78 |  |
| 117 | 3.3.3.4.19 | Visual inspection of welds |  | 0.5d | 2013-07-16 13:00 | 2013-07-16 17:00 | 116 | 136.5d | 0d | QA | 4h | arc 78 |  |
| 118 | 3.3.3.4.20 | Leak test M1, M2, M3 and N line welds |  | 0.5d | 2013-07-17 08:00 | 2013-07-17 12:00 | 117 | 136.5d | 0d | VSC | 4h | arc 78 |  |
| 119 | 3.3.3.4.21 | Install thermometers wires |  | 0.5d | 2013-07-17 13:00 | 2013-07-17 17:00 | 118 | 136.5d | 0d | CRG | 4h | arc 78 |  |
| 120 | 3.3.3.4.22 | General inspection before closure |  | 0.5d | 2013-07-18 08:00 | 2013-07-18 12:00 | 119 | 136.5d | 0d | Train | 4h | arc 78 |  |
| 121 | 3.3.3.4.23 | Install screens and MLI |  | 0.5d | 2013-07-18 13:00 | 2013-07-18 17:00 | 120 | 136.5d | 0d | Train | 4h | arc 78 |  |
| 122 | 3.3.3.4.24 | Close W bellows |  | 0.5d | 2013-07-19 08:00 | 2013-07-19 12:00 | 121 | 136.5d | 0d | Train | 4h | arc 78 |  |
| 123 | 3.3.3.4.25 | Leak test Vac sector |  | 0.5d | 2013-07-19 13:00 | 2013-07-19 17:00 | 122 | 136.5d |  | VSC | 4h | arc 78 |  |

| ID | WBS | Task | Type | Duration | Start | Finish | Predecessors | Total slack | Free slack | Constraint | Resources | Work | Location | fla2 |
| --- | --- | --- | --- | --- | --- | --- | --- | --- | --- | --- | --- | --- | --- | --- |
| 124 | 4 | **Sector 81** |  | 134d | 2013-05-22 08:00 | 2013-11-26 17:00 |  | 102d |  |  |  | 600h | arc 81 |  |
| 125 | 4.1 | Aimants: nothing to replace in this arc | milestone | 0d | 2013-05-22 08:00 | 2013-05-22 08:00 |  | 236d |  | start no earlier than 2013-05-22 08:00 |  |  | arc 81 | TE MSC |
| 126 | 4.2 | Mounting insulation start | milestone | 0d | 2013-10-09 08:00 | 2013-10-09 08:00 |  | 137d |  | start no earlier than 2013-10-09 08:00 |  |  |  |  |
| 127 | 4.3 | Train |  | 75d | 2013-08-13 08:00 | 2013-11-26 17:00 |  | 102d |  | start no earlier than 2013-08-13 08:00 | Train | 600h | arc 81 |  |
| 128 | 5 | **Sector 12** |  | 156d | 2013-05-27 08:00 | 2014-01-14 17:00 |  | 67.5d |  |  |  | 3888h | arc 12 |  |
| 129 | 5.1 | Train |  | 75d | 2013-09-18 08:00 | 2014-01-14 17:00 |  | 77d |  | start no earlier than 2013-09-18 08:00 | Train | 600h | arc 12 |  |
| 130 | 5.2 | Mounting insulation start | milestone | 0d | 2013-11-13 08:00 | 2013-11-13 08:00 |  | 112d |  | start no earlier than 2013-11-13 08:00 |  |  |  |  |
| 131 | 5.3 | **Aimants** |  | 88d | 2013-05-27 08:00 | 2013-09-26 17:00 |  | 67.5d |  | start no earlier than 2013-05-27 08:00 |  | 3288h | arc 12 | TE MSC |
| 132 | 5.3.1 | **C15R1** |  | 48d | 2013-05-27 08:00 | 2013-07-31 17:00 |  | 67.5d |  | start no earlier than 2013-05-27 08:00 |  | 548h | arc 12 | TE MSC |
| 133 | 5.3.1.1 | **deconnecting** |  | 13d | 2013-05-27 08:00 | 2013-06-12 17:00 |  | 67.5d | 0d |  |  | 144h | arc 12 | TE MSC |
| 134 | 5.3.1.1.1 | Remove thermometer wires+QC+Open |  | 2d | 2013-05-27 08:00 | 2013-05-28 17:00 | 89 | 67.5d | 0d |  | QC; CRG; Open close | 48h | arc 12 |  |
| 135 | 5.3.1.1.2 | Cut V1, V2, N line sleeves |  | 1.5d | 2013-05-27 13:00 | 2013-05-28 17:00 | 16, 134SS+0.5d | 69d | 0d |  | M3; M1 | 24h | arc 12 |  |
| 136 | 5.3.1.1.3 | Cut E, K, C', X, Y, N, M1, M2 and M3 |  | 2d | 2013-05-28 13:00 | 2013-05-30 12:00 | 135FS-0.5d, 91 | 69d | 0d |  | M4; M6 | 32h | arc 12 |  |
| 137 | 5.3.1.1.4 | Remove N line insulation+Nline connection box+ Open N line connection box and disconnect wires + remove N line cable |  | 1.5d | 2013-05-30 13:00 | 2013-05-31 17:00 | 136, 92 | 71.5d | 0.5d |  | EM1; EM2 | 24h | arc 12 |  |
| 138 | 5.3.1.1.5 | Disconnect spools and de-braze busbar |  | 1d | 2013-06-12 08:00 | 2013-06-12 17:00 | 137, 96 | 69d | 0d |  | EM3; EM4 | 16h | arc 12 |  |
| 139 | 5.3.1.2 | C15R1 disponible pour transport | milestone | 0d | 2013-06-12 17:00 | 2013-06-12 17:00 | 133 | 220d |  |  | Transport |  | arc 12 | TE MSC |
| 140 | 5.3.1.3 | **IC repairing** |  | 3d | 2013-06-20 08:00 | 2013-06-24 17:00 | 133 | 69d | 0d |  |  | 100h | arc 12 | TE MSC |
| 141 | 5.3.1.3.1 | Stabilization cables of adjacent magnets+ replacement of flanges |  | 3d | 2013-06-20 08:00 | 2013-06-24 17:00 | 323 | 69d | 0d |  | EM3; EM4; W1; M5 | 96h | arc 12 |  |
| 142 | 5.3.1.3.2 | Endoscopic inspection of adiacent PIM |  | 0.5d | 2013-06-24 13:00 | 2013-06-24 17:00 | 141FS-0.5d | 69d |  |  | Welding QC | 4h | arc 12 |  |
| 143 | 5.3.1.4 | **reconnection** |  | 27d | 2013-06-24 17:00 | 2013-07-31 17:00 | 140 | 69d |  |  |  | 304h | arc 12 | TE MSC |
| 144 | 5.3.1.4.1 | Install cryodipole | milestone | 0d | 2013-06-24 17:00 | 2013-06-24 17:00 |  | 69d | 0d |  | Transport |  | arc 12 |  |
| 145 | 5.3.1.4.2 | Alignement |  | 1d | 2013-06-25 08:00 | 2013-06-25 17:00 | 144 | 69d | 0d |  | Survey | 8h | arc 12 |  |
| 146 | 5.3.1.4.3 | Insertion N line cable, Braze Y, Visual inspection Y |  | 1d | 2013-06-26 08:00 | 2013-06-26 17:00 | 145, 103 | 69d | 0d |  | M2; W2; QA | 24h | arc 12 |  |
| 147 | 5.3.1.4.4 | Install PIM and weld PIM |  | 0.5d | 2013-06-27 08:00 | 2013-06-27 12:00 | 146 | 69d | 0d |  | W1; VSC; M5 | 12h | arc 12 |  |
| 148 | 5.3.1.4.5 | Weld X, E, K, C' sleeves |  | 2d | 2013-06-27 13:00 | 2013-07-01 12:00 | 147, 146 | 69d | 0d |  | W1; M2 | 32h | arc 12 |  |
| 149 | 5.3.1.4.6 | Leak test X,E, K, C', V and visual inspection |  | 2.5d | 2013-07-01 13:00 | 2013-07-03 17:00 | 148 | 69d | 0d |  | VSC; QA | 40h | arc 12 |  |
| 150 | 5.3.1.4.7 | Braze busbars, visual inspection, US check of BB, shunt installation |  | 3d | 2013-07-04 08:00 | 2013-07-08 17:00 | 149 | 69d | 4d |  | Train | 24h | arc 12 |  |
| 151 | 5.3.1.4.8 | Connect spools |  | 1d | 2013-07-15 08:00 | 2013-07-15 17:00 | 150, 113 | 65d | 0d |  | EM1; EM2 | 16h | arc 12 |  |
| 152 | 5.3.1.4.9 | Visual inspection of spool connections |  | 0.5d | 2013-07-15 13:00 | 2013-07-15 17:00 | 151SS+0.5d | 197d |  |  | QC | 4h | arc 12 |  |
| 153 | 5.3.1.4.10 | Connection of N line cable |  | 1d | 2013-07-16 08:00 | 2013-07-16 17:00 | 151 | 65d | 0d |  | EM1; EM2 | 16h | arc 12 |  |
| 154 | 5.3.1.4.11 | Visual inspection of connections |  | 0.5d | 2013-07-16 13:00 | 2013-07-16 17:00 | 153SS+0.5d | 65d | 0d |  | QC | 4h | arc 12 |  |
| 155 | 5.3.1.4.12 | MPAQ + AIV1 test |  | 1d | 2013-07-17 08:00 | 2013-07-17 17:00 | 153, 154 | 65d | 0d |  | ELQA | 8h | arc 12 |  |
| 156 | 5.3.1.4.13 | Weld N line wires |  | 2d | 2013-07-18 08:00 | 2013-07-19 17:00 | 155 | 65d | 0d |  | EM1; EM2 | 32h | arc 12 |  |
| 157 | 5.3.1.4.14 | AIV2 test |  | 1d | 2013-07-22 08:00 | 2013-07-22 17:00 | 156 | 65d | 0d |  | ELQA | 8h | arc 12 |  |
| 158 | 5.3.1.4.15 | Close N line connection box |  | 2d | 2013-07-23 08:00 | 2013-07-24 17:00 | 157 | 65d | 0d |  | EM1; EM2 | 32h | arc 12 |  |
| 159 | 5.3.1.4.16 | Weld N (139mm) sleeves |  | 0.5d | 2013-07-25 08:00 | 2013-07-25 12:00 | 158 | 185d | 0d |  | W1; M5 | 8h | arc 12 |  |
| 160 | 5.3.1.4.17 | Insulate busbars and spools |  | 0.5d | 2013-07-25 13:00 | 2013-07-25 17:00 | 159 | 185d | 0d |  | Train | 4h | arc 12 |  |
| 161 | 5.3.1.4.18 | Weld M1, M2, M3 and N (71mm) sleeves |  | 0.5d | 2013-07-26 08:00 | 2013-07-26 12:00 | 160 | 185d | 0d |  | Train | 4h | arc 12 |  |
| 162 | 5.3.1.4.19 | Visual inspection of welds |  | 0.5d | 2013-07-26 13:00 | 2013-07-26 17:00 | 161 | 185d | 0d |  | QA | 4h | arc 12 |  |
| 163 | 5.3.1.4.20 | Leak test M1, M2, M3 and N line welds |  | 0.5d | 2013-07-29 08:00 | 2013-07-29 12:00 | 162 | 185d | 0d |  | VSC | 4h | arc 12 |  |
| 164 | 5.3.1.4.21 | Install thermometers wires |  | 0.5d | 2013-07-29 13:00 | 2013-07-29 17:00 | 163 | 185d | 0d |  | CRG | 4h | arc 12 |  |
| 165 | 5.3.1.4.22 | General inspection before closure |  | 0.5d | 2013-07-30 08:00 | 2013-07-30 12:00 | 164 | 185d | 0d |  | Train | 4h | arc 12 |  |
| 166 | 5.3.1.4.23 | Install screens and MLI |  | 0.5d | 2013-07-30 13:00 | 2013-07-30 17:00 | 165 | 185d | 0d |  | Train | 4h | arc 12 |  |
| 167 | 5.3.1.4.24 | Close W bellows |  | 0.5d | 2013-07-31 08:00 | 2013-07-31 12:00 | 166 | 185d | 0d |  | Train | 4h | arc 12 |  |
| 168 | 5.3.1.4.25 | Leak test Vac sector |  | 0.5d | 2013-07-31 13:00 | 2013-07-31 17:00 | 167 | 185d |  |  | VSC | 4h | arc 12 |  |

Notes:
- 125: According to skeleton
- 131: According to skeleton

| ID | WBS | Task | Type | Duration | Start | Finish | Predecessors | Total slack | Free slack | Resources | Work | Location | fla2 |
| --- | --- | --- | --- | --- | --- | --- | --- | --- | --- | --- | --- | --- | --- |
| 169 | 5.3.2 | **A22R1** |  | 54d | 2013-05-29 08:00 | 2013-08-12 17:00 |  | 67.5d |  |  | 548h | arc 12 | TE MSC |
| 170 | 5.3.2.1 | **deconnecting** |  | 12d | 2013-05-29 08:00 | 2013-06-13 17:00 |  | 67.5d | 0d |  | 144h | arc 12 | TE MSC |
| 171 | 5.3.2.1.1 | Remove thermometer wires+QC+Open |  | 2d | 2013-05-29 08:00 | 2013-05-30 17:00 | 134 | 67.5d | 0d | QC; CRG; Open close | 48h | arc 12 |  |
| 172 | 5.3.2.1.2 | Cut V1, V2, N line sleeves |  | 1.5d | 2013-05-29 13:00 | 2013-05-30 17:00 | 135, 171SS+0.5d | 69d | 0d | M3; M1 | 24h | arc 12 |  |
| 173 | 5.3.2.1.3 | Cut E, K, C', X, Y, N, M1, M2 and M3 |  | 2d | 2013-05-30 13:00 | 2013-06-03 12:00 | 172FS-0.5d, 136 | 69d | 0d | M4; M6 | 32h | arc 12 |  |
| 174 | 5.3.2.1.4 | Remove N line insulation+Nline connection box+ Open N line connection box and disconnect wires + remove N line cable |  | 1.5d | 2013-06-03 13:00 | 2013-06-04 17:00 | 173, 137 | 71d | 0.5d | EM1; EM2 | 24h | arc 12 |  |
| 175 | 5.3.2.1.5 | Disconnect spools and de-braze busbar |  | 1d | 2013-06-13 08:00 | 2013-06-13 17:00 | 174, 138 | 69d | 0d | EM3; EM4 | 16h | arc 12 |  |
| 176 | 5.3.2.2 | C15R1 disponible pour transport | milestone | 0d | 2013-06-13 17:00 | 2013-06-13 17:00 | 170 | 219d |  | Transport |  | arc 12 | TE MSC |
| 177 | 5.3.2.3 | **IC repairing** |  | 3d | 2013-06-25 08:00 | 2013-06-27 17:00 | 170 | 74d | 0d |  | 100h | arc 12 | TE MSC |
| 178 | 5.3.2.3.1 | Stabilization cables of adjacent magnets+ replacement of flanges |  | 3d | 2013-06-25 08:00 | 2013-06-27 17:00 | 141 | 74d | 0d | EM3; EM4; W1; M5 | 96h | arc 12 |  |
| 179 | 5.3.2.3.2 | Endoscopic inspection of adiacent PIM |  | 0.5d | 2013-06-27 13:00 | 2013-06-27 17:00 | 178FS-0.5d | 74d |  | Welding QC | 4h | arc 12 |  |
| 180 | 5.3.2.4 | **reconnection** |  | 32d | 2013-06-27 17:00 | 2013-08-12 17:00 | 177 | 74d |  |  | 304h | arc 12 | TE MSC |
| 181 | 5.3.2.4.1 | Install cryodipole | milestone | 0d | 2013-06-27 17:00 | 2013-06-27 17:00 |  | 74d | 0d | Transport |  | arc 12 |  |
| 182 | 5.3.2.4.2 | Alignement |  | 1d | 2013-06-28 08:00 | 2013-06-28 17:00 | 181 | 74d | 0.5d | Survey | 8h | arc 12 |  |
| 183 | 5.3.2.4.3 | Insertion N line cable, Braze Y, Visual inspection Y |  | 1d | 2013-07-01 13:00 | 2013-07-02 12:00 | 182, 148 | 73.5d | 0d | M2; W2; QA | 24h | arc 12 |  |
| 184 | 5.3.2.4.4 | Install PIM and weld PIM |  | 0.5d | 2013-07-02 13:00 | 2013-07-02 17:00 | 183 | 73.5d | 0d | W1; VSC; M5 | 12h | arc 12 |  |
| 185 | 5.3.2.4.5 | Weld X, E, K, C' sleeves |  | 2d | 2013-07-03 08:00 | 2013-07-04 17:00 | 184, 183 | 73.5d | 0d | W1; M2 | 32h | arc 12 |  |
| 186 | 5.3.2.4.6 | Leak test X,E, K, C', V and visual inspection |  | 2.5d | 2013-07-05 08:00 | 2013-07-09 12:00 | 185 | 73.5d | 0d | VSC; QA | 40h | arc 12 |  |
| 187 | 5.3.2.4.7 | Braze busbars, visual inspection, US check of BB, shunt installation |  | 3d | 2013-07-09 13:00 | 2013-07-12 12:00 | 186 | 73.5d | 8.5d | Train | 24h | arc 12 |  |
| 188 | 5.3.2.4.8 | Connect spools |  | 1d | 2013-07-25 08:00 | 2013-07-25 17:00 | 187, 158 | 65d | 0d | EM1; EM2 | 16h | arc 12 |  |
| 189 | 5.3.2.4.9 | Visual inspection of spool connections |  | 0.5d | 2013-07-25 13:00 | 2013-07-25 17:00 | 188SS+0.5d | 189d |  | QC | 4h | arc 12 |  |
| 190 | 5.3.2.4.10 | Connection of N line cable |  | 1d | 2013-07-26 08:00 | 2013-07-26 17:00 | 188 | 65d | 0d | EM1; EM2 | 16h | arc 12 |  |
| 191 | 5.3.2.4.11 | Visual inspection of connections |  | 0.5d | 2013-07-26 13:00 | 2013-07-26 17:00 | 190SS+0.5d | 65d | 0d | QC | 4h | arc 12 |  |
| 192 | 5.3.2.4.12 | MPAQ + AIV1 test |  | 1d | 2013-07-29 08:00 | 2013-07-29 17:00 | 190, 191 | 65d | 0d | ELQA | 8h | arc 12 |  |
| 193 | 5.3.2.4.13 | Weld N line wires |  | 2d | 2013-07-30 08:00 | 2013-07-31 17:00 | 192 | 65d | 0d | EM1; EM2 | 32h | arc 12 |  |
| 194 | 5.3.2.4.14 | AIV2 test |  | 1d | 2013-08-01 08:00 | 2013-08-01 17:00 | 193 | 65d | 0d | ELQA | 8h | arc 12 |  |
| 195 | 5.3.2.4.15 | Close N line connection box |  | 2d | 2013-08-02 08:00 | 2013-08-05 17:00 | 194 | 65d | 0d | EM1; EM2 | 32h | arc 12 |  |
| 196 | 5.3.2.4.16 | Weld N (139mm) sleeves |  | 0.5d | 2013-08-06 08:00 | 2013-08-06 12:00 | 195 | 177d | 0d | W1; M5 | 8h | arc 12 |  |
| 197 | 5.3.2.4.17 | Insulate busbars and spools |  | 0.5d | 2013-08-06 13:00 | 2013-08-06 17:00 | 196 | 177d | 0d | Train | 4h | arc 12 |  |
| 198 | 5.3.2.4.18 | Weld M1, M2, M3 and N (71mm) sleeves |  | 0.5d | 2013-08-07 08:00 | 2013-08-07 12:00 | 197 | 177d | 0d | Train | 4h | arc 12 |  |
| 199 | 5.3.2.4.19 | Visual inspection of welds |  | 0.5d | 2013-08-07 13:00 | 2013-08-07 17:00 | 198 | 177d | 0d | QA | 4h | arc 12 |  |
| 200 | 5.3.2.4.20 | Leak test M1, M2, M3 and N line welds |  | 0.5d | 2013-08-08 08:00 | 2013-08-08 12:00 | 199 | 177d | 0d | VSC | 4h | arc 12 |  |
| 201 | 5.3.2.4.21 | Install thermometers wires |  | 0.5d | 2013-08-08 13:00 | 2013-08-08 17:00 | 200 | 177d | 0d | CRG | 4h | arc 12 |  |
| 202 | 5.3.2.4.22 | General inspection before closure |  | 0.5d | 2013-08-09 08:00 | 2013-08-09 12:00 | 201 | 177d | 0d | Train | 4h | arc 12 |  |
| 203 | 5.3.2.4.23 | Install screens and MLI |  | 0.5d | 2013-08-09 13:00 | 2013-08-09 17:00 | 202 | 177d | 0d | Train | 4h | arc 12 |  |
| 204 | 5.3.2.4.24 | Close W bellows |  | 0.5d | 2013-08-12 08:00 | 2013-08-12 12:00 | 203 | 177d | 0d | Train | 4h | arc 12 |  |
| 205 | 5.3.2.4.25 | Leak test Vac sector |  | 0.5d | 2013-08-12 13:00 | 2013-08-12 17:00 | 204 | 177d |  | VSC | 4h | arc 12 |  |

| ID | WBS | Task | Type | Duration | Start | Finish | Predecessors | Total slack | Free slack | Resources | Work | Location | fla2 |
| --- | --- | --- | --- | --- | --- | --- | --- | --- | --- | --- | --- | --- | --- |
| 206 | 5.3.3 | **C30R1** |  | 60d | 2013-05-31 08:00 | 2013-08-22 17:00 |  | 67.5d |  |  | 548h | arc 12 | TE MSC |
| 207 | 5.3.3.1 | **deconnecting** |  | 11d | 2013-05-31 08:00 | 2013-06-14 17:00 |  | 67.5d | 0d |  | 144h | arc 12 | TE MSC |
| 208 | 5.3.3.1.1 | Remove thermometer wires+QC+Open |  | 2d | 2013-05-31 08:00 | 2013-06-03 17:00 | 171 | 67.5d | 0d | QC; CRG; Open close | 48h | arc 12 |  |
| 209 | 5.3.3.1.2 | Cut V1, V2, N line sleeves |  | 1.5d | 2013-05-31 13:00 | 2013-06-03 17:00 | 172, 208SS+0.5d | 69d | 0d | M3; M1 | 24h | arc 12 |  |
| 210 | 5.3.3.1.3 | Cut E, K, C', X, Y, N, M1, M2 and M3 |  | 2d | 2013-06-03 13:00 | 2013-06-05 12:00 | 209FS-0.5d, 173 | 69d | 0d | M4; M6 | 32h | arc 12 |  |
| 211 | 5.3.3.1.4 | Remove N line insulation+Nline connection box+ Open N line connection box and disconnect wires + remove N line cable |  | 1.5d | 2013-06-05 13:00 | 2013-06-06 17:00 | 210, 174 | 70.5d | 0.5d | EM1; EM2 | 24h | arc 12 |  |
| 212 | 5.3.3.1.5 | Disconnect spools and de-braze busbar |  | 1d | 2013-06-14 08:00 | 2013-06-14 17:00 | 211, 175 | 69d | 0d | EM3; EM4 | 16h | arc 12 |  |
| 213 | 5.3.3.2 | C15R1 disponible pour transport | milestone | 0d | 2013-06-14 17:00 | 2013-06-14 17:00 | 207 | 218d |  | Transport |  | arc 12 | TE MSC |
| 214 | 5.3.3.3 | **IC repairing** |  | 3d | 2013-06-28 08:00 | 2013-07-02 17:00 | 207 | 79d | 0d |  | 100h | arc 12 | TE MSC |
| 215 | 5.3.3.3.1 | Stabilization cables of adjacent magnets+ replacement of flanges |  | 3d | 2013-06-28 08:00 | 2013-07-02 17:00 | 178 | 79d | 0d | EM3; EM4; W1; M5 | 96h | arc 12 |  |
| 216 | 5.3.3.3.2 | Endoscopic inspection of adiacent PIM |  | 0.5d | 2013-07-02 13:00 | 2013-07-02 17:00 | 215FS-0.5d | 79d |  | Welding QC | 4h | arc 12 |  |
| 217 | 5.3.3.4 | **reconnection** |  | 37d | 2013-07-02 17:00 | 2013-08-22 17:00 | 214 | 79d |  |  | 304h | arc 12 | TE MSC |
| 218 | 5.3.3.4.1 | Install cryodipole | milestone | 0d | 2013-07-02 17:00 | 2013-07-02 17:00 |  | 79d | 0d | Transport |  | arc 12 |  |
| 219 | 5.3.3.4.2 | Alignement |  | 1d | 2013-07-03 08:00 | 2013-07-03 17:00 | 218 | 79d | 1d | Survey | 8h | arc 12 |  |
| 220 | 5.3.3.4.3 | Insertion N line cable, Braze Y, Visual inspection Y |  | 1d | 2013-07-05 08:00 | 2013-07-05 17:00 | 219, 185 | 78d | 0d | M2; W2; QA | 24h | arc 12 |  |
| 221 | 5.3.3.4.4 | Install PIM and weld PIM |  | 0.5d | 2013-07-08 08:00 | 2013-07-08 12:00 | 220 | 78d | 0d | W1; VSC; M5 | 12h | arc 12 |  |
| 222 | 5.3.3.4.5 | Weld X, E, K, C' sleeves |  | 2d | 2013-07-08 13:00 | 2013-07-10 12:00 | 221, 220 | 78d | 0d | W1; M2 | 32h | arc 12 |  |
| 223 | 5.3.3.4.6 | Leak test X,E, K, C', V and visual inspection |  | 2.5d | 2013-07-10 13:00 | 2013-07-12 17:00 | 222 | 78d | 0d | VSC; QA | 40h | arc 12 |  |
| 224 | 5.3.3.4.7 | Braze busbars, visual inspection, US check of BB, shunt installation |  | 3d | 2013-07-15 08:00 | 2013-07-17 17:00 | 223 | 78d | 13d | Train | 24h | arc 12 |  |
| 225 | 5.3.3.4.8 | Connect spools |  | 1d | 2013-08-06 08:00 | 2013-08-06 17:00 | 224, 195 | 65d | 0d | EM1; EM2 | 16h | arc 12 |  |
| 226 | 5.3.3.4.9 | Visual inspection of spool connections |  | 0.5d | 2013-08-06 13:00 | 2013-08-06 17:00 | 225SS+0.5d | 181d |  | QC | 4h | arc 12 |  |
| 227 | 5.3.3.4.10 | Connection of N line cable |  | 1d | 2013-08-07 08:00 | 2013-08-07 17:00 | 225 | 65d | 0d | EM1; EM2 | 16h | arc 12 |  |
| 228 | 5.3.3.4.11 | Visual inspection of connections |  | 0.5d | 2013-08-07 13:00 | 2013-08-07 17:00 | 227SS+0.5d | 65d | 0d | QC | 4h | arc 12 |  |
| 229 | 5.3.3.4.12 | MPAQ + AIV1 test |  | 1d | 2013-08-08 08:00 | 2013-08-08 17:00 | 227, 228 | 65d | 0d | ELQA | 8h | arc 12 |  |
| 230 | 5.3.3.4.13 | Weld N line wires |  | 2d | 2013-08-09 08:00 | 2013-08-12 17:00 | 229 | 65d | 0d | EM1; EM2 | 32h | arc 12 |  |
| 231 | 5.3.3.4.14 | AIV2 test |  | 1d | 2013-08-13 08:00 | 2013-08-13 17:00 | 230 | 65d | 0d | ELQA | 8h | arc 12 |  |
| 232 | 5.3.3.4.15 | Close N line connection box |  | 2d | 2013-08-14 08:00 | 2013-08-15 17:00 | 231 | 65d | 0d | EM1; EM2 | 32h | arc 12 |  |
| 233 | 5.3.3.4.16 | Weld N (139mm) sleeves |  | 0.5d | 2013-08-16 08:00 | 2013-08-16 12:00 | 232 | 169d | 0d | W1; M5 | 8h | arc 12 |  |
| 234 | 5.3.3.4.17 | Insulate busbars and spools |  | 0.5d | 2013-08-16 13:00 | 2013-08-16 17:00 | 233 | 169d | 0d | Train | 4h | arc 12 |  |
| 235 | 5.3.3.4.18 | Weld M1, M2, M3 and N (71mm) sleeves |  | 0.5d | 2013-08-19 08:00 | 2013-08-19 12:00 | 234 | 169d | 0d | Train | 4h | arc 12 |  |
| 236 | 5.3.3.4.19 | Visual inspection of welds |  | 0.5d | 2013-08-19 13:00 | 2013-08-19 17:00 | 235 | 169d | 0d | QA | 4h | arc 12 |  |
| 237 | 5.3.3.4.20 | Leak test M1, M2, M3 and N line welds |  | 0.5d | 2013-08-20 08:00 | 2013-08-20 12:00 | 236 | 169d | 0d | VSC | 4h | arc 12 |  |
| 238 | 5.3.3.4.21 | Install thermometers wires |  | 0.5d | 2013-08-20 13:00 | 2013-08-20 17:00 | 237 | 169d | 0d | CRG | 4h | arc 12 |  |
| 239 | 5.3.3.4.22 | General inspection before closure |  | 0.5d | 2013-08-21 08:00 | 2013-08-21 12:00 | 238 | 169d | 0d | Train | 4h | arc 12 |  |
| 240 | 5.3.3.4.23 | Install screens and MLI |  | 0.5d | 2013-08-21 13:00 | 2013-08-21 17:00 | 239 | 169d | 0d | Train | 4h | arc 12 |  |
| 241 | 5.3.3.4.24 | Close W bellows |  | 0.5d | 2013-08-22 08:00 | 2013-08-22 12:00 | 240 | 169d | 0d | Train | 4h | arc 12 |  |
| 242 | 5.3.3.4.25 | Leak test Vac sector |  | 0.5d | 2013-08-22 13:00 | 2013-08-22 17:00 | 241 | 169d |  | VSC | 4h | arc 12 |  |

| ID | WBS | Task | Type | Duration | Start | Finish | Predecessors | Total slack | Free slack | Resources | Work | Location | fla2 |
| --- | --- | --- | --- | --- | --- | --- | --- | --- | --- | --- | --- | --- | --- |
| 243 | 5.3.4 | **C33R1** |  | 66d | 2013-06-04 08:00 | 2013-09-03 17:00 |  | 67.5d |  |  | 548h | arc 12 | TE MSC |
| 244 | 5.3.4.1 | **deconnecting** |  | 10d | 2013-06-04 08:00 | 2013-06-17 17:00 |  | 67.5d | 0d |  | 144h | arc 12 | TE MSC |
| 245 | 5.3.4.1.1 | Remove thermometer wires+QC+Open |  | 2d | 2013-06-04 08:00 | 2013-06-05 17:00 | 208 | 67.5d | 0d | QC; CRG; Open close | 48h | arc 12 |  |
| 246 | 5.3.4.1.2 | Cut V1, V2, N line sleeves |  | 1.5d | 2013-06-04 13:00 | 2013-06-05 17:00 | 209, 245SS+0.5d | 69d | 0d | M3; M1 | 24h | arc 12 |  |
| 247 | 5.3.4.1.3 | Cut E, K, C', X, Y, N, M1, M2 and M3 |  | 2d | 2013-06-05 13:00 | 2013-06-07 12:00 | 246FS-0.5d, 210 | 69d | 0d | M4; M6 | 32h | arc 12 |  |
| 248 | 5.3.4.1.4 | Remove N line insulation+Nline connection box+ Open N line connection box and disconnect wires + remove N line cable |  | 1.5d | 2013-06-07 13:00 | 2013-06-10 17:00 | 247, 211 | 70d | 0.5d | EM1; EM2 | 24h | arc 12 |  |
| 249 | 5.3.4.1.5 | Disconnect spools and de-braze busbar |  | 1d | 2013-06-17 08:00 | 2013-06-17 17:00 | 248, 212 | 69d | 0d | EM3; EM4 | 16h | arc 12 |  |
| 250 | 5.3.4.2 | C15R1 disponible pour transport | milestone | 0d | 2013-06-17 17:00 | 2013-06-17 17:00 | 244 | 217d |  | Transport |  | arc 12 | TE MSC |
| 251 | 5.3.4.3 | **IC repairing** |  | 3d | 2013-07-03 08:00 | 2013-07-05 17:00 | 244 | 84d | 0d |  | 100h | arc 12 | TE MSC |
| 252 | 5.3.4.3.1 | Stabilization cables of adjacent magnets+ replacement of flanges |  | 3d | 2013-07-03 08:00 | 2013-07-05 17:00 | 215 | 84d | 0d | EM3; EM4; W1; M5 | 96h | arc 12 |  |
| 253 | 5.3.4.3.2 | Endoscopic inspection of adiacent PIM |  | 0.5d | 2013-07-05 13:00 | 2013-07-05 17:00 | 252FS-0.5d | 84d |  | Welding QC | 4h | arc 12 |  |
| 254 | 5.3.4.4 | **reconnection** |  | 42d | 2013-07-05 17:00 | 2013-09-03 17:00 | 251 | 84d |  |  | 304h | arc 12 | TE MSC |
| 255 | 5.3.4.4.1 | Install cryodipole | milestone | 0d | 2013-07-05 17:00 | 2013-07-05 17:00 |  | 84d | 0d | Transport |  | arc 12 |  |
| 256 | 5.3.4.4.2 | Alignement |  | 1d | 2013-07-08 08:00 | 2013-07-08 17:00 | 255 | 84d | 1.5d | Survey | 8h | arc 12 |  |
| 257 | 5.3.4.4.3 | Insertion N line cable, Braze Y, Visual inspection Y |  | 1d | 2013-07-10 13:00 | 2013-07-11 12:00 | 256, 222 | 82.5d | 0d | M2; W2; QA | 24h | arc 12 |  |
| 258 | 5.3.4.4.4 | Install PIM and weld PIM |  | 0.5d | 2013-07-11 13:00 | 2013-07-11 17:00 | 257 | 82.5d | 0d | W1; VSC; M5 | 12h | arc 12 |  |
| 259 | 5.3.4.4.5 | Weld X, E, K, C' sleeves |  | 2d | 2013-07-12 08:00 | 2013-07-15 17:00 | 258, 257 | 82.5d | 0d | W1; M2 | 32h | arc 12 |  |
| 260 | 5.3.4.4.6 | Leak test X,E, K, C', V and visual inspection |  | 2.5d | 2013-07-16 08:00 | 2013-07-18 12:00 | 259 | 82.5d | 0d | VSC; QA | 40h | arc 12 |  |
| 261 | 5.3.4.4.7 | Braze busbars, visual inspection, US check of BB, shunt installation |  | 3d | 2013-07-18 13:00 | 2013-07-23 12:00 | 260 | 82.5d | 17.5d | Train | 24h | arc 12 |  |
| 262 | 5.3.4.4.8 | Connect spools |  | 1d | 2013-08-16 08:00 | 2013-08-16 17:00 | 261, 232 | 65d | 0d | EM1; EM2 | 16h | arc 12 |  |
| 263 | 5.3.4.4.9 | Visual inspection of spool connections |  | 0.5d | 2013-08-16 13:00 | 2013-08-16 17:00 | 262SS+0.5d | 173d |  | QC | 4h | arc 12 |  |
| 264 | 5.3.4.4.10 | Connection of N line cable |  | 1d | 2013-08-19 08:00 | 2013-08-19 17:00 | 262 | 65d | 0d | EM1; EM2 | 16h | arc 12 |  |
| 265 | 5.3.4.4.11 | Visual inspection of connections |  | 0.5d | 2013-08-19 13:00 | 2013-08-19 17:00 | 264SS+0.5d | 65d | 0d | QC | 4h | arc 12 |  |
| 266 | 5.3.4.4.12 | MPAQ + AIV1 test |  | 1d | 2013-08-20 08:00 | 2013-08-20 17:00 | 264, 265 | 65d | 0d | ELQA | 8h | arc 12 |  |
| 267 | 5.3.4.4.13 | Weld N line wires |  | 2d | 2013-08-21 08:00 | 2013-08-22 17:00 | 266 | 65d | 0d | EM1; EM2 | 32h | arc 12 |  |
| 268 | 5.3.4.4.14 | AIV2 test |  | 1d | 2013-08-23 08:00 | 2013-08-23 17:00 | 267 | 65d | 0d | ELQA | 8h | arc 12 |  |
| 269 | 5.3.4.4.15 | Close N line connection box |  | 2d | 2013-08-26 08:00 | 2013-08-27 17:00 | 268 | 65d | 0d | EM1; EM2 | 32h | arc 12 |  |
| 270 | 5.3.4.4.16 | Weld N (139mm) sleeves |  | 0.5d | 2013-08-28 08:00 | 2013-08-28 12:00 | 269 | 161d | 0d | W1; M5 | 8h | arc 12 |  |
| 271 | 5.3.4.4.17 | Insulate busbars and spools |  | 0.5d | 2013-08-28 13:00 | 2013-08-28 17:00 | 270 | 161d | 0d | Train | 4h | arc 12 |  |
| 272 | 5.3.4.4.18 | Weld M1, M2, M3 and N (71mm) sleeves |  | 0.5d | 2013-08-29 08:00 | 2013-08-29 12:00 | 271 | 161d | 0d | Train | 4h | arc 12 |  |
| 273 | 5.3.4.4.19 | Visual inspection of welds |  | 0.5d | 2013-08-29 13:00 | 2013-08-29 17:00 | 272 | 161d | 0d | QA | 4h | arc 12 |  |
| 274 | 5.3.4.4.20 | Leak test M1, M2, M3 and N line welds |  | 0.5d | 2013-08-30 08:00 | 2013-08-30 12:00 | 273 | 161d | 0d | VSC | 4h | arc 12 |  |
| 275 | 5.3.4.4.21 | Install thermometers wires |  | 0.5d | 2013-08-30 13:00 | 2013-08-30 17:00 | 274 | 161d | 0d | CRG | 4h | arc 12 |  |
| 276 | 5.3.4.4.22 | General inspection before closure |  | 0.5d | 2013-09-02 08:00 | 2013-09-02 12:00 | 275 | 161d | 0d | Train | 4h | arc 12 |  |
| 277 | 5.3.4.4.23 | Install screens and MLI |  | 0.5d | 2013-09-02 13:00 | 2013-09-02 17:00 | 276 | 161d | 0d | Train | 4h | arc 12 |  |
| 278 | 5.3.4.4.24 | Close W bellows |  | 0.5d | 2013-09-03 08:00 | 2013-09-03 12:00 | 277 | 161d | 0d | Train | 4h | arc 12 |  |
| 279 | 5.3.4.4.25 | Leak test Vac sector |  | 0.5d | 2013-09-03 13:00 | 2013-09-03 17:00 | 278 | 161d |  | VSC | 4h | arc 12 |  |

| ID | WBS | Task | Type | Duration | Start | Finish | Predecessors | Total slack | Free slack | Resources | Work | Location | fla2 |
| --- | --- | --- | --- | --- | --- | --- | --- | --- | --- | --- | --- | --- | --- |
| 280 | 5.3.5 | **C33L2** |  | 72d | 2013-06-06 08:00 | 2013-09-16 17:00 |  | 67.5d |  |  | 548h | arc 12 | TE MSC |
| 281 | 5.3.5.1 | **deconnecting** |  | 9d | 2013-06-06 08:00 | 2013-06-18 17:00 |  | 67.5d | 0d |  | 144h | arc 12 | TE MSC |
| 282 | 5.3.5.1.1 | Remove thermometer wires+QC+Open |  | 2d | 2013-06-06 08:00 | 2013-06-07 17:00 | 245 | 67.5d | 0d | QC; CRG; Open close | 48h | arc 12 |  |
| 283 | 5.3.5.1.2 | Cut V1, V2, N line sleeves |  | 1.5d | 2013-06-06 13:00 | 2013-06-07 17:00 | 246, 282SS+0.5d | 69d | 0d | M3; M1 | 24h | arc 12 |  |
| 284 | 5.3.5.1.3 | Cut E, K, C', X, Y, N, M1, M2 and M3 |  | 2d | 2013-06-07 13:00 | 2013-06-11 12:00 | 283FS-0.5d, 247 | 69d | 0d | M4; M6 | 32h | arc 12 |  |
| 285 | 5.3.5.1.4 | Remove N line insulation+Nline connection box+ Open N line connection box and disconnect wires + remove N line cable |  | 1.5d | 2013-06-11 13:00 | 2013-06-12 17:00 | 284, 248 | 69.5d | 2d | EM1; EM2 | 24h | arc 12 |  |
| 286 | 5.3.5.1.5 | Disconnect spools and de-braze busbar |  | 1d | 2013-06-18 08:00 | 2013-06-18 17:00 | 285, 249 | 69d | 0d | EM3; EM4 | 16h | arc 12 |  |
| 287 | 5.3.5.2 | C15R1 disponible pour transport | milestone | 0d | 2013-06-18 17:00 | 2013-06-18 17:00 | 281 | 216d |  | Transport |  | arc 12 | TE MSC |
| 288 | 5.3.5.3 | **IC repairing** |  | 3d | 2013-07-08 08:00 | 2013-07-10 17:00 | 281 | 89d | 0d |  | 100h | arc 12 | TE MSC |
| 289 | 5.3.5.3.1 | Stabilization cables of adjacent magnets+ replacement of flanges |  | 3d | 2013-07-08 08:00 | 2013-07-10 17:00 | 252 | 89d | 0d | EM3; EM4; W1; M5 | 96h | arc 12 |  |
| 290 | 5.3.5.3.2 | Endoscopic inspection of adiacent PIM |  | 0.5d | 2013-07-10 13:00 | 2013-07-10 17:00 | 289FS-0.5d | 89d |  | Welding QC | 4h | arc 12 |  |
| 291 | 5.3.5.4 | **reconnection** |  | 47d | 2013-07-10 17:00 | 2013-09-16 17:00 | 288 | 89d |  |  | 304h | arc 12 | TE MSC |
| 292 | 5.3.5.4.1 | Install cryodipole | milestone | 0d | 2013-07-10 17:00 | 2013-07-10 17:00 |  | 89d | 0d | Transport |  | arc 12 |  |
| 293 | 5.3.5.4.2 | Alignement |  | 1d | 2013-07-11 08:00 | 2013-07-11 17:00 | 292 | 89d | 2d | Survey | 8h | arc 12 |  |
| 294 | 5.3.5.4.3 | Insertion N line cable, Braze Y, Visual inspection Y |  | 1d | 2013-07-16 08:00 | 2013-07-16 17:00 | 293, 259 | 87d | 0d | M2; W2; QA | 24h | arc 12 |  |
| 295 | 5.3.5.4.4 | Install PIM and weld PIM |  | 0.5d | 2013-07-17 08:00 | 2013-07-17 12:00 | 294 | 87d | 0d | W1; VSC; M5 | 12h | arc 12 |  |
| 296 | 5.3.5.4.5 | Weld X, E, K, C' sleeves |  | 2d | 2013-07-17 13:00 | 2013-07-19 12:00 | 295, 294 | 87d | 0d | W1; M2 | 32h | arc 12 |  |
| 297 | 5.3.5.4.6 | Leak test X,E, K, C', V and visual inspection |  | 2.5d | 2013-07-19 13:00 | 2013-07-23 17:00 | 296 | 87d | 0d | VSC; QA | 40h | arc 12 |  |
| 298 | 5.3.5.4.7 | Braze busbars, visual inspection, US check of BB, shunt installation |  | 3d | 2013-07-24 08:00 | 2013-07-26 17:00 | 297 | 87d | 22d | Train | 24h | arc 12 |  |
| 299 | 5.3.5.4.8 | Connect spools |  | 1d | 2013-08-28 08:00 | 2013-08-28 17:00 | 298, 269 | 65d | 0d | EM1; EM2 | 16h | arc 12 |  |
| 300 | 5.3.5.4.9 | Visual inspection of spool connections |  | 0.5d | 2013-08-28 13:00 | 2013-08-28 17:00 | 299SS+0.5d | 165d |  | QC | 4h | arc 12 |  |
| 301 | 5.3.5.4.10 | Connection of N line cable |  | 1d | 2013-08-29 08:00 | 2013-08-29 17:00 | 299 | 65d | 0d | EM1; EM2 | 16h | arc 12 |  |
| 302 | 5.3.5.4.11 | Visual inspection of connections |  | 0.5d | 2013-08-29 13:00 | 2013-08-29 17:00 | 301SS+0.5d | 65d | 0d | QC | 4h | arc 12 |  |
| 303 | 5.3.5.4.12 | MPAQ + AIV1 test |  | 1d | 2013-08-30 08:00 | 2013-08-30 17:00 | 301, 302 | 65d | 0d | ELQA | 8h | arc 12 |  |
| 304 | 5.3.5.4.13 | Weld N line wires |  | 2d | 2013-09-02 08:00 | 2013-09-03 17:00 | 303 | 65d | 0d | EM1; EM2 | 32h | arc 12 |  |
| 305 | 5.3.5.4.14 | AIV2 test |  | 1d | 2013-09-04 08:00 | 2013-09-04 17:00 | 304 | 65d | 0d | ELQA | 8h | arc 12 |  |
| 306 | 5.3.5.4.15 | Close N line connection box |  | 2d | 2013-09-06 08:00 | 2013-09-09 17:00 | 305 | 65d | 0d | EM1; EM2 | 32h | arc 12 |  |
| 307 | 5.3.5.4.16 | Weld N (139mm) sleeves |  | 0.5d | 2013-09-10 08:00 | 2013-09-10 12:00 | 306 | 153d | 0d | W1; M5 | 8h | arc 12 |  |
| 308 | 5.3.5.4.17 | Insulate busbars and spools |  | 0.5d | 2013-09-10 13:00 | 2013-09-10 17:00 | 307 | 153d | 0d | Train | 4h | arc 12 |  |
| 309 | 5.3.5.4.18 | Weld M1, M2, M3 and N (71mm) sleeves |  | 0.5d | 2013-09-11 08:00 | 2013-09-11 12:00 | 308 | 153d | 0d | Train | 4h | arc 12 |  |
| 310 | 5.3.5.4.19 | Visual inspection of welds |  | 0.5d | 2013-09-11 13:00 | 2013-09-11 17:00 | 309 | 153d | 0d | QA | 4h | arc 12 |  |
| 311 | 5.3.5.4.20 | Leak test M1, M2, M3 and N line welds |  | 0.5d | 2013-09-12 08:00 | 2013-09-12 12:00 | 310 | 153d | 0d | VSC | 4h | arc 12 |  |
| 312 | 5.3.5.4.21 | Install thermometers wires |  | 0.5d | 2013-09-12 13:00 | 2013-09-12 17:00 | 311 | 153d | 0d | CRG | 4h | arc 12 |  |
| 313 | 5.3.5.4.22 | General inspection before closure |  | 0.5d | 2013-09-13 08:00 | 2013-09-13 12:00 | 312 | 153d | 0d | Train | 4h | arc 12 |  |
| 314 | 5.3.5.4.23 | Install screens and MLI |  | 0.5d | 2013-09-13 13:00 | 2013-09-13 17:00 | 313 | 153d | 0d | Train | 4h | arc 12 |  |
| 315 | 5.3.5.4.24 | Close W bellows |  | 0.5d | 2013-09-16 08:00 | 2013-09-16 12:00 | 314 | 153d | 0d | Train | 4h | arc 12 |  |
| 316 | 5.3.5.4.25 | Leak test Vac sector |  | 0.5d | 2013-09-16 13:00 | 2013-09-16 17:00 | 315 | 153d |  | VSC | 4h | arc 12 |  |

| ID | WBS | Task | Type | Duration | Start | Finish | Predecessors | Total slack | Free slack | Resources | Work | Location | fla2 |
| --- | --- | --- | --- | --- | --- | --- | --- | --- | --- | --- | --- | --- | --- |
| 317 | 5.3.6 | **A29L2** |  | 78d | 2013-06-10 08:00 | 2013-09-26 17:00 |  | 67.5d |  |  | 548h | arc 12 | TE MSC |
| 318 | 5.3.6.1 | **deconnecting** |  | 8d | 2013-06-10 08:00 | 2013-06-19 17:00 |  | 67.5d | 0d |  | 144h | arc 12 | TE MSC |
| 319 | 5.3.6.1.1 | Remove thermometer wires+QC+Open |  | 2d | 2013-06-10 08:00 | 2013-06-11 17:00 | 282 | 67.5d | 0d | QC; CRG; Open close | 48h | arc 12 |  |
| 320 | 5.3.6.1.2 | Cut V1, V2, N line sleeves |  | 1.5d | 2013-06-12 08:00 | 2013-06-13 12:00 | 283, 319 | 67.5d | 0d | M3; M1 | 24h | arc 12 |  |
| 321 | 5.3.6.1.3 | Cut E, K, C', X, Y, N, M1, M2 and M3 |  | 2d | 2013-06-13 08:00 | 2013-06-14 17:00 | 320FS-0.5d, 284 | 67.5d | 0d | M4; M6 | 32h | arc 12 |  |
| 322 | 5.3.6.1.4 | Remove N line insulation+Nline connection box+ Open N line connection box and disconnect wires + remove N line cable |  | 1.5d | 2013-06-17 08:00 | 2013-06-18 12:00 | 321, 285 | 67.5d | 0.5d | EM1; EM2 | 24h | arc 12 |  |
| 323 | 5.3.6.1.5 | Disconnect spools and de-braze busbar |  | 1d | 2013-06-19 08:00 | 2013-06-19 17:00 | 322, 286 | 69d | 0d | EM3; EM4 | 16h | arc 12 |  |
| 324 | 5.3.6.2 | C15R1 disponible pour transport | milestone | 0d | 2013-06-19 17:00 | 2013-06-19 17:00 | 318 | 215d |  | Transport |  | arc 12 | TE MSC |
| 325 | 5.3.6.3 | **IC repairing** |  | 3d | 2013-07-11 08:00 | 2013-07-15 17:00 | 318 | 94d | 0d |  | 100h | arc 12 | TE MSC |
| 326 | 5.3.6.3.1 | Stabilization cables of adjacent magnets+ replacement of flanges |  | 3d | 2013-07-11 08:00 | 2013-07-15 17:00 | 289 | 94d | 0d | EM3; EM4; W1; M5 | 96h | arc 12 |  |
| 327 | 5.3.6.3.2 | Endoscopic inspection of adiacent PIM |  | 0.5d | 2013-07-15 13:00 | 2013-07-15 17:00 | 326FS-0.5d | 94d |  | Welding QC | 4h | arc 12 |  |
| 328 | 5.3.6.4 | **reconnection** |  | 52d | 2013-07-15 17:00 | 2013-09-26 17:00 | 325 | 94d |  |  | 304h | arc 12 | TE MSC |
| 329 | 5.3.6.4.1 | Install cryodipole | milestone | 0d | 2013-07-15 17:00 | 2013-07-15 17:00 |  | 94d | 0d | Transport |  | arc 12 |  |
| 330 | 5.3.6.4.2 | Alignement |  | 1d | 2013-07-16 08:00 | 2013-07-16 17:00 | 329 | 94d | 2.5d | Survey | 8h | arc 12 |  |
| 331 | 5.3.6.4.3 | Insertion N line cable, Braze Y, Visual inspection Y |  | 1d | 2013-07-19 13:00 | 2013-07-22 12:00 | 330, 296 | 91.5d | 0d | M2; W2; QA | 24h | arc 12 |  |
| 332 | 5.3.6.4.4 | Install PIM and weld PIM |  | 0.5d | 2013-07-22 13:00 | 2013-07-22 17:00 | 331 | 91.5d | 0d | W1; VSC; M5 | 12h | arc 12 |  |
| 333 | 5.3.6.4.5 | Weld X, E, K, C' sleeves |  | 2d | 2013-07-23 08:00 | 2013-07-24 17:00 | 332, 331 | 91.5d | 0d | W1; M2 | 32h | arc 12 |  |
| 334 | 5.3.6.4.6 | Leak test X,E, K, C', V and visual inspection |  | 2.5d | 2013-07-25 08:00 | 2013-07-29 12:00 | 333 | 91.5d | 0d | VSC; QA | 40h | arc 12 |  |
| 335 | 5.3.6.4.7 | Braze busbars, visual inspection, US check of BB, shunt installation |  | 3d | 2013-07-29 13:00 | 2013-08-01 12:00 | 334 | 91.5d | 26.5d | Train | 24h | arc 12 |  |
| 336 | 5.3.6.4.8 | Connect spools |  | 1d | 2013-09-10 08:00 | 2013-09-10 17:00 | 335, 306 | 65d | 0d | EM1; EM2 | 16h | arc 12 |  |
| 337 | 5.3.6.4.9 | Visual inspection of spool connections |  | 0.5d | 2013-09-10 13:00 | 2013-09-10 17:00 | 336SS+0.5d | 157d |  | QC | 4h | arc 12 |  |
| 338 | 5.3.6.4.10 | Connection of N line cable |  | 1d | 2013-09-11 08:00 | 2013-09-11 17:00 | 336 | 65d | 0d | EM1; EM2 | 16h | arc 12 |  |
| 339 | 5.3.6.4.11 | Visual inspection of connections |  | 0.5d | 2013-09-11 13:00 | 2013-09-11 17:00 | 338SS+0.5d | 65d | 0d | QC | 4h | arc 12 |  |
| 340 | 5.3.6.4.12 | MPAQ + AIV1 test |  | 1d | 2013-09-12 08:00 | 2013-09-12 17:00 | 338, 339 | 65d | 0d | ELQA | 8h | arc 12 |  |
| 341 | 5.3.6.4.13 | Weld N line wires |  | 2d | 2013-09-13 08:00 | 2013-09-16 17:00 | 340 | 65d | 0d | EM1; EM2 | 32h | arc 12 |  |
| 342 | 5.3.6.4.14 | AIV2 test |  | 1d | 2013-09-17 08:00 | 2013-09-17 17:00 | 341 | 65d | 0d | ELQA | 8h | arc 12 |  |
| 343 | 5.3.6.4.15 | Close N line connection box |  | 2d | 2013-09-18 08:00 | 2013-09-19 17:00 | 342 | 65d | 0d | EM1; EM2 | 32h | arc 12 |  |
| 344 | 5.3.6.4.16 | Weld N (139mm) sleeves |  | 0.5d | 2013-09-20 08:00 | 2013-09-20 12:00 | 343 | 145d | 0d | W1; M5 | 8h | arc 12 |  |
| 345 | 5.3.6.4.17 | Insulate busbars and spools |  | 0.5d | 2013-09-20 13:00 | 2013-09-20 17:00 | 344 | 145d | 0d | Train | 4h | arc 12 |  |
| 346 | 5.3.6.4.18 | Weld M1, M2, M3 and N (71mm) sleeves |  | 0.5d | 2013-09-23 08:00 | 2013-09-23 12:00 | 345 | 145d | 0d | Train | 4h | arc 12 |  |
| 347 | 5.3.6.4.19 | Visual inspection of welds |  | 0.5d | 2013-09-23 13:00 | 2013-09-23 17:00 | 346 | 145d | 0d | QA | 4h | arc 12 |  |
| 348 | 5.3.6.4.20 | Leak test M1, M2, M3 and N line welds |  | 0.5d | 2013-09-24 08:00 | 2013-09-24 12:00 | 347 | 145d | 0d | VSC | 4h | arc 12 |  |
| 349 | 5.3.6.4.21 | Install thermometers wires |  | 0.5d | 2013-09-24 13:00 | 2013-09-24 17:00 | 348 | 145d | 0d | CRG | 4h | arc 12 |  |
| 350 | 5.3.6.4.22 | General inspection before closure |  | 0.5d | 2013-09-25 08:00 | 2013-09-25 12:00 | 349 | 145d | 0d | Train | 4h | arc 12 |  |
| 351 | 5.3.6.4.23 | Install screens and MLI |  | 0.5d | 2013-09-25 13:00 | 2013-09-25 17:00 | 350 | 145d | 0d | Train | 4h | arc 12 |  |
| 352 | 5.3.6.4.24 | Close W bellows |  | 0.5d | 2013-09-26 08:00 | 2013-09-26 12:00 | 351 | 145d | 0d | Train | 4h | arc 12 |  |
| 353 | 5.3.6.4.25 | Leak test Vac sector |  | 0.5d | 2013-09-26 13:00 | 2013-09-26 17:00 | 352 | 145d |  | VSC | 4h | arc 12 |  |

| ID | WBS | Task | Type | Duration | Start | Finish | Predecessors | Total slack | Free slack | Constraint | Resources | Work | Location | fla2 |
| --- | --- | --- | --- | --- | --- | --- | --- | --- | --- | --- | --- | --- | --- | --- |
| 354 | 6 | **Sector 23** |  | 171d | 2013-06-12 08:00 | 2014-02-20 17:00 |  | 50d |  |  |  | 2260h | arc 23 |  |
| 355 | 6.1 | Train |  | 77d | 2013-10-23 08:00 | 2014-02-20 17:00 |  | 50d |  | finish no earlier than 2014-02-20 17:00 | Train | 616h | arc 23 |  |
| 356 | 6.2 | Mounting insulation start | milestone | 0d | 2014-01-06 08:00 | 2014-01-06 08:00 |  | 84d |  | start no earlier than 2014-01-06 08:00 |  |  |  |  |
| 357 | 6.3 | **Aimants** |  | 100d | 2013-06-12 08:00 | 2013-10-30 17:00 |  | 115.5d |  | start no earlier than 2013-06-03 08:00 |  | 1644h | arc 23 | TE MSC |
| 358 | 6.3.1 | **A23R2** |  | 84d | 2013-06-12 08:00 | 2013-10-08 17:00 |  | 115.5d |  |  |  | 548h | arc 23 | TE MSC |
| 359 | 6.3.1.1 | **deconnecting** |  | 26.5d | 2013-06-12 08:00 | 2013-07-18 12:00 |  | 96.5d | 0d |  |  | 144h | arc 23 | TE MSC |
| 360 | 6.3.1.1.1 | Remove thermometer wires+QC+Open |  | 2d | 2013-06-12 08:00 | 2013-06-13 17:00 | 319 | 115.5d | 0d |  | QC; CRG; Open close | 48h | arc 23 |  |
| 361 | 6.3.1.1.2 | Cut V1, V2, N line sleeves |  | 1.5d | 2013-06-14 08:00 | 2013-06-17 12:00 | 320, 360 | 115.5d | 0d |  | M3; M1 | 24h | arc 23 |  |
| 362 | 6.3.1.1.3 | Cut E, K, C', X, Y, N, M1, M2 and M3 |  | 2d | 2013-06-17 08:00 | 2013-06-18 17:00 | 361FS-0.5d, 321 | 115.5d | 0d |  | M4; M6 | 32h | arc 23 |  |
| 363 | 6.3.1.1.4 | Remove N line insulation+Nline connection box+ Open N line connection box and disconnect wires + remove N line cable |  | 1.5d | 2013-07-16 08:00 | 2013-07-17 12:00 | 362, 326 | 96.5d | 0d |  | EM4; EM3 | 24h | arc 23 |  |
| 364 | 6.3.1.1.5 | Disconnect spools and de-braze busbar |  | 1d | 2013-07-17 13:00 | 2013-07-18 12:00 | 363, 326 | 96.5d | 0d |  | EM3; EM4 | 16h | arc 23 |  |
| 365 | 6.3.1.2 | C15R1 disponible pour transport | milestone | 0d | 2013-07-18 12:00 | 2013-07-18 12:00 | 359 | 194.5d |  |  | Transport |  | arc 23 | TE MSC |
| 366 | 6.3.1.3 | **IC repairing** |  | 3d | 2013-07-18 13:00 | 2013-07-23 12:00 | 359 | 96.5d | 0d |  |  | 100h | arc 23 | TE MSC |
| 367 | 6.3.1.3.1 | Stabilization cables of adjacent magnets+ replacement of flanges |  | 3d | 2013-07-18 13:00 | 2013-07-23 12:00 | 364 | 96.5d | 0d |  | EM3; EM4; W1; M5 | 96h | arc 23 |  |
| 368 | 6.3.1.3.2 | Endoscopic inspection of adiacent PIM |  | 0.5d | 2013-07-23 08:00 | 2013-07-23 12:00 | 367FS-0.5d | 96.5d |  |  | Welding QC | 4h | arc 23 |  |
| 369 | 6.3.1.4 | **reconnection** |  | 54.5d | 2013-07-23 12:00 | 2013-10-08 17:00 | 366 | 96.5d |  |  |  | 304h | arc 23 | TE MSC |
| 370 | 6.3.1.4.1 | Install cryodipole | milestone | 0d | 2013-07-23 12:00 | 2013-07-23 12:00 |  | 96.5d | 0d |  | Transport |  | arc 23 |  |
| 371 | 6.3.1.4.2 | Alignement |  | 1d | 2013-07-23 13:00 | 2013-07-24 12:00 | 370 | 96.5d | 0.5d |  | Survey | 8h | arc 23 |  |
| 372 | 6.3.1.4.3 | Insertion N line cable, Braze Y, Visual inspection Y |  | 1d | 2013-07-25 08:00 | 2013-07-25 17:00 | 371, 333 | 96d | 0d |  | M2; W2; QA | 24h | arc 23 |  |
| 373 | 6.3.1.4.4 | Install PIM and weld PIM |  | 0.5d | 2013-07-26 08:00 | 2013-07-26 12:00 | 372 | 96d | 0d |  | W1; VSC; M5 | 12h | arc 23 |  |
| 374 | 6.3.1.4.5 | Weld X, E, K, C' sleeves |  | 2d | 2013-07-26 13:00 | 2013-07-30 12:00 | 373, 372 | 96d | 0d |  | W1; M2 | 32h | arc 23 |  |
| 375 | 6.3.1.4.6 | Leak test X,E, K, C', V and visual inspection |  | 2.5d | 2013-07-30 13:00 | 2013-08-01 17:00 | 374 | 96d | 0d |  | VSC; QA | 40h | arc 23 |  |
| 376 | 6.3.1.4.7 | Braze busbars, visual inspection, US check of BB, shunt installation |  | 3d | 2013-08-02 08:00 | 2013-08-06 17:00 | 375 | 96d | 31d |  | Train | 24h | arc 23 |  |
| 377 | 6.3.1.4.8 | Connect spools |  | 1d | 2013-09-20 08:00 | 2013-09-20 17:00 | 376, 343 | 65d | 0d |  | EM1; EM2 | 16h | arc 23 |  |
| 378 | 6.3.1.4.9 | Visual inspection of spool connections |  | 0.5d | 2013-09-20 13:00 | 2013-09-20 17:00 | 377SS+0.5d | 149d |  |  | QC | 4h | arc 23 |  |
| 379 | 6.3.1.4.10 | Connection of N line cable |  | 1d | 2013-09-23 08:00 | 2013-09-23 17:00 | 377 | 65d | 0d |  | EM1; EM2 | 16h | arc 23 |  |
| 380 | 6.3.1.4.11 | Visual inspection of connections |  | 0.5d | 2013-09-23 13:00 | 2013-09-23 17:00 | 379SS+0.5d | 65d | 0d |  | QC | 4h | arc 23 |  |
| 381 | 6.3.1.4.12 | MPAQ + AIV1 test |  | 1d | 2013-09-24 08:00 | 2013-09-24 17:00 | 379, 380 | 65d | 0d |  | ELQA | 8h | arc 23 |  |
| 382 | 6.3.1.4.13 | Weld N line wires |  | 2d | 2013-09-25 08:00 | 2013-09-26 17:00 | 381 | 65d | 0d |  | EM1; EM2 | 32h | arc 23 |  |
| 383 | 6.3.1.4.14 | AIV2 test |  | 1d | 2013-09-27 08:00 | 2013-09-27 17:00 | 382 | 65d | 0d |  | ELQA | 8h | arc 23 |  |
| 384 | 6.3.1.4.15 | Close N line connection box |  | 2d | 2013-09-30 08:00 | 2013-10-01 17:00 | 383 | 65d | 0d |  | EM1; EM2 | 32h | arc 23 |  |
| 385 | 6.3.1.4.16 | Weld N (139mm) sleeves |  | 0.5d | 2013-10-02 08:00 | 2013-10-02 12:00 | 384 | 137d | 0d |  | W1; M5 | 8h | arc 23 |  |
| 386 | 6.3.1.4.17 | Insulate busbars and spools |  | 0.5d | 2013-10-02 13:00 | 2013-10-02 17:00 | 385 | 137d | 0d |  | Train | 4h | arc 23 |  |
| 387 | 6.3.1.4.18 | Weld M1, M2, M3 and N (71mm) sleeves |  | 0.5d | 2013-10-03 08:00 | 2013-10-03 12:00 | 386 | 137d | 0d |  | Train | 4h | arc 23 |  |
| 388 | 6.3.1.4.19 | Visual inspection of welds |  | 0.5d | 2013-10-03 13:00 | 2013-10-03 17:00 | 387 | 137d | 0d |  | QA | 4h | arc 23 |  |
| 389 | 6.3.1.4.20 | Leak test M1, M2, M3 and N line welds |  | 0.5d | 2013-10-04 08:00 | 2013-10-04 12:00 | 388 | 137d | 0d |  | VSC | 4h | arc 23 |  |
| 390 | 6.3.1.4.21 | Install thermometers wires |  | 0.5d | 2013-10-04 13:00 | 2013-10-04 17:00 | 389 | 137d | 0d |  | CRG | 4h | arc 23 |  |
| 391 | 6.3.1.4.22 | General inspection before closure |  | 0.5d | 2013-10-07 08:00 | 2013-10-07 12:00 | 390 | 137d | 0d |  | Train | 4h | arc 23 |  |
| 392 | 6.3.1.4.23 | Install screens and MLI |  | 0.5d | 2013-10-07 13:00 | 2013-10-07 17:00 | 391 | 137d | 0d |  | Train | 4h | arc 23 |  |
| 393 | 6.3.1.4.24 | Close W bellows |  | 0.5d | 2013-10-08 08:00 | 2013-10-08 12:00 | 392 | 137d | 0d |  | Train | 4h | arc 23 |  |
| 394 | 6.3.1.4.25 | Leak test Vac sector |  | 0.5d | 2013-10-08 13:00 | 2013-10-08 17:00 | 393 | 137d |  |  | VSC | 4h | arc 23 |  |

Notes:
- 357: According to skeleton

| ID | WBS | Task | Type | Duration | Start | Finish | Predecessors | Total slack | Free slack | Resources | Work | Location | fla2 |
| --- | --- | --- | --- | --- | --- | --- | --- | --- | --- | --- | --- | --- | --- |
| 395 | 6.3.2 | **B25R2** |  | 90d | 2013-06-14 08:00 | 2013-10-18 17:00 |  | 121.5d |  |  | 548h | arc 23 | TE MSC |
| 396 | 6.3.2.1 | **deconnecting** |  | 30d | 2013-06-14 08:00 | 2013-07-25 17:00 |  | 99d | 0d |  | 144h | arc 23 | TE MSC |
| 397 | 6.3.2.1.1 | Remove thermometer wires+QC+Open |  | 2d | 2013-06-14 08:00 | 2013-06-17 17:00 | 360 | 121.5d | 0d | QC; CRG; Open close | 48h | arc 23 |  |
| 398 | 6.3.2.1.2 | Cut V1, V2, N line sleeves |  | 1.5d | 2013-06-18 08:00 | 2013-06-19 12:00 | 361, 397 | 121.5d | 0d | M3; M1 | 24h | arc 23 |  |
| 399 | 6.3.2.1.3 | Cut E, K, C', X, Y, N, M1, M2 and M3 |  | 2d | 2013-06-19 08:00 | 2013-06-20 17:00 | 398FS-0.5d, 362 | 121.5d | 0d | M4; M6 | 32h | arc 23 |  |
| 400 | 6.3.2.1.4 | Remove N line insulation+Nline connection box+ Open N line connection box and disconnect wires + remove N line cable |  | 1.5d | 2013-07-23 13:00 | 2013-07-24 17:00 | 399, 367 | 99d | 0d | EM4; EM3 | 24h | arc 23 |  |
| 401 | 6.3.2.1.5 | Disconnect spools and de-braze busbar |  | 1d | 2013-07-25 08:00 | 2013-07-25 17:00 | 400 | 99d | 0d | EM3; EM4 | 16h | arc 23 |  |
| 402 | 6.3.2.2 | C15R1 disponible pour transport | milestone | 0d | 2013-07-25 17:00 | 2013-07-25 17:00 | 396 | 189d |  | Transport |  | arc 23 | TE MSC |
| 403 | 6.3.2.3 | **IC repairing** |  | 3d | 2013-07-26 08:00 | 2013-07-30 17:00 | 396 | 99d | 0d |  | 100h | arc 23 | TE MSC |
| 404 | 6.3.2.3.1 | Stabilization cables of adjacent magnets+ replacement of flanges |  | 3d | 2013-07-26 08:00 | 2013-07-30 17:00 | 401 | 99d | 0d | EM3; EM4; W1; M5 | 96h | arc 23 |  |
| 405 | 6.3.2.3.2 | Endoscopic inspection of adiacent PIM |  | 0.5d | 2013-07-30 13:00 | 2013-07-30 17:00 | 404FS-0.5d | 99d |  | Welding QC | 4h | arc 23 |  |
| 406 | 6.3.2.4 | **reconnection** |  | 57d | 2013-07-30 17:00 | 2013-10-18 17:00 | 403 | 99d |  |  | 304h | arc 23 | TE MSC |
| 407 | 6.3.2.4.1 | Install cryodipole | milestone | 0d | 2013-07-30 17:00 | 2013-07-30 17:00 |  | 99d | 0d | Transport |  | arc 23 |  |
| 408 | 6.3.2.4.2 | Alignement |  | 1d | 2013-07-31 08:00 | 2013-07-31 17:00 | 407 | 99d | 0d | Survey | 8h | arc 23 |  |
| 409 | 6.3.2.4.3 | Insertion N line cable, Braze Y, Visual inspection Y |  | 1d | 2013-08-01 08:00 | 2013-08-01 17:00 | 408, 374 | 99d | 0d | M2; W2; QA | 24h | arc 23 |  |
| 410 | 6.3.2.4.4 | Install PIM and weld PIM |  | 0.5d | 2013-08-02 08:00 | 2013-08-02 12:00 | 409 | 99d | 0d | W1; VSC; M5 | 12h | arc 23 |  |
| 411 | 6.3.2.4.5 | Weld X, E, K, C' sleeves |  | 2d | 2013-08-02 13:00 | 2013-08-06 12:00 | 410, 409 | 99d | 0d | W1; M2 | 32h | arc 23 |  |
| 412 | 6.3.2.4.6 | Leak test X,E, K, C', V and visual inspection |  | 2.5d | 2013-08-06 13:00 | 2013-08-08 17:00 | 411 | 99d | 0d | VSC; QA | 40h | arc 23 |  |
| 413 | 6.3.2.4.7 | Braze busbars, visual inspection, US check of BB, shunt installation |  | 3d | 2013-08-09 08:00 | 2013-08-13 17:00 | 412 | 99d | 34d | Train | 24h | arc 23 |  |
| 414 | 6.3.2.4.8 | Connect spools |  | 1d | 2013-10-02 08:00 | 2013-10-02 17:00 | 413, 384 | 65d | 0d | EM1; EM2 | 16h | arc 23 |  |
| 415 | 6.3.2.4.9 | Visual inspection of spool connections |  | 0.5d | 2013-10-02 13:00 | 2013-10-02 17:00 | 414SS+0.5d | 141d |  | QC | 4h | arc 23 |  |
| 416 | 6.3.2.4.10 | Connection of N line cable |  | 1d | 2013-10-03 08:00 | 2013-10-03 17:00 | 414 | 65d | 0d | EM1; EM2 | 16h | arc 23 |  |
| 417 | 6.3.2.4.11 | Visual inspection of connections |  | 0.5d | 2013-10-03 13:00 | 2013-10-03 17:00 | 416SS+0.5d | 65d | 0d | QC | 4h | arc 23 |  |
| 418 | 6.3.2.4.12 | MPAQ + AIV1 test |  | 1d | 2013-10-04 08:00 | 2013-10-04 17:00 | 416, 417 | 65d | 0d | ELQA | 8h | arc 23 |  |
| 419 | 6.3.2.4.13 | Weld N line wires |  | 2d | 2013-10-07 08:00 | 2013-10-08 17:00 | 418 | 65d | 0d | EM1; EM2 | 32h | arc 23 |  |
| 420 | 6.3.2.4.14 | AIV2 test |  | 1d | 2013-10-09 08:00 | 2013-10-09 17:00 | 419 | 65d | 0d | ELQA | 8h | arc 23 |  |
| 421 | 6.3.2.4.15 | Close N line connection box |  | 2d | 2013-10-10 08:00 | 2013-10-11 17:00 | 420 | 65d | 0d | EM1; EM2 | 32h | arc 23 |  |
| 422 | 6.3.2.4.16 | Weld N (139mm) sleeves |  | 0.5d | 2013-10-14 08:00 | 2013-10-14 12:00 | 421 | 129d | 0d | W1; M5 | 8h | arc 23 |  |
| 423 | 6.3.2.4.17 | Insulate busbars and spools |  | 0.5d | 2013-10-14 13:00 | 2013-10-14 17:00 | 422 | 129d | 0d | Train | 4h | arc 23 |  |
| 424 | 6.3.2.4.18 | Weld M1, M2, M3 and N (71mm) sleeves |  | 0.5d | 2013-10-15 08:00 | 2013-10-15 12:00 | 423 | 129d | 0d | Train | 4h | arc 23 |  |
| 425 | 6.3.2.4.19 | Visual inspection of welds |  | 0.5d | 2013-10-15 13:00 | 2013-10-15 17:00 | 424 | 129d | 0d | QA | 4h | arc 23 |  |
| 426 | 6.3.2.4.20 | Leak test M1, M2, M3 and N line welds |  | 0.5d | 2013-10-16 08:00 | 2013-10-16 12:00 | 425 | 129d | 0d | VSC | 4h | arc 23 |  |
| 427 | 6.3.2.4.21 | Install thermometers wires |  | 0.5d | 2013-10-16 13:00 | 2013-10-16 17:00 | 426 | 129d | 0d | CRG | 4h | arc 23 |  |
| 428 | 6.3.2.4.22 | General inspection before closure |  | 0.5d | 2013-10-17 08:00 | 2013-10-17 12:00 | 427 | 129d | 0d | Train | 4h | arc 23 |  |
| 429 | 6.3.2.4.23 | Install screens and MLI |  | 0.5d | 2013-10-17 13:00 | 2013-10-17 17:00 | 428 | 129d | 0d | Train | 4h | arc 23 |  |
| 430 | 6.3.2.4.24 | Close W bellows |  | 0.5d | 2013-10-18 08:00 | 2013-10-18 12:00 | 429 | 129d | 0d | Train | 4h | arc 23 |  |
| 431 | 6.3.2.4.25 | Leak test Vac sector |  | 0.5d | 2013-10-18 13:00 | 2013-10-18 17:00 | 430 | 129d |  | VSC | 4h | arc 23 |  |

| ID | WBS | Task | Type | Duration | Start | Finish | Predecessors | Total slack | Free slack | Resources | Work | Location | fla2 |
| --- | --- | --- | --- | --- | --- | --- | --- | --- | --- | --- | --- | --- | --- |
| 432 | 6.3.3 | **C15L3** |  | 96d | 2013-06-18 08:00 | 2013-10-30 17:00 |  | 121d |  |  | 548h | arc 23 | TE MSC |
| 433 | 6.3.3.1 | **deconnecting** |  | 33.5d | 2013-06-18 08:00 | 2013-08-02 12:00 |  | 101.5d | 0d |  | 144h | arc 23 | TE MSC |
| 434 | 6.3.3.1.1 | Remove thermometer wires+QC+Open |  | 2d | 2013-06-18 08:00 | 2013-06-19 17:00 | 397 | 127.5d | 0d | QC; CRG; Open close | 48h | arc 23 |  |
| 435 | 6.3.3.1.2 | Cut V1, V2, N line sleeves |  | 1.5d | 2013-06-20 08:00 | 2013-06-21 12:00 | 398, 434 | 127.5d | 0d | M3; M1 | 24h | arc 23 |  |
| 436 | 6.3.3.1.3 | Cut E, K, C', X, Y, N, M1, M2 and M3 |  | 2d | 2013-06-21 08:00 | 2013-06-24 17:00 | 435FS-0.5d, 399 | 127.5d | 7d | M4; M6 | 32h | arc 23 |  |
| 437 | 6.3.3.1.4 | Remove N line insulation+Nline connection box+ Open N line connection box and disconnect wires + remove N line cable |  | 1.5d | 2013-07-31 08:00 | 2013-08-01 12:00 | 436, 404 | 101.5d | 0d | EM4; EM3 | 24h | arc 23 |  |
| 438 | 6.3.3.1.5 | Disconnect spools and de-braze busbar |  | 1d | 2013-08-01 13:00 | 2013-08-02 12:00 | 437, 401 | 101.5d |  | EM3; EM4 | 16h | arc 23 |  |
| 439 | 6.3.3.2 | C15R1 disponible pour transport | milestone | 0d | 2013-08-02 12:00 | 2013-08-02 12:00 | 433 | 183.5d |  | Transport |  | arc 23 | TE MSC |
| 440 | 6.3.3.3 | **IC repairing** |  | 3d | 2013-08-02 13:00 | 2013-08-07 12:00 | 433 | 101.5d | 0d |  | 100h | arc 23 | TE MSC |
| 441 | 6.3.3.3.1 | Stabilization cables of adjacent magnets+ replacement of flanges |  | 3d | 2013-08-02 13:00 | 2013-08-07 12:00 | 404, 437 | 101.5d | 0d | EM3; EM4; W1; M5 | 96h | arc 23 |  |
| 442 | 6.3.3.3.2 | Endoscopic inspection of adiacent PIM |  | 0.5d | 2013-08-07 08:00 | 2013-08-07 12:00 | 441FS-0.5d | 101.5d |  | Welding QC | 4h | arc 23 |  |
| 443 | 6.3.3.4 | **reconnection** |  | 59.5d | 2013-08-07 12:00 | 2013-10-30 17:00 | 440 | 101.5d |  |  | 304h | arc 23 | TE MSC |
| 444 | 6.3.3.4.1 | Install cryodipole | milestone | 0d | 2013-08-07 12:00 | 2013-08-07 12:00 |  | 101.5d | 0d | Transport |  | arc 23 |  |
| 445 | 6.3.3.4.2 | Alignement |  | 1d | 2013-08-07 13:00 | 2013-08-08 12:00 | 444 | 101.5d | 0d | Survey | 8h | arc 23 |  |
| 446 | 6.3.3.4.3 | Insertion N line cable, Braze Y, Visual inspection Y |  | 1d | 2013-08-08 13:00 | 2013-08-09 12:00 | 445, 411 | 101.5d | 0d | M2; W2; QA | 24h | arc 23 |  |
| 447 | 6.3.3.4.4 | Install PIM and weld PIM |  | 0.5d | 2013-08-09 13:00 | 2013-08-09 17:00 | 446 | 101.5d | 0d | W1; VSC; M5 | 12h | arc 23 |  |
| 448 | 6.3.3.4.5 | Weld X, E, K, C' sleeves |  | 2d | 2013-08-12 08:00 | 2013-08-13 17:00 | 447, 446 | 101.5d | 0d | W1; M2 | 32h | arc 23 |  |
| 449 | 6.3.3.4.6 | Leak test X,E, K, C', V and visual inspection |  | 2.5d | 2013-08-14 08:00 | 2013-08-16 12:00 | 448 | 101.5d | 0d | VSC; QA | 40h | arc 23 |  |
| 450 | 6.3.3.4.7 | Braze busbars, visual inspection, US check of BB, shunt installation |  | 3d | 2013-08-16 13:00 | 2013-08-21 12:00 | 449 | 101.5d | 36.5d | Train | 24h | arc 23 |  |
| 451 | 6.3.3.4.8 | Connect spools |  | 1d | 2013-10-14 08:00 | 2013-10-14 17:00 | 450, 421 | 65d | 0d | EM1; EM2 | 16h | arc 23 |  |
| 452 | 6.3.3.4.9 | Visual inspection of spool connections |  | 0.5d | 2013-10-14 13:00 | 2013-10-14 17:00 | 451SS+0.5d | 133d |  | QC | 4h | arc 23 |  |
| 453 | 6.3.3.4.10 | Connection of N line cable |  | 1d | 2013-10-15 08:00 | 2013-10-15 17:00 | 451 | 65d | 0d | EM1; EM2 | 16h | arc 23 |  |
| 454 | 6.3.3.4.11 | Visual inspection of connections |  | 0.5d | 2013-10-15 13:00 | 2013-10-15 17:00 | 453SS+0.5d | 65d | 0d | QC | 4h | arc 23 |  |
| 455 | 6.3.3.4.12 | MPAQ + AIV1 test |  | 1d | 2013-10-16 08:00 | 2013-10-16 17:00 | 453, 454 | 65d | 0d | ELQA | 8h | arc 23 |  |
| 456 | 6.3.3.4.13 | Weld N line wires |  | 2d | 2013-10-17 08:00 | 2013-10-18 17:00 | 455 | 65d | 0d | EM1; EM2 | 32h | arc 23 |  |
| 457 | 6.3.3.4.14 | AIV2 test |  | 1d | 2013-10-21 08:00 | 2013-10-21 17:00 | 456 | 65d | 0d | ELQA | 8h | arc 23 |  |
| 458 | 6.3.3.4.15 | Close N line connection box |  | 2d | 2013-10-22 08:00 | 2013-10-23 17:00 | 457 | 65d | 0d | EM1; EM2 | 32h | arc 23 |  |
| 459 | 6.3.3.4.16 | Weld N (139mm) sleeves |  | 0.5d | 2013-10-24 08:00 | 2013-10-24 12:00 | 458 | 121d | 0d | W1; M5 | 8h | arc 23 |  |
| 460 | 6.3.3.4.17 | Insulate busbars and spools |  | 0.5d | 2013-10-24 13:00 | 2013-10-24 17:00 | 459 | 121d | 0d | Train | 4h | arc 23 |  |
| 461 | 6.3.3.4.18 | Weld M1, M2, M3 and N (71mm) sleeves |  | 0.5d | 2013-10-25 08:00 | 2013-10-25 12:00 | 460 | 121d | 0d | Train | 4h | arc 23 |  |
| 462 | 6.3.3.4.19 | Visual inspection of welds |  | 0.5d | 2013-10-25 13:00 | 2013-10-25 17:00 | 461 | 121d | 0d | QA | 4h | arc 23 |  |
| 463 | 6.3.3.4.20 | Leak test M1, M2, M3 and N line welds |  | 0.5d | 2013-10-28 08:00 | 2013-10-28 12:00 | 462 | 121d | 0d | VSC | 4h | arc 23 |  |
| 464 | 6.3.3.4.21 | Install thermometers wires |  | 0.5d | 2013-10-28 13:00 | 2013-10-28 17:00 | 463 | 121d | 0d | CRG | 4h | arc 23 |  |
| 465 | 6.3.3.4.22 | General inspection before closure |  | 0.5d | 2013-10-29 08:00 | 2013-10-29 12:00 | 464 | 121d | 0d | Train | 4h | arc 23 |  |
| 466 | 6.3.3.4.23 | Install screens and MLI |  | 0.5d | 2013-10-29 13:00 | 2013-10-29 17:00 | 465 | 121d | 0d | Train | 4h | arc 23 |  |
| 467 | 6.3.3.4.24 | Close W bellows |  | 0.5d | 2013-10-30 08:00 | 2013-10-30 12:00 | 466 | 121d | 0d | Train | 4h | arc 23 |  |
| 468 | 6.3.3.4.25 | Leak test Vac sector |  | 0.5d | 2013-10-30 13:00 | 2013-10-30 17:00 | 467 | 121d |  | VSC | 4h | arc 23 |  |

| ID | WBS | Task | Type | Duration | Start | Finish | Predecessors | Total slack | Free slack | Constraint | Resources | Work | Location | fla2 |
| --- | --- | --- | --- | --- | --- | --- | --- | --- | --- | --- | --- | --- | --- | --- |
| 469 | 7 | **Sector 34** |  | 183d | 2013-07-01 08:00 | 2014-03-27 17:00 |  | 25d |  |  |  | 3356h | arc 34 |  |
| 470 | 7.1 | Train |  | 77d | 2013-11-27 08:00 | 2014-03-27 17:00 |  | 25d |  | finish no earlier than 2014-03-27 17:00 | Train | 616h | arc 34 |  |
| 471 | 7.2 | Mounting insulation start | milestone | 0d | 2014-02-10 08:00 | 2014-02-10 08:00 |  | 59d |  | start no earlier than 2014-02-10 08:00 |  |  |  |  |
| 472 | 7.3 | **Aimants** |  | 127d | 2013-07-01 08:00 | 2014-01-08 17:00 |  | 81d |  | start no earlier than 2013-07-01 08:00 |  | 2740h | arc 34 | TE MSC |
| 473 | 7.3.1 | **Q7R3** |  | 95d | 2013-07-01 08:00 | 2013-11-11 17:00 |  | 113d |  |  |  | 548h | arc 34 | TE MSC |
| 474 | 7.3.1.1 | **deconnecting** |  | 30d | 2013-07-01 08:00 | 2013-08-09 17:00 |  | 104d | 0d |  |  | 144h | arc 34 | TE MSC |
| 475 | 7.3.1.1.1 | Remove thermometer wires+QC+Open |  | 2d | 2013-07-01 08:00 | 2013-07-02 17:00 | 434 | 126.5d | 0d |  | QC; CRG; Open close | 48h | arc 34 |  |
| 476 | 7.3.1.1.2 | Cut V1, V2, N line sleeves |  | 1.5d | 2013-07-03 08:00 | 2013-07-04 12:00 | 435, 475 | 126.5d | 0d |  | M3; M1 | 24h | arc 34 |  |
| 477 | 7.3.1.1.3 | Cut E, K, C', X, Y, N, M1, M2 and M3 |  | 2d | 2013-07-04 08:00 | 2013-07-05 17:00 | 476FS-0.5d, 436 | 126.5d | 0d |  | M4; M6 | 32h | arc 34 |  |
| 478 | 7.3.1.1.4 | Remove N line insulation+Nline connection box+ Open N line connection box and disconnect wires + remove N line cable |  | 1.5d | 2013-08-07 13:00 | 2013-08-08 17:00 | 477, 441 | 104d | 0d |  | EM4; EM3 | 24h | arc 34 |  |
| 479 | 7.3.1.1.5 | Disconnect spools and de-braze busbar |  | 1d | 2013-08-09 08:00 | 2013-08-09 17:00 | 478 | 104d | 0d |  | EM3; EM4 | 16h | arc 34 |  |
| 480 | 7.3.1.2 | C15R1 disponible pour transport | milestone | 0d | 2013-08-09 17:00 | 2013-08-09 17:00 | 474 | 178d |  |  | Transport |  | arc 34 | TE MSC |
| 481 | 7.3.1.3 | **IC repairing** |  | 3d | 2013-08-12 08:00 | 2013-08-14 17:00 | 474 | 104d | 0d |  |  | 100h | arc 34 | TE MSC |
| 482 | 7.3.1.3.1 | Stabilization cables of adjacent magnets+ replacement of flanges |  | 3d | 2013-08-12 08:00 | 2013-08-14 17:00 | 479 | 104d | 0d |  | EM3; EM4; W1; M5 | 96h | arc 34 |  |
| 483 | 7.3.1.3.2 | Endoscopic inspection of adiacent PIM |  | 0.5d | 2013-08-14 13:00 | 2013-08-14 17:00 | 482FS-0.5d | 104d |  |  | Welding QC | 4h | arc 34 |  |
| 484 | 7.3.1.4 | **reconnection** |  | 62d | 2013-08-14 17:00 | 2013-11-11 17:00 | 481 | 104d |  |  |  | 304h | arc 34 | TE MSC |
| 485 | 7.3.1.4.1 | Install cryodipole | milestone | 0d | 2013-08-14 17:00 | 2013-08-14 17:00 |  | 104d | 0d |  | Transport |  | arc 34 |  |
| 486 | 7.3.1.4.2 | Alignement |  | 1d | 2013-08-15 08:00 | 2013-08-15 17:00 | 485 | 104d | 0d |  | Survey | 8h | arc 34 |  |
| 487 | 7.3.1.4.3 | Insertion N line cable, Braze Y, Visual inspection Y |  | 1d | 2013-08-16 08:00 | 2013-08-16 17:00 | 486, 448 | 104d | 0d |  | M2; W2; QA | 24h | arc 34 |  |
| 488 | 7.3.1.4.4 | Install PIM and weld PIM |  | 0.5d | 2013-08-19 08:00 | 2013-08-19 12:00 | 487 | 104d | 0d |  | W1; VSC; M5 | 12h | arc 34 |  |
| 489 | 7.3.1.4.5 | Weld X, E, K, C' sleeves |  | 2d | 2013-08-19 13:00 | 2013-08-21 12:00 | 488, 487 | 104d | 0d |  | W1; M2 | 32h | arc 34 |  |
| 490 | 7.3.1.4.6 | Leak test X,E, K, C', V and visual inspection |  | 2.5d | 2013-08-21 13:00 | 2013-08-23 17:00 | 489 | 104d | 0d |  | VSC; QA | 40h | arc 34 |  |
| 491 | 7.3.1.4.7 | Braze busbars, visual inspection, US check of BB, shunt installation |  | 3d | 2013-08-26 08:00 | 2013-08-28 17:00 | 490 | 104d | 39d |  | Train | 24h | arc 34 |  |
| 492 | 7.3.1.4.8 | Connect spools |  | 1d | 2013-10-24 08:00 | 2013-10-24 17:00 | 491, 458 | 65d | 0d |  | EM1; EM2 | 16h | arc 34 |  |
| 493 | 7.3.1.4.9 | Visual inspection of spool connections |  | 0.5d | 2013-10-24 13:00 | 2013-10-24 17:00 | 492SS+0.5d | 125d |  |  | QC | 4h | arc 34 |  |
| 494 | 7.3.1.4.10 | Connection of N line cable |  | 1d | 2013-10-25 08:00 | 2013-10-25 17:00 | 492 | 65d | 0d |  | EM1; EM2 | 16h | arc 34 |  |
| 495 | 7.3.1.4.11 | Visual inspection of connections |  | 0.5d | 2013-10-25 13:00 | 2013-10-25 17:00 | 494SS+0.5d | 65d | 0d |  | QC | 4h | arc 34 |  |
| 496 | 7.3.1.4.12 | MPAQ + AIV1 test |  | 1d | 2013-10-28 08:00 | 2013-10-28 17:00 | 494, 495 | 65d | 0d |  | ELQA | 8h | arc 34 |  |
| 497 | 7.3.1.4.13 | Weld N line wires |  | 2d | 2013-10-29 08:00 | 2013-10-30 17:00 | 496 | 65d | 0d |  | EM1; EM2 | 32h | arc 34 |  |
| 498 | 7.3.1.4.14 | AIV2 test |  | 1d | 2013-10-31 08:00 | 2013-10-31 17:00 | 497 | 65d | 0d |  | ELQA | 8h | arc 34 |  |
| 499 | 7.3.1.4.15 | Close N line connection box |  | 2d | 2013-11-01 08:00 | 2013-11-04 17:00 | 498 | 65d | 0d |  | EM1; EM2 | 32h | arc 34 |  |
| 500 | 7.3.1.4.16 | Weld N (139mm) sleeves |  | 0.5d | 2013-11-05 08:00 | 2013-11-05 12:00 | 499 | 113d | 0d |  | W1; M5 | 8h | arc 34 |  |
| 501 | 7.3.1.4.17 | Insulate busbars and spools |  | 0.5d | 2013-11-05 13:00 | 2013-11-05 17:00 | 500 | 113d | 0d |  | Train | 4h | arc 34 |  |
| 502 | 7.3.1.4.18 | Weld M1, M2, M3 and N (71mm) sleeves |  | 0.5d | 2013-11-06 08:00 | 2013-11-06 12:00 | 501 | 113d | 0d |  | Train | 4h | arc 34 |  |
| 503 | 7.3.1.4.19 | Visual inspection of welds |  | 0.5d | 2013-11-06 13:00 | 2013-11-06 17:00 | 502 | 113d | 0d |  | QA | 4h | arc 34 |  |
| 504 | 7.3.1.4.20 | Leak test M1, M2, M3 and N line welds |  | 0.5d | 2013-11-07 08:00 | 2013-11-07 12:00 | 503 | 113d | 0d |  | VSC | 4h | arc 34 |  |
| 505 | 7.3.1.4.21 | Install thermometers wires |  | 0.5d | 2013-11-07 13:00 | 2013-11-07 17:00 | 504 | 113d | 0d |  | CRG | 4h | arc 34 |  |
| 506 | 7.3.1.4.22 | General inspection before closure |  | 0.5d | 2013-11-08 08:00 | 2013-11-08 12:00 | 505 | 113d | 0d |  | Train | 4h | arc 34 |  |
| 507 | 7.3.1.4.23 | Install screens and MLI |  | 0.5d | 2013-11-08 13:00 | 2013-11-08 17:00 | 506 | 113d | 0d |  | Train | 4h | arc 34 |  |
| 508 | 7.3.1.4.24 | Close W bellows |  | 0.5d | 2013-11-11 08:00 | 2013-11-11 12:00 | 507 | 113d | 0d |  | Train | 4h | arc 34 |  |
| 509 | 7.3.1.4.25 | Leak test Vac sector |  | 0.5d | 2013-11-11 13:00 | 2013-11-11 17:00 | 508 | 113d |  |  | VSC | 4h | arc 34 |  |

| ID | WBS | Task | Type | Duration | Start | Finish | Predecessors | Total slack | Free slack | Resources | Work | Location | fla2 |
| --- | --- | --- | --- | --- | --- | --- | --- | --- | --- | --- | --- | --- | --- |
| 510 | 7.3.2 | **Q23R3** |  | 101d | 2013-07-03 08:00 | 2013-11-21 17:00 |  | 105d |  |  | 548h | arc 34 | TE MSC |
| 511 | 7.3.2.1 | **deconnecting** |  | 33.5d | 2013-07-03 08:00 | 2013-08-19 12:00 |  | 106.5d | 0d |  | 144h | arc 34 | TE MSC |
| 512 | 7.3.2.1.1 | Remove thermometer wires+QC+Open |  | 2d | 2013-07-03 08:00 | 2013-07-04 17:00 | 475 | 132.5d | 0d | QC; CRG; Open close | 48h | arc 34 |  |
| 513 | 7.3.2.1.2 | Cut V1, V2, N line sleeves |  | 1.5d | 2013-07-05 08:00 | 2013-07-08 12:00 | 476, 512 | 132.5d | 0d | M3; M1 | 24h | arc 34 |  |
| 514 | 7.3.2.1.3 | Cut E, K, C', X, Y, N, M1, M2 and M3 |  | 2d | 2013-07-08 08:00 | 2013-07-09 17:00 | 513FS-0.5d, 477 | 132.5d | 0d | M4; M6 | 32h | arc 34 |  |
| 515 | 7.3.2.1.4 | Remove N line insulation+Nline connection box+ Open N line connection box and disconnect wires + remove N line cable |  | 1.5d | 2013-08-15 08:00 | 2013-08-16 12:00 | 514, 482 | 106.5d | 0d | EM4; EM3 | 24h | arc 34 |  |
| 516 | 7.3.2.1.5 | Disconnect spools and de-braze busbar |  | 1d | 2013-08-16 13:00 | 2013-08-19 12:00 | 515 | 106.5d | 0d | EM3; EM4 | 16h | arc 34 |  |
| 517 | 7.3.2.2 | C15R1 disponible pour transport | milestone | 0d | 2013-08-19 12:00 | 2013-08-19 12:00 | 511 | 172.5d |  | Transport |  | arc 34 | TE MSC |
| 518 | 7.3.2.3 | **IC repairing** |  | 3d | 2013-08-19 13:00 | 2013-08-22 12:00 | 511 | 106.5d | 0d |  | 100h | arc 34 | TE MSC |
| 519 | 7.3.2.3.1 | Stabilization cables of adjacent magnets+ replacement of flanges |  | 3d | 2013-08-19 13:00 | 2013-08-22 12:00 | 516 | 106.5d | 0d | EM3; EM4; W1; M5 | 96h | arc 34 |  |
| 520 | 7.3.2.3.2 | Endoscopic inspection of adiacent PIM |  | 0.5d | 2013-08-22 08:00 | 2013-08-22 12:00 | 519FS-0.5d | 106.5d |  | Welding QC | 4h | arc 34 |  |
| 521 | 7.3.2.4 | **reconnection** |  | 64.5d | 2013-08-22 12:00 | 2013-11-21 17:00 | 518 | 105d |  |  | 304h | arc 34 | TE MSC |
| 522 | 7.3.2.4.1 | Install cryodipole | milestone | 0d | 2013-08-22 12:00 | 2013-08-22 12:00 |  | 106.5d | 0d | Transport |  | arc 34 |  |
| 523 | 7.3.2.4.2 | Alignement |  | 1d | 2013-08-22 13:00 | 2013-08-23 12:00 | 522 | 106.5d | 0d | Survey | 8h | arc 34 |  |
| 524 | 7.3.2.4.3 | Insertion N line cable, Braze Y, Visual inspection Y |  | 1d | 2013-08-23 13:00 | 2013-08-26 12:00 | 523, 489 | 106.5d | 0d | M2; W2; QA | 24h | arc 34 |  |
| 525 | 7.3.2.4.4 | Install PIM and weld PIM |  | 0.5d | 2013-08-26 13:00 | 2013-08-26 17:00 | 524 | 106.5d | 0d | W1; VSC; M5 | 12h | arc 34 |  |
| 526 | 7.3.2.4.5 | Weld X, E, K, C' sleeves |  | 2d | 2013-08-27 08:00 | 2013-08-28 17:00 | 525, 524 | 106.5d | 0d | W1; M2 | 32h | arc 34 |  |
| 527 | 7.3.2.4.6 | Leak test X,E, K, C', V and visual inspection |  | 2.5d | 2013-08-29 08:00 | 2013-09-02 12:00 | 526 | 106.5d | 0d | VSC; QA | 40h | arc 34 |  |
| 528 | 7.3.2.4.7 | Braze busbars, visual inspection, US check of BB, shunt installation |  | 3d | 2013-09-02 13:00 | 2013-09-06 12:00 | 527 | 106.5d | 41.5d | Train | 24h | arc 34 |  |
| 529 | 7.3.2.4.8 | Connect spools |  | 1d | 2013-11-05 08:00 | 2013-11-05 17:00 | 528, 499 | 65d | 0d | EM1; EM2 | 16h | arc 34 |  |
| 530 | 7.3.2.4.9 | Visual inspection of spool connections |  | 0.5d | 2013-11-05 13:00 | 2013-11-05 17:00 | 529SS+0.5d | 117d |  | QC | 4h | arc 34 |  |
| 531 | 7.3.2.4.10 | Connection of N line cable |  | 1d | 2013-11-06 08:00 | 2013-11-06 17:00 | 529 | 65d | 0d | EM1; EM2 | 16h | arc 34 |  |
| 532 | 7.3.2.4.11 | Visual inspection of connections |  | 0.5d | 2013-11-06 13:00 | 2013-11-06 17:00 | 531SS+0.5d | 65d | 0d | QC | 4h | arc 34 |  |
| 533 | 7.3.2.4.12 | MPAQ + AIV1 test |  | 1d | 2013-11-07 08:00 | 2013-11-07 17:00 | 531, 532 | 65d | 0d | ELQA | 8h | arc 34 |  |
| 534 | 7.3.2.4.13 | Weld N line wires |  | 2d | 2013-11-08 08:00 | 2013-11-11 17:00 | 533 | 65d | 0d | EM1; EM2 | 32h | arc 34 |  |
| 535 | 7.3.2.4.14 | AIV2 test |  | 1d | 2013-11-12 08:00 | 2013-11-12 17:00 | 534 | 65d | 0d | ELQA | 8h | arc 34 |  |
| 536 | 7.3.2.4.15 | Close N line connection box |  | 2d | 2013-11-13 08:00 | 2013-11-14 17:00 | 535 | 65d | 0d | EM1; EM2 | 32h | arc 34 |  |
| 537 | 7.3.2.4.16 | Weld N (139mm) sleeves |  | 0.5d | 2013-11-15 08:00 | 2013-11-15 12:00 | 536 | 105d | 0d | W1; M5 | 8h | arc 34 |  |
| 538 | 7.3.2.4.17 | Insulate busbars and spools |  | 0.5d | 2013-11-15 13:00 | 2013-11-15 17:00 | 537 | 105d | 0d | Train | 4h | arc 34 |  |
| 539 | 7.3.2.4.18 | Weld M1, M2, M3 and N (71mm) sleeves |  | 0.5d | 2013-11-18 08:00 | 2013-11-18 12:00 | 538 | 105d | 0d | Train | 4h | arc 34 |  |
| 540 | 7.3.2.4.19 | Visual inspection of welds |  | 0.5d | 2013-11-18 13:00 | 2013-11-18 17:00 | 539 | 105d | 0d | QA | 4h | arc 34 |  |
| 541 | 7.3.2.4.20 | Leak test M1, M2, M3 and N line welds |  | 0.5d | 2013-11-19 08:00 | 2013-11-19 12:00 | 540 | 105d | 0d | VSC | 4h | arc 34 |  |
| 542 | 7.3.2.4.21 | Install thermometers wires |  | 0.5d | 2013-11-19 13:00 | 2013-11-19 17:00 | 541 | 105d | 0d | CRG | 4h | arc 34 |  |
| 543 | 7.3.2.4.22 | General inspection before closure |  | 0.5d | 2013-11-20 08:00 | 2013-11-20 12:00 | 542 | 105d | 0d | Train | 4h | arc 34 |  |
| 544 | 7.3.2.4.23 | Install screens and MLI |  | 0.5d | 2013-11-20 13:00 | 2013-11-20 17:00 | 543 | 105d | 0d | Train | 4h | arc 34 |  |
| 545 | 7.3.2.4.24 | Close W bellows |  | 0.5d | 2013-11-21 08:00 | 2013-11-21 12:00 | 544 | 105d | 0d | Train | 4h | arc 34 |  |
| 546 | 7.3.2.4.25 | Leak test Vac sector |  | 0.5d | 2013-11-21 13:00 | 2013-11-21 17:00 | 545 | 105d |  | VSC | 4h | arc 34 |  |

| ID | WBS | Task | Type | Duration | Start | Finish | Predecessors | Total slack | Free slack | Resources | Work | Location | fla2 |
| --- | --- | --- | --- | --- | --- | --- | --- | --- | --- | --- | --- | --- | --- |
| 547 | 7.3.3 | **A26R3** |  | 107d | 2013-07-05 08:00 | 2013-12-03 17:00 |  | 97d |  |  | 548h | arc 34 | TE MSC |
| 548 | 7.3.3.1 | **deconnecting** |  | 37d | 2013-07-05 08:00 | 2013-08-26 17:00 |  | 109d | 0d |  | 144h | arc 34 | TE MSC |
| 549 | 7.3.3.1.1 | Remove thermometer wires+QC+Open |  | 2d | 2013-07-05 08:00 | 2013-07-08 17:00 | 512 | 138.5d | 0d | QC; CRG; Open close | 48h | arc 34 |  |
| 550 | 7.3.3.1.2 | Cut V1, V2, N line sleeves |  | 1.5d | 2013-07-09 08:00 | 2013-07-10 12:00 | 513, 549 | 138.5d | 0d | M3; M1 | 24h | arc 34 |  |
| 551 | 7.3.3.1.3 | Cut E, K, C', X, Y, N, M1, M2 and M3 |  | 2d | 2013-07-10 08:00 | 2013-07-11 17:00 | 550FS-0.5d, 514 | 138.5d | 0d | M4; M6 | 32h | arc 34 |  |
| 552 | 7.3.3.1.4 | Remove N line insulation+Nline connection box+ Open N line connection box and disconnect wires + remove N line cable |  | 1.5d | 2013-08-22 13:00 | 2013-08-23 17:00 | 551, 519 | 109d | 0d | EM4; EM3 | 24h | arc 34 |  |
| 553 | 7.3.3.1.5 | Disconnect spools and de-braze busbar |  | 1d | 2013-08-26 08:00 | 2013-08-26 17:00 | 552 | 109d | 0d | EM3; EM4 | 16h | arc 34 |  |
| 554 | 7.3.3.2 | C15R1 disponible pour transport | milestone | 0d | 2013-08-26 17:00 | 2013-08-26 17:00 | 548 | 167d |  | Transport |  | arc 34 | TE MSC |
| 555 | 7.3.3.3 | **IC repairing** |  | 3d | 2013-08-27 08:00 | 2013-08-29 17:00 | 548 | 109d | 0d |  | 100h | arc 34 | TE MSC |
| 556 | 7.3.3.3.1 | Stabilization cables of adjacent magnets+ replacement of flanges |  | 3d | 2013-08-27 08:00 | 2013-08-29 17:00 | 553 | 109d | 0d | EM3; EM4; W1; M5 | 96h | arc 34 |  |
| 557 | 7.3.3.3.2 | Endoscopic inspection of adiacent PIM |  | 0.5d | 2013-08-29 13:00 | 2013-08-29 17:00 | 556FS-0.5d | 109d |  | Welding QC | 4h | arc 34 |  |
| 558 | 7.3.3.4 | **reconnection** |  | 67d | 2013-08-29 17:00 | 2013-12-03 17:00 | 555 | 97d |  |  | 304h | arc 34 | TE MSC |
| 559 | 7.3.3.4.1 | Install cryodipole | milestone | 0d | 2013-08-29 17:00 | 2013-08-29 17:00 |  | 109d | 0d | Transport |  | arc 34 |  |
| 560 | 7.3.3.4.2 | Alignement |  | 1d | 2013-08-30 08:00 | 2013-08-30 17:00 | 559 | 109d | 0d | Survey | 8h | arc 34 |  |
| 561 | 7.3.3.4.3 | Insertion N line cable, Braze Y, Visual inspection Y |  | 1d | 2013-09-02 08:00 | 2013-09-02 17:00 | 560, 526 | 109d | 0d | M2; W2; QA | 24h | arc 34 |  |
| 562 | 7.3.3.4.4 | Install PIM and weld PIM |  | 0.5d | 2013-09-03 08:00 | 2013-09-03 12:00 | 561 | 109d | 0d | W1; VSC; M5 | 12h | arc 34 |  |
| 563 | 7.3.3.4.5 | Weld X, E, K, C' sleeves |  | 2d | 2013-09-03 13:00 | 2013-09-06 12:00 | 562, 561 | 109d | 0d | W1; M2 | 32h | arc 34 |  |
| 564 | 7.3.3.4.6 | Leak test X,E, K, C', V and visual inspection |  | 2.5d | 2013-09-06 13:00 | 2013-09-10 17:00 | 563 | 109d | 0d | VSC; QA | 40h | arc 34 |  |
| 565 | 7.3.3.4.7 | Braze busbars, visual inspection, US check of BB, shunt installation |  | 3d | 2013-09-11 08:00 | 2013-09-13 17:00 | 564 | 109d | 44d | Train | 24h | arc 34 |  |
| 566 | 7.3.3.4.8 | Connect spools |  | 1d | 2013-11-15 08:00 | 2013-11-15 17:00 | 565, 536 | 65d | 0d | EM1; EM2 | 16h | arc 34 |  |
| 567 | 7.3.3.4.9 | Visual inspection of spool connections |  | 0.5d | 2013-11-15 13:00 | 2013-11-15 17:00 | 566SS+0.5d | 109d |  | QC | 4h | arc 34 |  |
| 568 | 7.3.3.4.10 | Connection of N line cable |  | 1d | 2013-11-18 08:00 | 2013-11-18 17:00 | 566 | 65d | 0d | EM1; EM2 | 16h | arc 34 |  |
| 569 | 7.3.3.4.11 | Visual inspection of connections |  | 0.5d | 2013-11-18 13:00 | 2013-11-18 17:00 | 568SS+0.5d | 65d | 0d | QC | 4h | arc 34 |  |
| 570 | 7.3.3.4.12 | MPAQ + AIV1 test |  | 1d | 2013-11-19 08:00 | 2013-11-19 17:00 | 568, 569 | 65d | 0d | ELQA | 8h | arc 34 |  |
| 571 | 7.3.3.4.13 | Weld N line wires |  | 2d | 2013-11-20 08:00 | 2013-11-21 17:00 | 570 | 65d | 0d | EM1; EM2 | 32h | arc 34 |  |
| 572 | 7.3.3.4.14 | AIV2 test |  | 1d | 2013-11-22 08:00 | 2013-11-22 17:00 | 571 | 65d | 0d | ELQA | 8h | arc 34 |  |
| 573 | 7.3.3.4.15 | Close N line connection box |  | 2d | 2013-11-25 08:00 | 2013-11-26 17:00 | 572 | 65d | 0d | EM1; EM2 | 32h | arc 34 |  |
| 574 | 7.3.3.4.16 | Weld N (139mm) sleeves |  | 0.5d | 2013-11-27 08:00 | 2013-11-27 12:00 | 573 | 97d | 0d | W1; M5 | 8h | arc 34 |  |
| 575 | 7.3.3.4.17 | Insulate busbars and spools |  | 0.5d | 2013-11-27 13:00 | 2013-11-27 17:00 | 574 | 97d | 0d | Train | 4h | arc 34 |  |
| 576 | 7.3.3.4.18 | Weld M1, M2, M3 and N (71mm) sleeves |  | 0.5d | 2013-11-28 08:00 | 2013-11-28 12:00 | 575 | 97d | 0d | Train | 4h | arc 34 |  |
| 577 | 7.3.3.4.19 | Visual inspection of welds |  | 0.5d | 2013-11-28 13:00 | 2013-11-28 17:00 | 576 | 97d | 0d | QA | 4h | arc 34 |  |
| 578 | 7.3.3.4.20 | Leak test M1, M2, M3 and N line welds |  | 0.5d | 2013-11-29 08:00 | 2013-11-29 12:00 | 577 | 97d | 0d | VSC | 4h | arc 34 |  |
| 579 | 7.3.3.4.21 | Install thermometers wires |  | 0.5d | 2013-11-29 13:00 | 2013-11-29 17:00 | 578 | 97d | 0d | CRG | 4h | arc 34 |  |
| 580 | 7.3.3.4.22 | General inspection before closure |  | 0.5d | 2013-12-02 08:00 | 2013-12-02 12:00 | 579 | 97d | 0d | Train | 4h | arc 34 |  |
| 581 | 7.3.3.4.23 | Install screens and MLI |  | 0.5d | 2013-12-02 13:00 | 2013-12-02 17:00 | 580 | 97d | 0d | Train | 4h | arc 34 |  |
| 582 | 7.3.3.4.24 | Close W bellows |  | 0.5d | 2013-12-03 08:00 | 2013-12-03 12:00 | 581 | 97d | 0d | Train | 4h | arc 34 |  |
| 583 | 7.3.3.4.25 | Leak test Vac sector |  | 0.5d | 2013-12-03 13:00 | 2013-12-03 17:00 | 582 | 97d |  | VSC | 4h | arc 34 |  |

| ID | WBS | Task | Type | Duration | Start | Finish | Predecessors | Total slack | Free slack | Resources | Work | Location | fla2 |
| --- | --- | --- | --- | --- | --- | --- | --- | --- | --- | --- | --- | --- | --- |
| 584 | 7.3.4 | **Q27R3** |  | 113d | 2013-07-09 08:00 | 2013-12-13 17:00 |  | 89d |  |  | 548h | arc 34 | TE MSC |
| 585 | 7.3.4.1 | **deconnecting** |  | 40.5d | 2013-07-09 08:00 | 2013-09-03 12:00 |  | 111.5d | 0d |  | 144h | arc 34 | TE MSC |
| 586 | 7.3.4.1.1 | Remove thermometer wires+QC+Open |  | 2d | 2013-07-09 08:00 | 2013-07-10 17:00 | 549 | 144.5d | 0d | QC; CRG; Open close | 48h | arc 34 |  |
| 587 | 7.3.4.1.2 | Cut V1, V2, N line sleeves |  | 1.5d | 2013-07-11 08:00 | 2013-07-12 12:00 | 550, 586 | 144.5d | 0d | M3; M1 | 24h | arc 34 |  |
| 588 | 7.3.4.1.3 | Cut E, K, C', X, Y, N, M1, M2 and M3 |  | 2d | 2013-07-12 08:00 | 2013-07-15 17:00 | 587FS-0.5d, 551 | 144.5d | 0d | M4; M6 | 32h | arc 34 |  |
| 589 | 7.3.4.1.4 | Remove N line insulation+Nline connection box+ Open N line connection box and disconnect wires + remove N line cable |  | 1.5d | 2013-08-30 08:00 | 2013-09-02 12:00 | 588, 556 | 111.5d | 0d | EM4; EM3 | 24h | arc 34 |  |
| 590 | 7.3.4.1.5 | Disconnect spools and de-braze busbar |  | 1d | 2013-09-02 13:00 | 2013-09-03 12:00 | 589 | 111.5d | 0d | EM3; EM4 | 16h | arc 34 |  |
| 591 | 7.3.4.2 | C15R1 disponible pour transport | milestone | 0d | 2013-09-03 12:00 | 2013-09-03 12:00 | 585 | 161.5d |  | Transport |  | arc 34 | TE MSC |
| 592 | 7.3.4.3 | **IC repairing** |  | 3d | 2013-09-03 13:00 | 2013-09-09 12:00 | 585 | 111.5d | 0d |  | 100h | arc 34 | TE MSC |
| 593 | 7.3.4.3.1 | Stabilization cables of adjacent magnets+ replacement of flanges |  | 3d | 2013-09-03 13:00 | 2013-09-09 12:00 | 590 | 111.5d | 0d | EM3; EM4; W1; M5 | 96h | arc 34 |  |
| 594 | 7.3.4.3.2 | Endoscopic inspection of adiacent PIM |  | 0.5d | 2013-09-09 08:00 | 2013-09-09 12:00 | 593FS-0.5d | 111.5d |  | Welding QC | 4h | arc 34 |  |
| 595 | 7.3.4.4 | **reconnection** |  | 69.5d | 2013-09-09 12:00 | 2013-12-13 17:00 | 592 | 89d |  |  | 304h | arc 34 | TE MSC |
| 596 | 7.3.4.4.1 | Install cryodipole | milestone | 0d | 2013-09-09 12:00 | 2013-09-09 12:00 |  | 111.5d | 0d | Transport |  | arc 34 |  |
| 597 | 7.3.4.4.2 | Alignement |  | 1d | 2013-09-09 13:00 | 2013-09-10 12:00 | 596 | 111.5d | 0d | Survey | 8h | arc 34 |  |
| 598 | 7.3.4.4.3 | Insertion N line cable, Braze Y, Visual inspection Y |  | 1d | 2013-09-10 13:00 | 2013-09-11 12:00 | 597, 563 | 111.5d | 0d | M2; W2; QA | 24h | arc 34 |  |
| 599 | 7.3.4.4.4 | Install PIM and weld PIM |  | 0.5d | 2013-09-11 13:00 | 2013-09-11 17:00 | 598 | 111.5d | 0d | W1; VSC; M5 | 12h | arc 34 |  |
| 600 | 7.3.4.4.5 | Weld X, E, K, C' sleeves |  | 2d | 2013-09-12 08:00 | 2013-09-13 17:00 | 599, 598 | 111.5d | 0d | W1; M2 | 32h | arc 34 |  |
| 601 | 7.3.4.4.6 | Leak test X,E, K, C', V and visual inspection |  | 2.5d | 2013-09-16 08:00 | 2013-09-18 12:00 | 600 | 111.5d | 0d | VSC; QA | 40h | arc 34 |  |
| 602 | 7.3.4.4.7 | Braze busbars, visual inspection, US check of BB, shunt installation |  | 3d | 2013-09-18 13:00 | 2013-09-23 12:00 | 601 | 111.5d | 46.5d | Train | 24h | arc 34 |  |
| 603 | 7.3.4.4.8 | Connect spools |  | 1d | 2013-11-27 08:00 | 2013-11-27 17:00 | 602, 573 | 65d | 0d | EM1; EM2 | 16h | arc 34 |  |
| 604 | 7.3.4.4.9 | Visual inspection of spool connections |  | 0.5d | 2013-11-27 13:00 | 2013-11-27 17:00 | 603SS+0.5d | 101d |  | QC | 4h | arc 34 |  |
| 605 | 7.3.4.4.10 | Connection of N line cable |  | 1d | 2013-11-28 08:00 | 2013-11-28 17:00 | 603 | 65d | 0d | EM1; EM2 | 16h | arc 34 |  |
| 606 | 7.3.4.4.11 | Visual inspection of connections |  | 0.5d | 2013-11-28 13:00 | 2013-11-28 17:00 | 605SS+0.5d | 65d | 0d | QC | 4h | arc 34 |  |
| 607 | 7.3.4.4.12 | MPAQ + AIV1 test |  | 1d | 2013-11-29 08:00 | 2013-11-29 17:00 | 605, 606 | 65d | 0d | ELQA | 8h | arc 34 |  |
| 608 | 7.3.4.4.13 | Weld N line wires |  | 2d | 2013-12-02 08:00 | 2013-12-03 17:00 | 607 | 65d | 0d | EM1; EM2 | 32h | arc 34 |  |
| 609 | 7.3.4.4.14 | AIV2 test |  | 1d | 2013-12-04 08:00 | 2013-12-04 17:00 | 608 | 65d | 0d | ELQA | 8h | arc 34 |  |
| 610 | 7.3.4.4.15 | Close N line connection box |  | 2d | 2013-12-05 08:00 | 2013-12-06 17:00 | 609 | 65d | 0d | EM1; EM2 | 32h | arc 34 |  |
| 611 | 7.3.4.4.16 | Weld N (139mm) sleeves |  | 0.5d | 2013-12-09 08:00 | 2013-12-09 12:00 | 610 | 89d | 0d | W1; M5 | 8h | arc 34 |  |
| 612 | 7.3.4.4.17 | Insulate busbars and spools |  | 0.5d | 2013-12-09 13:00 | 2013-12-09 17:00 | 611 | 89d | 0d | Train | 4h | arc 34 |  |
| 613 | 7.3.4.4.18 | Weld M1, M2, M3 and N (71mm) sleeves |  | 0.5d | 2013-12-10 08:00 | 2013-12-10 12:00 | 612 | 89d | 0d | Train | 4h | arc 34 |  |
| 614 | 7.3.4.4.19 | Visual inspection of welds |  | 0.5d | 2013-12-10 13:00 | 2013-12-10 17:00 | 613 | 89d | 0d | QA | 4h | arc 34 |  |
| 615 | 7.3.4.4.20 | Leak test M1, M2, M3 and N line welds |  | 0.5d | 2013-12-11 08:00 | 2013-12-11 12:00 | 614 | 89d | 0d | VSC | 4h | arc 34 |  |
| 616 | 7.3.4.4.21 | Install thermometers wires |  | 0.5d | 2013-12-11 13:00 | 2013-12-11 17:00 | 615 | 89d | 0d | CRG | 4h | arc 34 |  |
| 617 | 7.3.4.4.22 | General inspection before closure |  | 0.5d | 2013-12-12 08:00 | 2013-12-12 12:00 | 616 | 89d | 0d | Train | 4h | arc 34 |  |
| 618 | 7.3.4.4.23 | Install screens and MLI |  | 0.5d | 2013-12-12 13:00 | 2013-12-12 17:00 | 617 | 89d | 0d | Train | 4h | arc 34 |  |
| 619 | 7.3.4.4.24 | Close W bellows |  | 0.5d | 2013-12-13 08:00 | 2013-12-13 12:00 | 618 | 89d | 0d | Train | 4h | arc 34 |  |
| 620 | 7.3.4.4.25 | Leak test Vac sector |  | 0.5d | 2013-12-13 13:00 | 2013-12-13 17:00 | 619 | 89d |  | VSC | 4h | arc 34 |  |

| ID | WBS | Task | Type | Duration | Start | Finish | Predecessors | Total slack | Free slack | Resources | Work | Location | fla2 |
| --- | --- | --- | --- | --- | --- | --- | --- | --- | --- | --- | --- | --- | --- |
| 621 | 7.3.5 | **B32R3** |  | 119d | 2013-07-11 08:00 | 2014-01-08 17:00 |  | 81d |  |  | 548h | arc 34 | TE MSC |
| 622 | 7.3.5.1 | **deconnecting** |  | 44d | 2013-07-11 08:00 | 2013-09-11 17:00 |  | 114d | 0d |  | 144h | arc 34 | TE MSC |
| 623 | 7.3.5.1.1 | Remove thermometer wires+QC+Open |  | 2d | 2013-07-11 08:00 | 2013-07-12 17:00 | 586 | 152d | 0d | QC; CRG; Open close | 48h | arc 34 |  |
| 624 | 7.3.5.1.2 | Cut V1, V2, N line sleeves |  | 1.5d | 2013-07-12 13:00 | 2013-07-15 17:00 | 587, 623SS+0.5d | 151d | 0d | M3; M1 | 24h | arc 34 |  |
| 625 | 7.3.5.1.3 | Cut E, K, C', X, Y, N, M1, M2 and M3 |  | 2d | 2013-07-16 08:00 | 2013-07-17 17:00 | 624FS-0.5d, 588 | 150.5d | 0d | M4; M6 | 32h | arc 34 |  |
| 626 | 7.3.5.1.4 | Remove N line insulation+Nline connection box+ Open N line connection box and disconnect wires + remove N line cable |  | 1.5d | 2013-09-09 13:00 | 2013-09-10 17:00 | 625, 593 | 114d | 0d | EM4; EM3 | 24h | arc 34 |  |
| 627 | 7.3.5.1.5 | Disconnect spools and de-braze busbar |  | 1d | 2013-09-11 08:00 | 2013-09-11 17:00 | 626 | 114d | 0d | EM3; EM4 | 16h | arc 34 |  |
| 628 | 7.3.5.2 | C15R1 disponible pour transport | milestone | 0d | 2013-09-11 17:00 | 2013-09-11 17:00 | 622 | 156d |  | Transport |  | arc 34 | TE MSC |
| 629 | 7.3.5.3 | **IC repairing** |  | 3d | 2013-09-12 08:00 | 2013-09-16 17:00 | 622 | 114d | 0d |  | 100h | arc 34 | TE MSC |
| 630 | 7.3.5.3.1 | Stabilization cables of adjacent magnets+ replacement of flanges |  | 3d | 2013-09-12 08:00 | 2013-09-16 17:00 | 627 | 114d | 0d | EM3; EM4; W1; M5 | 96h | arc 34 |  |
| 631 | 7.3.5.3.2 | Endoscopic inspection of adiacent PIM |  | 0.5d | 2013-09-16 13:00 | 2013-09-16 17:00 | 630FS-0.5d | 114d |  | Welding QC | 4h | arc 34 |  |
| 632 | 7.3.5.4 | **reconnection** |  | 72d | 2013-09-16 17:00 | 2014-01-08 17:00 | 629 | 81d |  |  | 304h | arc 34 | TE MSC |
| 633 | 7.3.5.4.1 | Install cryodipole | milestone | 0d | 2013-09-16 17:00 | 2013-09-16 17:00 |  | 114d | 0d | Transport |  | arc 34 |  |
| 634 | 7.3.5.4.2 | Alignement |  | 1d | 2013-09-17 08:00 | 2013-09-17 17:00 | 633 | 114d | 0d | Survey | 8h | arc 34 |  |
| 635 | 7.3.5.4.3 | Insertion N line cable, Braze Y, Visual inspection Y |  | 1d | 2013-09-18 08:00 | 2013-09-18 17:00 | 634, 600 | 114d | 0d | M2; W2; QA | 24h | arc 34 |  |
| 636 | 7.3.5.4.4 | Install PIM and weld PIM |  | 0.5d | 2013-09-19 08:00 | 2013-09-19 12:00 | 635 | 114d | 0d | W1; VSC; M5 | 12h | arc 34 |  |
| 637 | 7.3.5.4.5 | Weld X, E, K, C' sleeves |  | 2d | 2013-09-19 13:00 | 2013-09-23 12:00 | 636, 635 | 114d | 0d | W1; M2 | 32h | arc 34 |  |
| 638 | 7.3.5.4.6 | Leak test X,E, K, C', V and visual inspection |  | 2.5d | 2013-09-23 13:00 | 2013-09-25 17:00 | 637 | 114d | 0d | VSC; QA | 40h | arc 34 |  |
| 639 | 7.3.5.4.7 | Braze busbars, visual inspection, US check of BB, shunt installation |  | 3d | 2013-09-26 08:00 | 2013-09-30 17:00 | 638 | 114d | 49d | Train | 24h | arc 34 |  |
| 640 | 7.3.5.4.8 | Connect spools |  | 1d | 2013-12-09 08:00 | 2013-12-09 17:00 | 639, 610 | 65d | 0d | EM1; EM2 | 16h | arc 34 |  |
| 641 | 7.3.5.4.9 | Visual inspection of spool connections |  | 0.5d | 2013-12-09 13:00 | 2013-12-09 17:00 | 640SS+0.5d | 93d |  | QC | 4h | arc 34 |  |
| 642 | 7.3.5.4.10 | Connection of N line cable |  | 1d | 2013-12-10 08:00 | 2013-12-10 17:00 | 640 | 65d | 0d | EM1; EM2 | 16h | arc 34 |  |
| 643 | 7.3.5.4.11 | Visual inspection of connections |  | 0.5d | 2013-12-10 13:00 | 2013-12-10 17:00 | 642SS+0.5d | 65d | 0d | QC | 4h | arc 34 |  |
| 644 | 7.3.5.4.12 | MPAQ + AIV1 test |  | 1d | 2013-12-11 08:00 | 2013-12-11 17:00 | 642, 643 | 65d | 0d | ELQA | 8h | arc 34 |  |
| 645 | 7.3.5.4.13 | Weld N line wires |  | 2d | 2013-12-12 08:00 | 2013-12-13 17:00 | 644 | 65d | 0d | EM1; EM2 | 32h | arc 34 |  |
| 646 | 7.3.5.4.14 | AIV2 test |  | 1d | 2013-12-16 08:00 | 2013-12-16 17:00 | 645 | 65d | 0d | ELQA | 8h | arc 34 |  |
| 647 | 7.3.5.4.15 | Close N line connection box |  | 2d | 2013-12-17 08:00 | 2013-12-18 17:00 | 646 | 65d | 0d | EM1; EM2 | 32h | arc 34 |  |
| 648 | 7.3.5.4.16 | Weld N (139mm) sleeves |  | 0.5d | 2013-12-19 08:00 | 2013-12-19 12:00 | 647 | 81d | 0d | W1; M5 | 8h | arc 34 |  |
| 649 | 7.3.5.4.17 | Insulate busbars and spools |  | 0.5d | 2013-12-19 13:00 | 2013-12-19 17:00 | 648 | 81d | 0d | Train | 4h | arc 34 |  |
| 650 | 7.3.5.4.18 | Weld M1, M2, M3 and N (71mm) sleeves |  | 0.5d | 2013-12-20 08:00 | 2013-12-20 12:00 | 649 | 81d | 0d | Train | 4h | arc 34 |  |
| 651 | 7.3.5.4.19 | Visual inspection of welds |  | 0.5d | 2013-12-20 13:00 | 2013-12-20 17:00 | 650 | 81d | 0d | QA | 4h | arc 34 |  |
| 652 | 7.3.5.4.20 | Leak test M1, M2, M3 and N line welds |  | 0.5d | 2014-01-06 08:00 | 2014-01-06 12:00 | 651 | 81d | 0d | VSC | 4h | arc 34 |  |
| 653 | 7.3.5.4.21 | Install thermometers wires |  | 0.5d | 2014-01-06 13:00 | 2014-01-06 17:00 | 652 | 81d | 0d | CRG | 4h | arc 34 |  |
| 654 | 7.3.5.4.22 | General inspection before closure |  | 0.5d | 2014-01-07 08:00 | 2014-01-07 12:00 | 653 | 81d | 0d | Train | 4h | arc 34 |  |
| 655 | 7.3.5.4.23 | Install screens and MLI |  | 0.5d | 2014-01-07 13:00 | 2014-01-07 17:00 | 654 | 81d | 0d | Train | 4h | arc 34 |  |
| 656 | 7.3.5.4.24 | Close W bellows |  | 0.5d | 2014-01-08 08:00 | 2014-01-08 12:00 | 655 | 81d | 0d | Train | 4h | arc 34 |  |
| 657 | 7.3.5.4.25 | Leak test Vac sector |  | 0.5d | 2014-01-08 13:00 | 2014-01-08 17:00 | 656 | 81d |  | VSC | 4h | arc 34 |  |

| ID | WBS | Task | Type | Duration | Start | Finish | Predecessors | Total slack | Free slack | Constraint | Resources | Work | Location | fla2 |
| --- | --- | --- | --- | --- | --- | --- | --- | --- | --- | --- | --- | --- | --- | --- |
| 658 | 8 | **Sector 45** |  | 198d | 2013-07-15 08:00 | 2014-05-06 17:00 |  | 0d |  |  |  | 1712h | arc 45 |  |
| 659 | 8.1 | Train |  | 77d | 2014-01-15 08:00 | 2014-05-06 17:00 |  | 0d |  | finish no earlier than 2014-05-06 17:00 | Train | 616h | arc 45 |  |
| 660 | 8.2 | Mounting insulation start | milestone | 0d | 2014-03-17 08:00 | 2014-03-17 08:00 |  | 34d |  | start no earlier than 2014-03-17 08:00 |  |  |  |  |
| 661 | 8.3 | **Aimants** |  | 133d | 2013-07-15 08:00 | 2014-01-30 17:00 |  | 65d |  | start no earlier than 2013-04-25 08:00 |  | 1096h | arc 45 |  |
| 662 | 8.3.1 | **C17R4** |  | 125d | 2013-07-15 08:00 | 2014-01-20 17:00 |  | 73d |  |  |  | 548h | arc 45 | TE MSC |
| 663 | 8.3.1.1 | **deconnecting** |  | 47.5d | 2013-07-15 08:00 | 2013-09-19 12:00 |  | 116.5d | 0d |  |  | 144h | arc 45 | TE MSC |
| 664 | 8.3.1.1.1 | Remove thermometer wires+QC+Open |  | 2d | 2013-07-15 08:00 | 2013-07-16 17:00 | 623 | 158d | 0d |  | QC; CRG; Open close | 48h | arc 45 |  |
| 665 | 8.3.1.1.2 | Cut V1, V2, N line sleeves |  | 1.5d | 2013-07-16 08:00 | 2013-07-17 12:00 | 624, 664SS+0.5d | 157.5d | 0d |  | M3; M1 | 24h | arc 45 |  |
| 666 | 8.3.1.1.3 | Cut E, K, C', X, Y, N, M1, M2 and M3 |  | 2d | 2013-07-18 08:00 | 2013-07-19 17:00 | 665FS-0.5d, 625 | 156.5d | 0d |  | M4; M6 | 32h | arc 45 |  |
| 667 | 8.3.1.1.4 | Remove N line insulation+Nline connection box+ Open N line connection box and disconnect wires + remove N line cable |  | 1.5d | 2013-09-17 08:00 | 2013-09-18 12:00 | 666, 630 | 116.5d | 0d |  | EM4; EM3 | 24h | arc 45 |  |
| 668 | 8.3.1.1.5 | Disconnect spools and de-braze busbar |  | 1d | 2013-09-18 13:00 | 2013-09-19 12:00 | 667 | 116.5d | 0d |  | EM3; EM4 | 16h | arc 45 |  |
| 669 | 8.3.1.2 | C15R1 disponible pour transport | milestone | 0d | 2013-09-19 12:00 | 2013-09-19 12:00 | 663 | 150.5d |  |  | Transport |  | arc 45 | TE MSC |
| 670 | 8.3.1.3 | **IC repairing** |  | 3d | 2013-09-19 13:00 | 2013-09-24 12:00 | 663 | 116.5d | 0d |  |  | 100h | arc 45 | TE MSC |
| 671 | 8.3.1.3.1 | Stabilization cables of adjacent magnets+ replacement of flanges |  | 3d | 2013-09-19 13:00 | 2013-09-24 12:00 | 668 | 116.5d | 0d |  | EM3; EM4; W1; M5 | 96h | arc 45 |  |
| 672 | 8.3.1.3.2 | Endoscopic inspection of adiacent PIM |  | 0.5d | 2013-09-24 08:00 | 2013-09-24 12:00 | 671FS-0.5d | 116.5d |  |  | Welding QC | 4h | arc 45 |  |
| 673 | 8.3.1.4 | **reconnection** |  | 74.5d | 2013-09-24 12:00 | 2014-01-20 17:00 | 670 | 73d |  |  |  | 304h | arc 45 | TE MSC |
| 674 | 8.3.1.4.1 | Install cryodipole | milestone | 0d | 2013-09-24 12:00 | 2013-09-24 12:00 |  | 116.5d | 0d |  | Transport |  | arc 45 |  |
| 675 | 8.3.1.4.2 | Alignement |  | 1d | 2013-09-24 13:00 | 2013-09-25 12:00 | 674 | 116.5d | 0d |  | Survey | 8h | arc 45 |  |
| 676 | 8.3.1.4.3 | Insertion N line cable, Braze Y, Visual inspection Y |  | 1d | 2013-09-25 13:00 | 2013-09-26 12:00 | 675, 637 | 116.5d | 0d |  | M2; W2; QA | 24h | arc 45 |  |
| 677 | 8.3.1.4.4 | Install PIM and weld PIM |  | 0.5d | 2013-09-26 13:00 | 2013-09-26 17:00 | 676 | 116.5d | 0d |  | W1; VSC; M5 | 12h | arc 45 |  |
| 678 | 8.3.1.4.5 | Weld X, E, K, C' sleeves |  | 2d | 2013-09-27 08:00 | 2013-09-30 17:00 | 677, 676 | 116.5d | 0d |  | W1; M2 | 32h | arc 45 |  |
| 679 | 8.3.1.4.6 | Leak test X,E, K, C', V and visual inspection |  | 2.5d | 2013-10-01 08:00 | 2013-10-03 12:00 | 678 | 116.5d | 0d |  | VSC; QA | 40h | arc 45 |  |
| 680 | 8.3.1.4.7 | Braze busbars, visual inspection, US check of BB, shunt installation |  | 3d | 2013-10-03 13:00 | 2013-10-08 12:00 | 679 | 116.5d | 51.5d |  | Train | 24h | arc 45 |  |
| 681 | 8.3.1.4.8 | Connect spools |  | 1d | 2013-12-19 08:00 | 2013-12-19 17:00 | 680, 647 | 65d | 0d |  | EM1; EM2 | 16h | arc 45 |  |
| 682 | 8.3.1.4.9 | Visual inspection of spool connections |  | 0.5d | 2013-12-19 13:00 | 2013-12-19 17:00 | 681SS+0.5d | 85d |  |  | QC | 4h | arc 45 |  |
| 683 | 8.3.1.4.10 | Connection of N line cable |  | 1d | 2013-12-20 08:00 | 2013-12-20 17:00 | 681 | 65d | 0d |  | EM1; EM2 | 16h | arc 45 |  |
| 684 | 8.3.1.4.11 | Visual inspection of connections |  | 0.5d | 2013-12-20 13:00 | 2013-12-20 17:00 | 683SS+0.5d | 65d | 0d |  | QC | 4h | arc 45 |  |
| 685 | 8.3.1.4.12 | MPAQ + AIV1 test |  | 1d | 2014-01-06 08:00 | 2014-01-06 17:00 | 683, 684 | 65d | 0d |  | ELQA | 8h | arc 45 |  |
| 686 | 8.3.1.4.13 | Weld N line wires |  | 2d | 2014-01-07 08:00 | 2014-01-08 17:00 | 685 | 65d | 0d |  | EM1; EM2 | 32h | arc 45 |  |
| 687 | 8.3.1.4.14 | AIV2 test |  | 1d | 2014-01-09 08:00 | 2014-01-09 17:00 | 686 | 65d | 0d |  | ELQA | 8h | arc 45 |  |
| 688 | 8.3.1.4.15 | Close N line connection box |  | 2d | 2014-01-10 08:00 | 2014-01-13 17:00 | 687 | 65d | 0d |  | EM1; EM2 | 32h | arc 45 |  |
| 689 | 8.3.1.4.16 | Weld N (139mm) sleeves |  | 0.5d | 2014-01-14 08:00 | 2014-01-14 12:00 | 688 | 73d | 0d |  | W1; M5 | 8h | arc 45 |  |
| 690 | 8.3.1.4.17 | Insulate busbars and spools |  | 0.5d | 2014-01-14 13:00 | 2014-01-14 17:00 | 689 | 73d | 0d |  | Train | 4h | arc 45 |  |
| 691 | 8.3.1.4.18 | Weld M1, M2, M3 and N (71mm) sleeves |  | 0.5d | 2014-01-15 08:00 | 2014-01-15 12:00 | 690 | 73d | 0d |  | Train | 4h | arc 45 |  |
| 692 | 8.3.1.4.19 | Visual inspection of welds |  | 0.5d | 2014-01-15 13:00 | 2014-01-15 17:00 | 691 | 73d | 0d |  | QA | 4h | arc 45 |  |
| 693 | 8.3.1.4.20 | Leak test M1, M2, M3 and N line welds |  | 0.5d | 2014-01-16 08:00 | 2014-01-16 12:00 | 692 | 73d | 0d |  | VSC | 4h | arc 45 |  |
| 694 | 8.3.1.4.21 | Install thermometers wires |  | 0.5d | 2014-01-16 13:00 | 2014-01-16 17:00 | 693 | 73d | 0d |  | CRG | 4h | arc 45 |  |
| 695 | 8.3.1.4.22 | General inspection before closure |  | 0.5d | 2014-01-17 08:00 | 2014-01-17 12:00 | 694 | 73d | 0d |  | Train | 4h | arc 45 |  |
| 696 | 8.3.1.4.23 | Install screens and MLI |  | 0.5d | 2014-01-17 13:00 | 2014-01-17 17:00 | 695 | 73d | 0d |  | Train | 4h | arc 45 |  |
| 697 | 8.3.1.4.24 | Close W bellows |  | 0.5d | 2014-01-20 08:00 | 2014-01-20 12:00 | 696 | 73d | 0d |  | Train | 4h | arc 45 |  |
| 698 | 8.3.1.4.25 | Leak test Vac sector |  | 0.5d | 2014-01-20 13:00 | 2014-01-20 17:00 | 697 | 73d |  |  | VSC | 4h | arc 45 |  |

Notes:
- 661: According to skeleton

| ID | WBS | Task | Type | Duration | Start | Finish | Predecessors | Total slack | Free slack | Resources | Work | Location | fla2 |
| --- | --- | --- | --- | --- | --- | --- | --- | --- | --- | --- | --- | --- | --- |
| 699 | 8.3.2 | **B31R4** |  | 131d | 2013-07-17 08:00 | 2014-01-30 17:00 |  | 65d |  |  | 548h | arc 45 | TE MSC |
| 700 | 8.3.2.1 | **deconnecting** |  | 51d | 2013-07-17 08:00 | 2013-09-26 17:00 |  | 119d | 0d |  | 144h | arc 45 | TE MSC |
| 701 | 8.3.2.1.1 | Remove thermometer wires+QC+Open |  | 2d | 2013-07-17 08:00 | 2013-07-18 17:00 | 664 | 164d | 0d | QC; CRG; Open close | 48h | arc 45 |  |
| 702 | 8.3.2.1.2 | Cut V1, V2, N line sleeves |  | 1.5d | 2013-07-17 13:00 | 2013-07-18 17:00 | 665, 701SS+0.5d | 164d | 1.5d | M3; M1 | 24h | arc 45 |  |
| 703 | 8.3.2.1.3 | Cut E, K, C', X, Y, N, M1, M2 and M3 |  | 2d | 2013-07-22 08:00 | 2013-07-23 17:00 | 702FS-0.5d, 666 | 162.5d | 43.5d | M4; M6 | 32h | arc 45 |  |
| 704 | 8.3.2.1.4 | Remove N line insulation+Nline connection box+ Open N line connection box and disconnect wires + remove N line cable |  | 1.5d | 2013-09-24 13:00 | 2013-09-25 17:00 | 703, 671 | 119d | 0d | EM4; EM3 | 24h | arc 45 |  |
| 705 | 8.3.2.1.5 | Disconnect spools and de-braze busbar |  | 1d | 2013-09-26 08:00 | 2013-09-26 17:00 | 704 | 119d | 0d | EM3; EM4 | 16h | arc 45 |  |
| 706 | 8.3.2.2 | C15R1 disponible pour transport | milestone | 0d | 2013-09-26 17:00 | 2013-09-26 17:00 | 700 | 145d |  | Transport |  | arc 45 | TE MSC |
| 707 | 8.3.2.3 | **IC repairing** |  | 3d | 2013-09-27 08:00 | 2013-10-01 17:00 | 700 | 119d | 0d |  | 100h | arc 45 | TE MSC |
| 708 | 8.3.2.3.1 | Stabilization cables of adjacent magnets+ replacement of flanges |  | 3d | 2013-09-27 08:00 | 2013-10-01 17:00 | 705 | 119d | 0d | EM3; EM4; W1; M5 | 96h | arc 45 |  |
| 709 | 8.3.2.3.2 | Endoscopic inspection of adiacent PIM |  | 0.5d | 2013-10-01 13:00 | 2013-10-01 17:00 | 708FS-0.5d | 119d |  | Welding QC | 4h | arc 45 |  |
| 710 | 8.3.2.4 | **reconnection** |  | 77d | 2013-10-01 17:00 | 2014-01-30 17:00 | 707 | 65d |  |  | 304h | arc 45 | TE MSC |
| 711 | 8.3.2.4.1 | Install cryodipole | milestone | 0d | 2013-10-01 17:00 | 2013-10-01 17:00 |  | 119d | 0d | Transport |  | arc 45 |  |
| 712 | 8.3.2.4.2 | Alignement |  | 1d | 2013-10-02 08:00 | 2013-10-02 17:00 | 711 | 119d | 0d | Survey | 8h | arc 45 |  |
| 713 | 8.3.2.4.3 | Insertion N line cable, Braze Y, Visual inspection Y |  | 1d | 2013-10-03 08:00 | 2013-10-03 17:00 | 712, 678 | 119d | 0d | M2; W2; QA | 24h | arc 45 |  |
| 714 | 8.3.2.4.4 | Install PIM and weld PIM |  | 0.5d | 2013-10-04 08:00 | 2013-10-04 12:00 | 713 | 119d | 0d | W1; VSC; M5 | 12h | arc 45 |  |
| 715 | 8.3.2.4.5 | Weld X, E, K, C' sleeves |  | 2d | 2013-10-04 13:00 | 2013-10-08 12:00 | 714, 713 | 119d | 0d | W1; M2 | 32h | arc 45 |  |
| 716 | 8.3.2.4.6 | Leak test X,E, K, C', V and visual inspection |  | 2.5d | 2013-10-08 13:00 | 2013-10-10 17:00 | 715 | 119d | 0d | VSC; QA | 40h | arc 45 |  |
| 717 | 8.3.2.4.7 | Braze busbars, visual inspection, US check of BB, shunt installation |  | 3d | 2013-10-11 08:00 | 2013-10-15 17:00 | 716 | 119d | 54d | Train | 24h | arc 45 |  |
| 718 | 8.3.2.4.8 | Connect spools |  | 1d | 2014-01-14 08:00 | 2014-01-14 17:00 | 717, 688 | 65d | 0d | EM1; EM2 | 16h | arc 45 |  |
| 719 | 8.3.2.4.9 | Visual inspection of spool connections |  | 0.5d | 2014-01-14 13:00 | 2014-01-14 17:00 | 718SS+0.5d | 77d |  | QC | 4h | arc 45 |  |
| 720 | 8.3.2.4.10 | Connection of N line cable |  | 1d | 2014-01-15 08:00 | 2014-01-15 17:00 | 718 | 65d | 0d | EM1; EM2 | 16h | arc 45 |  |
| 721 | 8.3.2.4.11 | Visual inspection of connections |  | 0.5d | 2014-01-15 13:00 | 2014-01-15 17:00 | 720SS+0.5d | 65d | 0d | QC | 4h | arc 45 |  |
| 722 | 8.3.2.4.12 | MPAQ + AIV1 test |  | 1d | 2014-01-16 08:00 | 2014-01-16 17:00 | 720, 721 | 65d | 0d | ELQA | 8h | arc 45 |  |
| 723 | 8.3.2.4.13 | Weld N line wires |  | 2d | 2014-01-17 08:00 | 2014-01-20 17:00 | 722 | 65d | 0d | EM1; EM2 | 32h | arc 45 |  |
| 724 | 8.3.2.4.14 | AIV2 test |  | 1d | 2014-01-21 08:00 | 2014-01-21 17:00 | 723 | 65d | 0d | ELQA | 8h | arc 45 |  |
| 725 | 8.3.2.4.15 | Close N line connection box |  | 2d | 2014-01-22 08:00 | 2014-01-23 17:00 | 724 | 65d | 0d | EM1; EM2 | 32h | arc 45 |  |
| 726 | 8.3.2.4.16 | Weld N (139mm) sleeves |  | 0.5d | 2014-01-24 08:00 | 2014-01-24 12:00 | 725 | 65d | 0d | W1; M5 | 8h | arc 45 |  |
| 727 | 8.3.2.4.17 | Insulate busbars and spools |  | 0.5d | 2014-01-24 13:00 | 2014-01-24 17:00 | 726 | 65d | 0d | Train | 4h | arc 45 |  |
| 728 | 8.3.2.4.18 | Weld M1, M2, M3 and N (71mm) sleeves |  | 0.5d | 2014-01-27 08:00 | 2014-01-27 12:00 | 727 | 65d | 0d | Train | 4h | arc 45 |  |
| 729 | 8.3.2.4.19 | Visual inspection of welds |  | 0.5d | 2014-01-27 13:00 | 2014-01-27 17:00 | 728 | 65d | 0d | QA | 4h | arc 45 |  |
| 730 | 8.3.2.4.20 | Leak test M1, M2, M3 and N line welds |  | 0.5d | 2014-01-28 08:00 | 2014-01-28 12:00 | 729 | 65d | 0d | VSC | 4h | arc 45 |  |
| 731 | 8.3.2.4.21 | Install thermometers wires |  | 0.5d | 2014-01-28 13:00 | 2014-01-28 17:00 | 730 | 65d | 0d | CRG | 4h | arc 45 |  |
| 732 | 8.3.2.4.22 | General inspection before closure |  | 0.5d | 2014-01-29 08:00 | 2014-01-29 12:00 | 731 | 65d | 0d | Train | 4h | arc 45 |  |
| 733 | 8.3.2.4.23 | Install screens and MLI |  | 0.5d | 2014-01-29 13:00 | 2014-01-29 17:00 | 732 | 65d | 0d | Train | 4h | arc 45 |  |
| 734 | 8.3.2.4.24 | Close W bellows |  | 0.5d | 2014-01-30 08:00 | 2014-01-30 12:00 | 733 | 65d | 0d | Train | 4h | arc 45 |  |
| 735 | 8.3.2.4.25 | Leak test Vac sector |  | 0.5d | 2014-01-30 13:00 | 2014-01-30 17:00 | 734 | 65d |  | VSC | 4h | arc 45 |  |
